# NGAO Design v7

Schedule from MS Project, 2005-10-03 to 2010-03-22, costs in $.
CARA

## Calendars

- Standard: Mon-Fri 08:00-12:00, 13:00-17:00; Sat-Sun off.

## Resources

| Resource | Group | Rate |
| --- | --- | --- |
| Dekany | COO |  |
| Gavel | UCO | 75 |
| Max | UCO |  |
| Wizinowich | WMKO | 75 |
| Other |  | 75 |
| Adkins | KO | 75 |
| McGrath | UCO | 75 |
| Tyau | WMKO | 75 |
| Le Mignant | WMKO | 75 |
| Bell | KO | 75 |
| Chin | WMKO | 75 |
| Kupke | UCO | 75 |
| Lockwood | UCO | 75 |
| Neyman | WMKO | 75 |
| Reinig | UCO | 75 |
| Velur | COO | 75 |
| Free | WMKO |  |
| Student |  | 75 |
| Johansson | WMKO | 75 |
| Wetherell | WMKO | 75 |
| Medeiros | WMKO | 75 |
| Nance | WMKO | 75 |
| Summers | WMKO | 75 |
| Mogensen | WMKO | 75 |
| Bouchez | KO | 75 |
| Kissner | WMKO | 75 |
| Chock | WMKO | 75 |
| Panteleev | WMKO | 75 |
| Morrison | WMKO | 75 |
| Macintosh | UCO | 75 |
| Electrical Engineer / Programmer | UCO | 75 |
| Zolkower | COO | 75 |
| Britton | COO | 75 |
| Hale | COO | 75 |
| Grace |  | 75 |
| Doyle | WMKO | 75 |
| Contract Administrator | WMKO | 75 |
| Brown | COO | 75 |

## Schedule

| ID | WBS | Task | Duration | Start | Finish | Total slack | Constraint | Resources | Work | Cost |
| --- | --- | --- | --- | --- | --- | --- | --- | --- | --- | --- |
| 1 | 1 | **NGAO Design** | 1166d? | 2005-10-03 | 2010-03-22 | 0d |  |  | 36275h | 2,603,399.97 |
| 2 | 1.1 | Proposal | 195d? | 2005-10-03 | 2006-06-30 | 971d | finish no earlier than 2006-06-30 |  |  |  |
| 3 | 1.2 | System Design | 413d? | 2006-10-02 | 2008-04-30 | 493d | finish no earlier than 2008-04-30 |  |  |  |
| 4 | 1.3 | **Preliminary Design** | 494d? | 2008-04-30 | 2010-03-22 | 0d |  |  | 36275h | 2,603,399.97 |
| 5 | 1.3.1 | Reserved | 1d? | 2008-05-01 | 2008-05-01 | 492d | start no earlier than 2008-05-01 |  |  |  |
| 6 | 1.3.2 | **PD Phase Management** | 494d? | 2008-04-30 | 2010-03-22 | 0d |  |  | 9306h | 648,300 |
| 7 | 1.3.2.1 | **Planning** | 456d? | 2008-05-02 | 2010-01-29 | 36d |  |  | 1640h | 120,450 |
| 8 | 1.3.2.1.1 | **Replans (PD phase)** | 286d? | 2008-05-02 | 2009-06-05 | 206d |  |  | 190h | 14,250 |
| 9 | 1.3.2.1.1.1 | Replan based on SDR | 6d? | 2008-05-02 | 2008-05-09 | 486d | start no earlier than 2008-05-02 | Dekany [12.5%]; Gavel [12.5%]; Wizinowich [37.5%] | 30h | 2,250 |
| 10 | 1.3.2.1.1.2 | Replan 1 | 10d? | 2008-10-27 | 2008-11-07 | 356d | finish no earlier than 2008-11-07 | Dekany [20%]; Gavel [20%]; Wizinowich [45%]; Lockwood [1.2%]; Velur [3.8%]; Neyman [1.2%]; Le Mignant [1.2%]; Johansson [2.5%]; Reinig [2.5%]; Bell [1.2%]; Wetherell [1.2%] | 80h | 6,000 |
| 11 | 1.3.2.1.1.3 | Replan 2 | 10d? | 2009-05-25 | 2009-06-05 | 206d | finish no earlier than 2009-06-05 | Dekany [20%]; Gavel [20%]; Wizinowich [40%]; Wetherell [2.5%]; Bell [1.2%]; Reinig [3.8%]; Johansson [2.5%]; Le Mignant [2.5%]; Neyman [1.2%]; Velur [5%]; Lockwood [1.2%] | 80h | 6,000 |
| 12 | 1.3.2.1.2 | **WMKO FY Plans** | 280d? | 2008-05-05 | 2009-05-29 | 211d |  |  | 40h | 3,000 |
| 13 | 1.3.2.1.2.1 | Support WMKO FY09 Planning | 20d? | 2008-05-05 | 2008-05-30 | 471d | start no earlier than 2008-05-05 | Wizinowich [6.2%] | 10h | 750 |
| 14 | 1.3.2.1.2.2 | Support WMKO FY10 Planning | 85d? | 2009-02-02 | 2009-05-29 | 211d | start no earlier than 2009-02-02 | Wizinowich [4.4%] | 30h | 2,250 |
| 15 | 1.3.2.1.3 | **Systems Engineering Management Plan** | 218d? | 2009-04-01 | 2010-01-29 | 36d |  |  | 1410h | 103,200 |
| 16 | 1.3.2.1.3.1 | **Project Plan** | 50d? | 2009-11-02 | 2010-01-08 | 51d |  |  | 1010h | 74,250 |
| 17 | 1.3.2.1.3.1.1 | PBS, WBS & Task Definition | 15d? | 2009-11-02 | 2009-11-20 | 86d | start no earlier than 2009-11-02 | Dekany [33.3%]; Gavel [33.3%]; Wizinowich [33.3%]; Max [8.3%]; Reinig [12.5%]; Wetherell [8.3%]; Johansson [12.5%]; Le Mignant [12.5%]; Neyman [8.3%]; Bell [8.3%]; Velur [33.3%]; Lockwood [12.5%] | 260h | 18,750 |
| 18 | 1.3.2.1.3.1.2 | Cost Estimation | 20d? | 2009-11-23 | 2009-12-18 | 66d | start no earlier than 2009-11-23 | Dekany [37.5%]; Gavel [25%]; Max [6.2%]; Wizinowich [37.5%]; Nance [12.5%]; Neyman [18.8%]; Le Mignant [18.8%]; Bell [12.5%]; Johansson [25%]; Wetherell [9.4%]; Reinig [12.5%]; Kupke [9.4%]; Lockwood [12.5%]; Velur [9.4%]; Brown [25%]; Britton [9.4%]; Hale [9.4%]; Zolkower [9.4%] | 480h | 35,250 |
| 19 | 1.3.2.1.3.1.3 | Full Schedule (MS Project Plan) | 25d? | 2009-12-07 | 2010-01-08 | 51d | start no earlier than 2009-12-07 | Wizinowich [30%]; Dekany [15%]; Gavel [15%]; Velur [20%]; Bell [5%]; Neyman [7.5%]; Le Mignant [10%]; Johansson [10%]; Wetherell [5%]; Lockwood [7.5%]; Reinig [10%] | 270h | 20,250 |
| 20 | 1.3.2.1.3.2 | **Detailed Design Phase Plan** | 177d? | 2009-04-01 | 2009-12-03 | 77d |  |  | 320h | 23,250 |
| 21 | 1.3.2.1.3.2.1 | Detailed Design Plan v1 (FY10 planning) | 33d? | 2009-04-01 | 2009-05-15 | 221d | finish no earlier than 2009-05-15 | Wizinowich [15.2%] | 40h | 3,000 |
| 22 | 1.3.2.1.3.2.2 | Detailed Design Plan v2 (TSIP proposal) | 18d? | 2009-07-15 | 2009-08-07 | 161d | start no earlier than 2009-07-15 | Wizinowich [22.2%]; Dekany [27.8%]; Gavel [27.8%] | 40h | 3,000 |
| 23 | 1.3.2.1.3.2.3 | Detailed Design Plan Final Version | 19d? | 2009-11-09 | 2009-12-03 | 77d | start no earlier than 2009-11-09 | Wizinowich [46.1%]; Dekany [19.7%]; Gavel [19.7%]; Max [6.6%]; Lockwood [65.8%]; Nance; Bell; Neyman; Le Mignant; Johansson; Reinig; Velur | 240h | 17,250 |
| 24 | 1.3.2.1.3.3 | SEMP Document | 15d? | 2010-01-11 | 2010-01-29 | 36d | start no earlier than 2010-01-11 | Wizinowich [30%]; Dekany [20%]; Gavel [13.3%]; Max [3.3%] | 80h | 5,700 |

Notes:
- 6: PW
- 7: PW
- 15: PW
- 17: PW
- 18: RD
- 19: PW
- 20: PW
- 21: PW
- 22: PW
- 23: PW
- 24: PW

| ID | WBS | Task | Type | Duration | Start | Finish | Total slack | Constraint | Resources | Work | Cost |
| --- | --- | --- | --- | --- | --- | --- | --- | --- | --- | --- | --- |
| 25 | 1.3.2.2 | **Project Management & Meetings** |  | 477d? | 2008-05-01 | 2010-02-26 | 16d |  |  | 2270h | 162,750 |
| 26 | 1.3.2.2.1 | **Executive Committee** |  | 477d? | 2008-05-01 | 2010-02-26 | 16d |  |  | 600h | 37,500 |
| 27 | 1.3.2.2.1.1 | Executive Committee Management Activities |  | 477d? | 2008-05-01 | 2010-02-26 | 16d | finish no earlier than 2010-02-26 | Dekany [2%]; Gavel [2%]; Max [0.7%]; Wizinowich [3.3%] | 300h | 20,625 |
| 28 | 1.3.2.2.1.2 | Executive Committee Telecons |  | 477d? | 2008-05-01 | 2010-02-26 | 16d | finish no earlier than 2010-02-26 | Dekany [2%]; Gavel [2%]; Max [2%]; Wizinowich [2%] | 300h | 16,875 |
| 29 | 1.3.2.2.2 | **Team Meetings** |  | 477d? | 2008-05-01 | 2010-02-26 | 16d |  |  | 1670h | 125,250 |
| 30 | 1.3.2.2.2.1 | Meeting Participation |  | 477d? | 2008-05-01 | 2010-02-26 | 16d | start no earlier than 2008-05-01 | Dekany [4.2%]; Gavel [4.2%]; Wizinowich [4.2%]; Le Mignant [3.9%]; Johansson [4.3%]; Neyman [3.9%]; Bell [2.1%]; Adkins [2.4%]; Kupke [2.4%]; Lockwood [2.4%]; Velur [3.9%]; Wetherell [3.3%]; Reinig [2.6%]; Zolkower [2.6%] | 1670h | 125,250 |
| 31 | 1.3.2.2.2.2 | Team Meeting #1 (CIT - 1 day) | milestone | 0d | 2008-05-01 | 2008-05-01 | 493d | start no earlier than 2008-05-01 |  |  |  |
| 32 | 1.3.2.2.2.3 | Team Meeting #2 (telecon) | milestone | 0d | 2008-06-13 | 2008-06-13 | 462d | start no earlier than 2008-06-13 |  |  |  |
| 33 | 1.3.2.2.2.4 | Team Meeting #3 (telecon) | milestone | 0d? | 2008-07-11 | 2008-07-11 | 442d | start no earlier than 2008-07-11 |  |  |  |
| 34 | 1.3.2.2.2.5 | Team Meeting #4 (telecon) | milestone | 0d | 2008-08-15 | 2008-08-15 | 417d | start no earlier than 2008-08-15 |  |  |  |
| 35 | 1.3.2.2.2.6 | Team Meeting #5 (UC - 3 days) | milestone | 0d? | 2008-09-18 | 2008-09-18 | 392d | finish no earlier than 2008-09-18 |  |  |  |
| 36 | 1.3.2.2.2.7 | Team Meeting #6 (telecon) | milestone | 0d | 2008-10-17 | 2008-10-17 | 372d | start no earlier than 2008-10-17 |  |  |  |
| 37 | 1.3.2.2.2.8 | Team Meeting #7 (telecon) | milestone | 0d | 2008-11-14 | 2008-11-14 | 352d | start no earlier than 2008-11-14 |  |  |  |
| 38 | 1.3.2.2.2.9 | Team Meeting #8 (telecon) | milestone | 0d | 2008-12-12 | 2008-12-12 | 332d | start no earlier than 2008-12-12 |  |  |  |
| 39 | 1.3.2.2.2.10 | Team Meeting #9 (telecon) | milestone | 0d | 2009-01-16 | 2009-01-16 | 306d | finish no earlier than 2009-01-16 |  |  |  |
| 40 | 1.3.2.2.2.11 | Team Meeting #10 (WMKO - 4 days) | milestone | 0d | 2009-02-10 | 2009-02-10 | 290d | start no earlier than 2009-02-10 |  |  |  |
| 41 | 1.3.2.2.2.12 | Team Meeting #11 (telecon) | milestone | 0d | 2009-03-13 | 2009-03-13 | 267d | start no earlier than 2009-03-13 |  |  |  |
| 42 | 1.3.2.2.2.13 | Team Meeting #12 (telecon) | milestone | 0d | 2009-04-17 | 2009-04-17 | 242d | start no earlier than 2009-04-17 |  |  |  |
| 43 | 1.3.2.2.2.14 | Team Meeting #13 (telecon) | milestone | 0d | 2009-05-15 | 2009-05-15 | 221d | finish no earlier than 2009-05-15 |  |  |  |
| 44 | 1.3.2.2.2.15 | Team Meeting #14 (telecon) | milestone | 0d | 2009-06-12 | 2009-06-12 | 201d | finish no earlier than 2009-06-12 |  |  |  |
| 45 | 1.3.2.2.2.16 | Team Meeting #15 (telecon) | milestone | 0d | 2009-07-17 | 2009-07-17 | 177d | start no earlier than 2009-07-17 |  |  |  |
| 46 | 1.3.2.2.2.17 | Team Meeting #16 (CIT - 3 days)) | milestone | 0d | 2009-08-20 | 2009-08-20 | 152d | finish no earlier than 2009-08-20 |  |  |  |
| 47 | 1.3.2.2.2.18 | Team Meeting #17 (telecon) | milestone | 0d | 2009-09-18 | 2009-09-18 | 132d | start no earlier than 2009-09-18 |  |  |  |
| 48 | 1.3.2.2.2.19 | Team Meeting #18 (telecon) | milestone | 0d | 2009-10-16 | 2009-10-16 | 112d | start no earlier than 2009-10-16 |  |  |  |
| 49 | 1.3.2.2.2.20 | Team Meeting #19 (telecon) | milestone | 0d | 2009-11-13 | 2009-11-13 | 92d | start no earlier than 2009-11-13 |  |  |  |
| 50 | 1.3.2.2.2.21 | Team Meeting #20 (telecon) | milestone | 0d | 2009-12-11 | 2009-12-11 | 72d | start no earlier than 2009-12-11 |  |  |  |
| 51 | 1.3.2.2.2.22 | Team Meeting #21 (telecon) | milestone | 0d | 2010-01-15 | 2010-01-15 | 47d | start no earlier than 2010-01-15 |  |  |  |

Notes:
- 25: PW
- 26: PW
- 29: PW

| ID | WBS | Task | Type | Duration | Start | Finish | Total slack | Constraint | Resources | Work | Cost |
| --- | --- | --- | --- | --- | --- | --- | --- | --- | --- | --- | --- |
| 52 | 1.3.2.2.3 | **Director Telecons** |  | 390d | 2008-05-09 | 2009-11-06 | 97d |  |  |  |  |
| 53 | 1.3.2.2.3.1 | Director Telecon #1 | milestone | 0d | 2008-05-09 | 2008-05-09 | 487d | start no earlier than 2008-05-09 |  |  |  |
| 54 | 1.3.2.2.3.2 | Director Telecon #2 | milestone | 0d | 2008-11-07 | 2008-11-07 | 357d | start no earlier than 2008-11-07 |  |  |  |
| 55 | 1.3.2.2.3.3 | Director Telecon #3 | milestone | 0d | 2009-05-08 | 2009-05-08 | 227d | start no earlier than 2009-05-08 |  |  |  |
| 56 | 1.3.2.2.3.4 | Director Telecon #4 | milestone | 0d | 2009-11-06 | 2009-11-06 | 97d | start no earlier than 2009-11-06 |  |  |  |
| 57 | 1.3.2.3 | **Tracking & Reporting** |  | 478d? | 2008-04-30 | 2010-02-26 | 16d |  |  | 869h | 62,175 |
| 58 | 1.3.2.3.1 | **Monthly Status Reports** |  | 477d? | 2008-05-01 | 2010-02-26 | 16d |  |  | 546h | 37,950 |
| 59 | 1.3.2.3.1.1 | Monthly Team Status Reports |  | 477d? | 2008-05-01 | 2010-02-26 | 16d | start no earlier than 2008-05-01 | Wizinowich [1%]; Max [0.5%]; Gavel [1%]; Dekany [1%]; Reinig [0.6%]; Johansson [0.8%]; Le Mignant [0.7%]; Velur [1%]; Kupke [0.5%]; Neyman [0.5%]; Lockwood [0.5%]; Bell [0.3%]; Adkins [0.5%]; Wetherell [0.4%] | 340h | 24,000 |
| 60 | 1.3.2.3.1.2 | Monthly Project Reports (TSIP, Directors) |  | 467d? | 2008-05-15 | 2010-02-26 | 16d | start no earlier than 2008-05-15 | Wizinowich [2.4%]; Dekany [0.5%]; Gavel [0.5%]; Adkins [0.5%]; Max [0.5%] | 170h | 11,250 |
| 61 | 1.3.2.3.1.3 | TSIP Project Report Telecons |  | 464d? | 2008-05-20 | 2010-02-26 | 16d | start no earlier than 2008-05-20 | Adkins [0.5%]; Wizinowich [0.5%] | 36h | 2,700 |
| 62 | 1.3.2.3.2 | **SSC Meetings** |  | 459.88d? | 2008-04-30 | 2010-02-02 | 34.12d |  |  | 91h | 6,825 |
| 63 | 1.3.2.3.2.1 | SSC Meeting (CIT) - SDR report | milestone | 0d | 2008-04-30 | 2008-04-30 | 494d | start no earlier than 2008-04-30 |  |  |  |
| 64 | 1.3.2.3.2.2 | SSC Meeting (Keck) |  | 1.12d | 2008-06-18 | 2008-06-19 | 457.88d | start no earlier than 2008-06-18 | Dekany; Gavel; Wizinowich | 13h | 975 |
| 65 | 1.3.2.3.2.3 | SSC Meeting (UCSC) |  | 1.12d | 2008-11-03 | 2008-11-04 | 359.88d | start no earlier than 2008-11-03 | Dekany; Gavel; Wizinowich | 13h | 975 |
| 66 | 1.3.2.3.2.4 | SSC Meeting (Keck) |  | 1.12d | 2009-02-19 | 2009-02-20 | 281.88d | start no earlier than 2009-02-19 | Dekany; Gavel; Wizinowich | 13h | 975 |
| 67 | 1.3.2.3.2.5 | SSC Meeting (CIT) |  | 1.12d | 2009-04-29 | 2009-04-30 | 232.88d | start no earlier than 2009-04-29 | Dekany; Gavel; Wizinowich | 13h | 975 |
| 68 | 1.3.2.3.2.6 | SSC Meeting (Keck) |  | 1.12d | 2009-06-17 | 2009-06-18 | 197.88d | start no earlier than 2009-06-17 | Dekany; Gavel; Wizinowich | 13h | 975 |
| 69 | 1.3.2.3.2.7 | SSC Meeting (UCSC) |  | 1.12d | 2009-11-03 | 2009-11-04 | 98.88d | start no earlier than 2009-11-03 | Dekany; Gavel; Wizinowich | 13h | 975 |
| 70 | 1.3.2.3.2.8 | SSC Meeting (Keck) |  | 1.88d? | 2010-02-01 | 2010-02-02 | 34.12d | start no earlier than 2010-02-01 | Dekany [50%]; Gavel [50%]; Wizinowich [60%] | 13h | 975 |
| 71 | 1.3.2.3.3 | **Other Presentations** |  | 350d? | 2008-06-02 | 2009-10-02 | 121d |  |  | 232h | 17,400 |
| 72 | 1.3.2.3.3.1 | SPIE AO Conference Presentations/Papers |  | 15d? | 2008-06-02 | 2008-06-20 | 456d | start no earlier than 2008-06-02 | Dekany [33.3%]; Gavel [33.3%]; Wizinowich [33.3%] | 120h | 9,000 |
| 73 | 1.3.2.3.3.2 | SPIE AO Conference (Marseille) |  | 5d? | 2008-06-23 | 2008-06-28 | 451d | finish no earlier than 2008-06-28 |  |  |  |
| 74 | 1.3.2.3.3.3 | Keck Science Meeting 08 |  | 3d | 2008-09-18 | 2008-09-22 | 390d | start no earlier than 2008-09-18 | Dekany; Gavel; Wizinowich | 56h | 4,200 |
| 75 | 1.3.2.3.3.4 | Keck Science Meeting 09 |  | 3d | 2009-09-17 | 2009-09-21 | 130d | start no earlier than 2009-09-17 | Dekany; Gavel; Wizinowich | 56h | 4,200 |
| 76 | 1.3.2.3.3.5 | Other |  | 195d? | 2009-01-05 | 2009-10-02 | 121d | finish no earlier than 2009-10-02 |  |  |  |

Notes:
- 52: PW
- 57: PW
- 58: PW
- 62: PW
- 71: PW

| ID | WBS | Task | Type | Duration | Start | Finish | Total slack | Constraint | Resources | Work | Cost |
| --- | --- | --- | --- | --- | --- | --- | --- | --- | --- | --- | --- |
| 77 | 1.3.2.4 | **Proposals** |  | 348d? | 2008-06-02 | 2009-09-30 | 123d |  |  | 480h | 3,000 |
| 78 | 1.3.2.4.1 | Advancement Support |  | 348d? | 2008-06-02 | 2009-09-30 | 123d | start no earlier than 2008-06-02 | Free [2.9%] | 80h |  |
| 79 | 1.3.2.4.2 | TSIP Proposal for DDR |  | 25d? | 2009-07-28 | 2009-08-31 | 145d | finish no earlier than 2009-08-31 | Dekany [10%]; Gavel [10%]; Max [10%]; Free [90%] | 240h | 3,000 |
| 80 | 1.3.2.4.3 | Other Proposal |  | 20d? | 2009-09-03 | 2009-09-30 | 123d | finish no earlier than 2009-09-30 | Free | 160h |  |
| 81 | 1.3.2.5 | **Programmatic Risk Assessment & Mitigation** |  | 355d? | 2008-05-19 | 2009-09-25 | 126d |  |  | 180h | 13,500 |
| 82 | 1.3.2.5.1 | **Risk Assessment** |  | 213.25d? | 2008-09-04 | 2009-06-30 | 189d |  |  | 60h | 4,500 |
| 83 | 1.3.2.5.1.1 | Programmatic Risk Assessment v1 |  | 6.25d? | 2008-09-04 | 2008-09-12 | 396d | finish no earlier than 2008-09-12 | Wizinowich [40%]; Dekany [8%]; Gavel [8%]; Adkins [8.9%] | 32h | 2,400 |
| 84 | 1.3.2.5.1.2 | Programmatic Risk Assessment v2 |  | 2d? | 2009-06-29 | 2009-06-30 | 189d | finish no earlier than 2009-06-30 | Wizinowich; Dekany; Gavel; Adkins | 28h | 2,100 |
| 85 | 1.3.2.5.2 | **Risk Mitigation** |  | 355d? | 2008-05-19 | 2009-09-25 | 126d |  |  | 120h | 9,000 |
| 86 | 1.3.2.5.2.1 | Laser Procurement |  | 350d? | 2008-05-26 | 2009-09-25 | 126d | finish no earlier than 2009-09-25 | Wizinowich [1.4%] | 40h | 3,000 |
| 87 | 1.3.2.5.2.2 | Science Instruments |  | 35d? | 2008-10-06 | 2008-11-21 | 346d | finish no earlier than 2008-11-21 | Wizinowich [14.3%] | 40h | 3,000 |
| 88 | 1.3.2.5.2.3 | Funding |  | 95d? | 2008-05-19 | 2008-09-26 | 386d | finish no earlier than 2008-09-26 | Wizinowich [5.3%] | 40h | 3,000 |
| 89 | 1.3.2.6 | **Preliminary Design Review** |  | 404.33d? | 2008-09-02 | 2010-03-22 | 0d |  |  | 506h | 34,350 |
| 90 | 1.3.2.6.1 | Define Success Criteria for all Reviews |  | 8.33d? | 2008-09-02 | 2008-09-12 | 396d | finish no earlier than 2008-09-12 | Wizinowich [60%]; Dekany [12%]; Gavel [12%]; Max [6%] | 60h | 4,200 |
| 91 | 1.3.2.6.2 | Review Setup (Date, Participants, Charter) |  | 5d? | 2009-09-07 | 2009-09-11 | 136d | start no earlier than 2009-09-07 | Wizinowich [30%]; Max [10%] | 16h | 900 |
| 92 | 1.3.2.6.3 | Preliminary Design Report |  | 12d? | 2010-01-11 | 2010-01-26 | 39d | start no earlier than 2010-01-11 | Wizinowich [52.1%]; Dekany [15.6%]; Gavel [15.6%]; Max [4.2%]; Neyman [2.1%]; Le Mignant [2.1%]; Johansson [2.1%]; Reinig [3.1%]; Velur [5.2%]; Kupke [2.1%] | 100h | 7,200 |
| 93 | 1.3.2.6.4 | Review Package Distributed |  | 1d? | 2010-01-27 | 2010-01-27 | 38d | start no earlier than 2010-01-27 | Wizinowich [75%] | 6h | 450 |
| 94 | 1.3.2.6.5 | Reviewer Comments Received | milestone | 0d | 2010-02-10 | 2010-02-10 | 29d | start no earlier than 2010-02-10 |  |  |  |
| 95 | 1.3.2.6.6 | Reviewer Comments Addressed |  | 5d? | 2010-02-11 | 2010-02-17 | 23d | start no earlier than 2010-02-11 | Wizinowich [50%]; Dekany [30%]; Gavel [30%]; Max [40%]; Reinig [5%]; Velur [15%]; Bell [2.5%]; Wetherell [2.5%]; Neyman [5%]; Le Mignant [5%]; Johansson [5%]; Kupke [5%]; Lockwood [5%] | 80h | 4,800 |
| 96 | 1.3.2.6.7 | PDR Presentation Preparation |  | 15d? | 2010-02-01 | 2010-02-19 | 21d | start no earlier than 2010-02-01 | Wizinowich [16.7%]; Dekany [10%]; Gavel [10%]; Reinig [3.3%]; Kupke [1.7%]; Lockwood [1.7%]; Velur [5%]; Wetherell [0.8%]; Bell [0.8%]; Neyman [1.7%]; Le Mignant [2.5%]; Johansson [2.5%] | 68h | 5,100 |
| 97 | 1.3.2.6.8 | Preliminary Design Review |  | 1d? | 2010-02-22 | 2010-02-22 | 20d | start no earlier than 2010-02-22 | Wizinowich [1250%]; Dekany [1250%]; Max [1250%]; Gavel [1250%]; Zolkower; Velur; Reinig; Lockwood; Kupke; Wetherell; Le Mignant; Neyman; Johansson; Britton | 128h | 8,700 |
| 98 | 1.3.2.6.9 | Reviewer Report Received | milestone | 0d | 2010-03-15 | 2010-03-15 | 6d | start no earlier than 2010-03-15 |  |  |  |
| 99 | 1.3.2.6.10 | Response to Reviewer Report |  | 5d? | 2010-03-16 | 2010-03-22 | 0d | start no earlier than 2010-03-16 | Wizinowich [40%]; Dekany [20%]; Gavel [20%]; Max [20%]; Reinig [5%]; Kupke [2.5%]; Velur [5%]; Neyman [2.5%]; Le Mignant [2.5%]; Johansson [2.5%] | 48h | 3,000 |
| 100 | 1.3.2.7 | **Project Support** |  | 477d? | 2008-05-01 | 2010-02-26 | 16d |  |  | 3361h | 252,075 |
| 101 | 1.3.2.7.1 | Administrative/Contract Support |  | 477d? | 2008-05-01 | 2010-02-26 | 16d | start no earlier than 2008-05-01 | Tyau [20.6%]; Contract Administrator [2.1%]; Wizinowich [10.4%] | 765h | 57,375 |
| 102 | 1.3.2.7.2 | Shared Infrastructure |  | 430d? | 2008-07-07 | 2010-02-26 | 16d | finish no earlier than 2010-02-26 | Chock [5.8%] | 200h | 15,000 |
| 103 | 1.3.2.7.3 | Research Time |  | 477d? | 2008-05-01 | 2010-02-26 | 16d | start no earlier than 2008-05-01 | McGrath [47.3%]; Le Mignant [15.5%] | 2396h | 179,700 |

Notes:
- 77: PW
- 81: PW
- 82: PW
- 85: PW
- 89: PW
- 100: PW

| ID | WBS | Task | Duration | Start | Finish | Total slack | Constraint | Resources | Work | Cost |
| --- | --- | --- | --- | --- | --- | --- | --- | --- | --- | --- |
| 104 | 1.3.3 | **Systems Engineering** | 457d? | 2008-05-01 | 2010-01-29 | 36d |  |  | 9815h | 668,550 |
| 105 | 1.3.3.1 | **Science Case Development** | 457d? | 2008-05-01 | 2010-01-29 | 36d |  |  | 4005h | 232,800 |
| 106 | 1.3.3.1.1 | **Science Case Requirements** | 447d? | 2008-05-01 | 2010-01-15 | 46d |  |  | 2701h | 166,500 |
| 107 | 1.3.3.1.1.1 | **Requirements for new Science Drivers** | 183d? | 2008-05-01 | 2009-01-12 | 310d |  |  | 440h | 24,000 |
| 108 | 1.3.3.1.1.1.1 | Astrometry Science in Sparse Fields | 71d? | 2008-10-06 | 2009-01-12 | 310d | finish no earlier than 2009-01-12 | McGrath [7%]; Student [14.1%]; Max [3.5%] | 140h | 9,000 |
| 109 | 1.3.3.1.1.1.2 | Resolved Stellar Populations in Crowded Fields | 61d? | 2008-07-14 | 2008-10-06 | 380d | finish no earlier than 2008-10-06 | Student [24.6%]; Max [8.2%] | 160h | 9,000 |
| 110 | 1.3.3.1.1.1.3 | Debris Disks & Young Stellar Objects | 61d? | 2008-07-14 | 2008-10-06 | 380d | finish no earlier than 2008-10-06 | McGrath [8.2%]; Max [8.2%] | 80h | 3,000 |
| 111 | 1.3.3.1.1.1.4 | QSO Host Galaxies | 52d? | 2008-05-01 | 2008-07-11 | 441d | finish no earlier than 2008-07-11 | McGrath [9.6%]; Max [4.8%] | 60h | 3,000 |
| 112 | 1.3.3.1.1.2 | **Extend SCRD Discussion of Science Drivers** | 168d? | 2008-05-01 | 2008-12-22 | 325d |  |  | 601h | 37,500 |
| 113 | 1.3.3.1.1.2.1 | Nearby AGNs | 52d? | 2008-05-01 | 2008-07-11 | 441d | finish no earlier than 2008-07-11 | McGrath [4.8%]; Max [2.4%] | 30h | 1,500 |
| 114 | 1.3.3.1.1.2.2 | Gravitational Lensing | 52d? | 2008-05-01 | 2008-07-11 | 441d | finish no earlier than 2008-07-11 | McGrath [9.6%]; Max [1%] | 44h | 3,000 |
| 115 | 1.3.3.1.1.2.3 | Backup Science | 52d? | 2008-05-01 | 2008-07-11 | 441d | finish no earlier than 2008-07-11 | McGrath [4.8%]; Max [1%]; Le Mignant [4.8%] | 44h | 3,000 |
| 116 | 1.3.3.1.1.2.4 | Ice Giant Planets | 61d? | 2008-07-14 | 2008-10-06 | 380d | finish no earlier than 2008-10-06 | McGrath [2%] | 10h | 750 |
| 117 | 1.3.3.1.1.2.5 | GR at Galactic Center | 61d? | 2008-07-14 | 2008-10-06 | 380d | finish no earlier than 2008-10-06 | Student [16.4%]; Max [3.1%] | 95h | 6,000 |
| 118 | 1.3.3.1.1.2.6 | Extrasolar Planets | 52d? | 2008-10-06 | 2008-12-16 | 329d | start no earlier than 2008-10-06 | McGrath [9.6%]; Macintosh [19.2%]; Max [4.8%] | 140h | 9,000 |
| 119 | 1.3.3.1.1.2.7 | Asteroids | 52d? | 2008-05-01 | 2008-07-11 | 441d | finish no earlier than 2008-07-11 | Student [9.6%]; Le Mignant [4.8%]; Max [1.9%] | 68h | 4,500 |
| 120 | 1.3.3.1.1.2.8 | QSO Host Galaxies | 116d? | 2008-07-14 | 2008-12-22 | 325d | finish no earlier than 2008-12-22 | McGrath [6.5%]; Max [2.2%] | 80h | 4,500 |
| 121 | 1.3.3.1.1.2.9 | Backup Science - NGS & Acquisition Camera | 61d? | 2008-07-14 | 2008-10-06 | 380d | finish no earlier than 2008-10-06 | McGrath [4.1%]; Le Mignant [6.1%]; Neyman [4.1%]; Max [4.1%] | 90h | 5,250 |
| 122 | 1.3.3.1.1.3 | **Characterize PSF Stability, Knowledge & Subtraction Requirements** | 226d? | 2008-10-06 | 2009-08-17 | 155d |  |  | 1340h | 87,000 |
| 123 | 1.3.3.1.1.3.1 | Nearby AGNs | 226d? | 2008-10-06 | 2009-08-17 | 155d | finish no earlier than 2009-08-17 | McGrath [8.8%]; Student [19.9%]; Max [3.3%] | 580h | 39,000 |
| 124 | 1.3.3.1.1.3.2 | Galactic Center Astrometry | 97d? | 2008-10-06 | 2009-02-17 | 284d | start no earlier than 2008-10-06 | Student [20.6%]; Max [3.9%] | 190h | 12,000 |
| 125 | 1.3.3.1.1.3.3 | Extrasolar Planets | 96d? | 2009-01-12 | 2009-05-25 | 215d | start no earlier than 2009-01-12 | McGrath [5.2%]; Student [15.6%]; Macintosh [10.4%]; Max [2.6%] | 260h | 18,000 |
| 126 | 1.3.3.1.1.3.4 | Minor Planet Multiplicity | 36d? | 2008-10-20 | 2008-12-08 | 335d | start no earlier than 2008-10-20 | Student [27.8%]; Max [3.5%] | 90h | 6,000 |
| 127 | 1.3.3.1.1.3.5 | QSO Host Galaxies | 81d? | 2008-10-06 | 2009-01-26 | 300d | finish no earlier than 2009-01-26 | McGrath [6.2%]; Student [18.5%]; Max [9.3%] | 220h | 12,000 |
| 128 | 1.3.3.1.1.4 | Characterize Sensitivity & Background Requirements | 96d? | 2009-01-12 | 2009-05-25 | 215d | finish no earlier than 2009-05-25 | McGrath [15.6%]; Max [5.2%] | 160h | 9,000 |
| 129 | 1.3.3.1.1.5 | Science Requirements Summary Matrix | 165d? | 2009-05-25 | 2010-01-08 | 51d | finish no earlier than 2010-01-08 | McGrath [6.1%]; Max [1.5%] | 100h | 6,000 |
| 130 | 1.3.3.1.1.6 | SEMP Input | 75d? | 2009-10-05 | 2010-01-15 | 46d | start no earlier than 2009-10-05 | McGrath [6.7%]; Max [3.3%] | 60h | 3,000 |

Notes:
- 104: RD
- 105: CM
- 106: CM

| ID | WBS | Task | Duration | Start | Finish | Total slack | Constraint | Resources | Work | Cost |
| --- | --- | --- | --- | --- | --- | --- | --- | --- | --- | --- |
| 131 | 1.3.3.1.2 | **Science Observing Planning & Execution** | 379d? | 2008-08-04 | 2010-01-14 | 47d |  |  | 480h | 31,500 |
| 132 | 1.3.3.1.2.1 | Key Science Driver Observing Scenarios | 120d? | 2008-08-04 | 2009-01-16 | 306d | start no earlier than 2008-08-04 | McGrath [13.5%]; Le Mignant [8.3%]; Max [3.1%] | 240h | 15,750 |
| 133 | 1.3.3.1.2.2 | Design Reference Missions | 119d? | 2009-08-03 | 2010-01-14 | 47d | start no earlier than 2009-08-03 | McGrath [13.7%]; Le Mignant [8.5%]; Max [3.2%] | 240h | 15,750 |
| 134 | 1.3.3.1.3 | **Science Performance Input** | 315d? | 2008-10-06 | 2009-12-18 | 66d |  |  | 180h | 9,750 |
| 135 | 1.3.3.1.3.1 | Define Science Driver Parameters for Performance Budgets | 12d? | 2008-10-13 | 2008-10-28 | 364d | start no earlier than 2008-10-13 | McGrath [10.4%]; Max [10.4%] | 20h | 750 |
| 136 | 1.3.3.1.3.2 | Input to User Interfaces, Planning & Observing Tools | 300d? | 2008-10-06 | 2009-11-27 | 81d | finish no earlier than 2009-11-27 | McGrath [3.3%] | 80h | 6,000 |
| 137 | 1.3.3.1.3.3 | Input to Preliminary Operations Concept Document | 275d? | 2008-12-01 | 2009-12-18 | 66d | finish no earlier than 2009-12-18 | McGrath [1.8%]; Max [1.8%] | 80h | 3,000 |
| 138 | 1.3.3.1.4 | **Science Competitiveness** | 380d? | 2008-07-07 | 2009-12-18 | 66d |  |  | 144h | 7,800 |
| 139 | 1.3.3.1.4.1 | Update List of Science Goals for Other Facilities | 380d? | 2008-07-07 | 2009-12-18 | 66d | finish no earlier than 2009-12-18 | McGrath [1.4%]; Max [0.7%] | 64h | 3,300 |
| 140 | 1.3.3.1.4.2 | Evaluate NGAO Potential to Compliment Other Facilities | 380d? | 2008-07-07 | 2009-12-18 | 66d | finish no earlier than 2009-12-18 | McGrath [1.3%]; Max [0.3%] | 50h | 3,000 |
| 141 | 1.3.3.1.4.3 | Define NGAO Uniqueness Space | 380d? | 2008-07-07 | 2009-12-18 | 66d | finish no earlier than 2009-12-18 | McGrath [0.7%]; Max [0.3%] | 30h | 1,500 |
| 142 | 1.3.3.1.5 | **User Community Liaison** | 445d? | 2008-05-19 | 2010-01-29 | 36d |  |  | 220h | 5,250 |
| 143 | 1.3.3.1.5.1 | Enlist People to work on new NGAO Science Aspects | 358d? | 2008-05-19 | 2009-09-30 | 123d | finish no earlier than 2009-09-30 | Max [1.4%]; McGrath [0.7%] | 60h | 1,500 |
| 144 | 1.3.3.1.5.2 | **SSC & Keck Science Meeting** | 435d? | 2008-06-02 | 2010-01-29 | 36d |  |  | 160h | 3,750 |
| 145 | 1.3.3.1.5.2.1 | Prepare & Give Presentations | 435d? | 2008-06-02 | 2010-01-29 | 36d | finish no earlier than 2010-01-29 | Max [2%]; McGrath [1.1%] | 110h | 3,000 |
| 146 | 1.3.3.1.5.2.2 | Obtain & Document Feedback | 435d? | 2008-06-02 | 2010-01-29 | 36d | finish no earlier than 2010-01-29 | Max [1.1%]; McGrath [0.3%] | 50h | 750 |
| 147 | 1.3.3.1.6 | **Science Advisory Team Meetings** | 385d? | 2008-06-09 | 2009-11-27 | 81d |  |  | 280h | 12,000 |
| 148 | 1.3.3.1.6.1 | Prepare Minutes, Presentations & KAONs | 385d? | 2008-06-09 | 2009-11-27 | 81d | finish no earlier than 2009-11-27 | Max [2.6%]; McGrath [2.6%]; Le Mignant [0.6%] | 180h | 7,500 |
| 149 | 1.3.3.1.6.2 | Refine Science Requirements | 355d? | 2008-07-21 | 2009-11-27 | 81d | finish no earlier than 2009-11-27 | Le Mignant [0.7%] | 20h | 1,500 |
| 150 | 1.3.3.1.6.3 | Evaluate Science Impact of Proposed Changes | 355d? | 2008-07-21 | 2009-11-27 | 81d | finish no earlier than 2009-11-27 | Max [1.4%]; McGrath [1.4%] | 80h | 3,000 |
| 151 | 1.3.3.2 | **Requirements** | 410d? | 2008-05-26 | 2009-12-18 | 66d |  |  | 970h | 72,750 |
| 152 | 1.3.3.2.1 | **Operations Concept Document (OCD)** | 410d? | 2008-05-26 | 2009-12-18 | 66d |  |  | 480h | 36,000 |
| 153 | 1.3.3.2.1.1 | OCD Outline | 10d? | 2008-05-26 | 2008-06-06 | 466d | start no earlier than 2008-05-26 | Le Mignant [40%]; Wizinowich [10%] | 40h | 3,000 |
| 154 | 1.3.3.2.1.2 | OCD Release 1 | 45d? | 2008-12-01 | 2009-01-30 | 296d | start no earlier than 2008-12-01 | Le Mignant [33.3%]; Other [13.9%]; Wizinowich [2.8%]; Johansson [5.6%] | 200h | 15,000 |
| 155 | 1.3.3.2.1.3 | OCD Release 2 | 55d? | 2009-10-05 | 2009-12-18 | 66d | start no earlier than 2009-10-05 | Le Mignant [36.4%]; Other [11.4%]; Johansson [4.5%]; Wizinowich [2.3%] | 240h | 18,000 |

Notes:
- 131: CM
- 134: CM
- 138: CM
- 142: CM
- 147: CM
- 151: EJ
- 152: DLM
- 153: DLM
- 154: DLM
- 155: DLM

| ID | WBS | Task | Duration | Start | Finish | Total slack | Constraint | Resources | Work | Cost |
| --- | --- | --- | --- | --- | --- | --- | --- | --- | --- | --- |
| 156 | 1.3.3.2.2 | **System Requirements (SRD)** | 270d? | 2008-12-01 | 2009-12-11 | 71d |  |  | 80h | 6,000 |
| 157 | 1.3.3.2.2.1 | SRD Release I | 10d? | 2008-12-01 | 2008-12-12 | 331d | finish no earlier than 2008-12-12 | Johansson [62.5%] | 50h | 3,750 |
| 158 | 1.3.3.2.2.2 | SRD Release 2 | 10d? | 2009-11-30 | 2009-12-11 | 71d | finish no earlier than 2009-12-11 | Johansson [37.5%] | 30h | 2,250 |
| 159 | 1.3.3.2.3 | **Functional Requirements (FRD)** | 375d? | 2008-07-14 | 2009-12-18 | 66d |  |  | 250h | 18,750 |
| 160 | 1.3.3.2.3.1 | FRD Release 1 | 35d? | 2008-07-14 | 2008-08-29 | 406d | start no earlier than 2008-07-14 | Johansson [14.3%]; Dekany [10.7%]; Wizinowich [7.1%]; Gavel [10.7%] | 120h | 9,000 |
| 161 | 1.3.3.2.3.2 | FRD Release 2 | 35d? | 2009-11-02 | 2009-12-18 | 66d | start no earlier than 2009-11-02 | Johansson [17.9%]; Dekany [7.1%] | 70h | 5,250 |
| 162 | 1.3.3.2.3.3 | Compliance Matrix | 20d? | 2008-10-06 | 2008-10-31 | 361d | finish no earlier than 2008-10-31 | Johansson [37.5%] | 60h | 4,500 |
| 163 | 1.3.3.2.4 | Software Standards (Define & Document) | 31d? | 2008-10-06 | 2008-11-17 | 350d | start no earlier than 2008-10-06 | Johansson [32.3%] | 80h | 6,000 |
| 164 | 1.3.3.2.5 | Component Standards (Define & Document) | 25d? | 2008-11-03 | 2008-12-05 | 336d | finish no earlier than 2008-12-05 | Johansson [40%] | 80h | 6,000 |
| 165 | 1.3.3.3 | **Systems Engineering Analysis** | 427d? | 2008-05-01 | 2009-12-18 | 66d |  |  | 2188h | 164,100 |
| 166 | 1.3.3.3.1 | **Performance Budgets** | 389d? | 2008-06-24 | 2009-12-18 | 66d |  |  | 828h | 62,100 |
| 167 | 1.3.3.3.1.1 | Requirements Flowdown Report | 15d? | 2009-11-30 | 2009-12-18 | 66d | start no earlier than 2009-11-30 | Dekany [50%] | 60h | 4,500 |
| 168 | 1.3.3.3.1.2 | **Throughput & Background Budget** | 30d? | 2008-11-03 | 2008-12-12 | 331d |  |  | 80h | 6,000 |
| 169 | 1.3.3.3.1.2.1 | Thermal Background Analysis Software with Documentation | 15d? | 2008-11-03 | 2008-11-21 | 346d | finish no earlier than 2008-11-21 | Bouchez [41.7%] | 50h | 3,750 |
| 170 | 1.3.3.3.1.2.2 | Thermal Analysis | 10d? | 2008-12-01 | 2008-12-12 | 331d | finish no earlier than 2008-12-12 | Bouchez [37.5%] | 30h | 2,250 |
| 171 | 1.3.3.3.1.3 | **Wavefront & Encircled Energy** | 260d? | 2008-09-01 | 2009-08-28 | 146d |  |  | 328h | 24,600 |
| 172 | 1.3.3.3.1.3.1 | **WFE/EE Budget Tool** | 213d? | 2008-09-01 | 2009-06-24 | 193d |  |  | 256h | 19,200 |
| 173 | 1.3.3.3.1.3.1.1 | NGS TT & TTFA Sharpening Budgets | 31.5d? | 2008-10-06 | 2008-11-18 | 349.5d | start no earlier than 2008-10-06 | Dekany [23.8%] | 60h | 4,500 |
| 174 | 1.3.3.3.1.3.1.2 | Improved Bandwidth Model | 25d? | 2008-12-01 | 2009-01-02 | 316d | start no earlier than 2008-12-01 | Dekany [4%]; Britton [36%] | 80h | 6,000 |
| 175 | 1.3.3.3.1.3.1.3 | Improved Atmospheric Dispersion Model | 15d? | 2008-09-01 | 2008-09-19 | 391d | start no earlier than 2008-09-01 | Britton [33.3%] | 40h | 3,000 |
| 176 | 1.3.3.3.1.3.1.4 | Other | 38d? | 2009-05-04 | 2009-06-24 | 193d | start no earlier than 2009-05-04 | Dekany [25%] | 76h | 5,700 |
| 177 | 1.3.3.3.1.3.2 | **WFE/EE Performance Analysis** | 65d? | 2009-06-01 | 2009-08-28 | 146d |  |  | 72h | 5,400 |
| 178 | 1.3.3.3.1.3.2.1 | Key Science Cases Analysis | 20d? | 2009-06-01 | 2009-06-26 | 191d | start no earlier than 2009-06-01 | Dekany [15%] | 24h | 1,800 |
| 179 | 1.3.3.3.1.3.2.2 | Additional Science Case Analysis | 20d? | 2009-08-03 | 2009-08-28 | 146d | start no earlier than 2009-08-03 | Dekany [30%] | 48h | 3,600 |

Notes:
- 156: EJ
- 157: EJ
- 158: EJ
- 159: EJ
- 160: EJ
- 161: EJ
- 162: EJ
- 163: EJ
- 164: EJ
- 165: RD
- 166: RD
- 167: RD
- 168: AB
- 171: RD
- 172: RD
- 177: RD

| ID | WBS | Task | Duration | Start | Finish | Predecessors | Total slack | Free slack | Constraint | Resources | Work | Cost |
| --- | --- | --- | --- | --- | --- | --- | --- | --- | --- | --- | --- | --- |
| 180 | 1.3.3.3.1.4 | **Astrometric Precision** | 105d? | 2008-10-06 | 2009-02-27 |  | 276d |  |  |  | 200h | 15,000 |
| 181 | 1.3.3.3.1.4.1 | Develop Astrometric Budget Tool | 55d? | 2008-10-06 | 2008-12-19 |  | 326d |  | start no earlier than 2008-10-06 | Britton [13.6%]; Wizinowich [13.6%] | 120h | 9,000 |
| 182 | 1.3.3.3.1.4.2 | Galactic Center Astrometric Analysis | 40d? | 2009-01-05 | 2009-02-27 |  | 276d |  | start no earlier than 2009-01-05 | Neyman [25%] | 80h | 6,000 |
| 183 | 1.3.3.3.1.5 | **Observing Efficiency** | 266d? | 2008-06-24 | 2009-06-30 |  | 189d |  |  |  | 80h | 6,000 |
| 184 | 1.3.3.3.1.5.1 | Observing Efficiency Tool | 5d? | 2008-06-24 | 2008-06-30 |  | 450d |  | finish no earlier than 2008-06-30 | Le Mignant | 40h | 3,000 |
| 185 | 1.3.3.3.1.5.2 | Observing Efficiency Analysis | 5d? | 2009-06-24 | 2009-06-30 |  | 189d |  | finish no earlier than 2009-06-30 | Le Mignant | 40h | 3,000 |
| 186 | 1.3.3.3.1.6 | **Observing Uptime** | 250d? | 2008-12-01 | 2009-11-13 |  | 91d |  |  |  | 80h | 6,000 |
| 187 | 1.3.3.3.1.6.1 | Observing Uptime Tool | 10d? | 2008-12-01 | 2008-12-12 |  | 331d |  | start no earlier than 2008-12-01 | Johansson [50%] | 40h | 3,000 |
| 188 | 1.3.3.3.1.6.2 | Observing Uptime Analysis | 10d? | 2009-11-02 | 2009-11-13 |  | 91d |  | start no earlier than 2009-11-02 | Johansson [50%] | 40h | 3,000 |
| 189 | 1.3.3.3.2 | **Modeling & Analysis** | 247d? | 2008-05-01 | 2009-04-10 |  | 246d |  |  |  | 880h | 66,000 |
| 190 | 1.3.3.3.2.1 | T/T Sharpening Study Report | 42d? | 2008-05-01 | 2008-06-27 |  | 451d |  | start no earlier than 2008-05-01 | Dekany [23.8%]; Neyman [47.6%] | 240h | 18,000 |
| 191 | 1.3.3.3.2.2 | Performance vs T/T NGS Report | 32d? | 2008-09-01 | 2008-10-14 |  | 374d |  | start no earlier than 2008-09-01 | Dekany [83.3%]; Neyman [62.5%] | 240h | 18,000 |
| 192 | 1.3.3.3.2.3 | Galactic Center Performance Report | 30d? | 2009-03-02 | 2009-04-10 |  | 246d |  | start no earlier than 2009-03-02 | Dekany [50%]; Neyman [50%] | 240h | 18,000 |
| 193 | 1.3.3.3.2.4 | PSF Libraries | 35d? | 2008-11-03 | 2008-12-19 |  | 326d |  | finish no earlier than 2008-12-19 | Neyman [57.1%] | 160h | 12,000 |
| 194 | 1.3.3.3.3 | PSF Calibration | 125d? | 2009-05-04 | 2009-10-23 |  | 106d |  | start no earlier than 2009-05-04 | Le Mignant [12%]; Neyman [36%] | 480h | 36,000 |
| 195 | 1.3.3.4 | **System Architecture** | 411d? | 2008-05-05 | 2009-11-30 |  | 80d |  |  |  | 1070h | 80,250 |
| 196 | 1.3.3.4.1 | **System Hardware Architecture** | 391d? | 2008-06-02 | 2009-11-30 |  | 80d |  |  |  | 264h | 19,800 |
| 197 | 1.3.3.4.1.1 | Hybrid Rayleigh / Sodium Trade Study | 65d? | 2008-06-30 | 2008-09-26 |  | 386d |  | start no earlier than 2008-06-30 | Dekany [15.4%]; Neyman [15.4%] | 160h | 12,000 |
| 198 | 1.3.3.4.1.2 | Degraded Laser Power Trade Study | 10d? | 2008-08-04 | 2008-08-15 |  | 416d |  | start no earlier than 2008-08-04 | Neyman [50%] | 40h | 3,000 |
| 199 | 1.3.3.4.1.3 | System Architecture: Evaluate & Document Changes | 391d? | 2008-06-02 | 2009-11-30 |  | 80d |  | start no earlier than 2008-06-02 | Dekany [2%] | 64h | 4,800 |
| 200 | 1.3.3.4.2 | **Software Architecture** | 308d? | 2008-07-28 | 2009-09-30 |  | 123d |  |  |  | 162h | 12,150 |
| 201 | 1.3.3.4.2.1 | Evaluate Software Architecture Options | 20d? | 2008-07-28 | 2008-08-22 |  | 391d | 0d | start no earlier than 2008-07-28 | Johansson [21.9%]; Morrison [9.4%] | 50h | 3,750 |
| 202 | 1.3.3.4.2.2 | Determine/Document Software Arch Approach | 20d? | 2008-08-25 | 2008-09-19 | 201 | 391d |  | finish no earlier than 2008-09-19 | Johansson [25%]; Morrison [25%] | 80h | 6,000 |
| 203 | 1.3.3.4.2.3 | Software Architecture: Evaluate & Document Changes | 268d? | 2008-09-22 | 2009-09-30 |  | 123d |  | start no earlier than 2008-09-22 | Johansson [1.5%] | 32h | 2,400 |

Notes:
- 180: PW
- 183: DLM
- 186: EJ
- 189: RD
- 194: DLM
- 195: RD
- 196: RD
- 200: EJ
- 201: EJ
- 202: EJ
- 203: EJ

| ID | WBS | Task | Duration | Start | Finish | Predecessors | Total slack | Free slack | Constraint | Resources | Work | Cost |
| --- | --- | --- | --- | --- | --- | --- | --- | --- | --- | --- | --- | --- |
| 204 | 1.3.3.4.3 | **Control Systems Architecture** | 261d? | 2008-10-01 | 2009-09-30 |  | 123d |  |  |  | 420h | 31,500 |
| 205 | 1.3.3.4.3.1 | Evaluate Control Systems Arch Options | 33d? | 2008-10-01 | 2008-11-14 |  | 315d | 0d | finish no earlier than 2008-11-14 | Johansson [30.3%] | 80h | 6,000 |
| 206 | 1.3.3.4.3.2 | Determine/Document Control Systems Arch | 36d? | 2008-11-17 | 2009-01-05 | 205 | 315d |  | start no earlier than 2008-11-17 | Johansson [34.7%] | 100h | 7,500 |
| 207 | 1.3.3.4.3.3 | Evaluate Motion Control Arch Options | 37d? | 2009-01-08 | 2009-02-27 |  | 256d | 0d | finish no earlier than 2009-02-27 | Johansson [20.3%]; Wetherell [20.3%] | 120h | 9,000 |
| 208 | 1.3.3.4.3.4 | Determine/Document Motion Control Arch | 20d? | 2009-03-02 | 2009-03-27 | 207 | 256d |  | finish no earlier than 2009-03-27 | Johansson [18.8%]; Wetherell [18.8%] | 60h | 4,500 |
| 209 | 1.3.3.4.3.5 | Control Systems Architecture: Evaluate & Document Changes | 190d? | 2009-01-08 | 2009-09-30 |  | 123d |  | start no earlier than 2009-01-08 | Johansson [2.6%]; Wetherell [1.3%] | 60h | 4,500 |
| 210 | 1.3.3.4.4 | **Operations Sequences Architecture** | 330d? | 2008-05-05 | 2009-08-07 |  | 161d |  |  |  | 224h | 16,800 |
| 211 | 1.3.3.4.4.1 | Define Required System Level Sequences | 10d? | 2008-05-05 | 2008-05-16 |  | 481d |  | start no earlier than 2008-05-05 | Le Mignant [50%] | 40h | 3,000 |
| 212 | 1.3.3.4.4.2 | Develop System Level Sequences Approach | 15d? | 2008-05-19 | 2008-06-06 |  | 466d |  | finish no earlier than 2008-06-06 | Le Mignant [33.3%] | 40h | 3,000 |
| 213 | 1.3.3.4.4.3 | Sequences Definition Document | 15d? | 2008-06-09 | 2008-06-27 |  | 451d |  | start no earlier than 2008-06-09 | Le Mignant [66.7%] | 80h | 6,000 |
| 214 | 1.3.3.4.4.4 | Sequences: Evaluate & Document Changes | 285d? | 2008-07-07 | 2009-08-07 |  | 161d |  | start no earlier than 2008-07-07 | Le Mignant [2.8%] | 64h | 4,800 |
| 215 | 1.3.3.5 | **External Interface Control** | 100d? | 2008-10-06 | 2009-02-20 |  | 281d |  |  |  | 244h | 18,300 |
| 216 | 1.3.3.5.1 | **Observatory Interfaces** | 100d? | 2008-10-06 | 2009-02-20 |  | 281d |  |  |  | 120h | 9,000 |
| 217 | 1.3.3.5.1.1 | AO System ICD | 15d? | 2009-02-02 | 2009-02-20 |  | 281d |  | finish no earlier than 2009-02-20 | Neyman [33.3%] | 40h | 3,000 |
| 218 | 1.3.3.5.1.2 | Laser System ICD | 10d? | 2008-10-06 | 2008-10-17 |  | 371d |  | finish no earlier than 2008-10-17 | Chin [12.5%]; Neyman [25%]; Adkins [12.5%] | 40h | 3,000 |
| 219 | 1.3.3.5.1.3 | Science Tools ICD | 20d? | 2008-10-06 | 2008-10-31 |  | 361d |  | finish no earlier than 2008-10-31 | Le Mignant [15.6%]; Johansson | 40h | 3,000 |
| 220 | 1.3.3.5.2 | **Science Instrument Interfaces to NGAO** | 40d? | 2008-10-06 | 2008-11-28 |  | 341d |  |  |  | 124h | 9,300 |
| 221 | 1.3.3.5.2.1 | Generic Science Instrument ICD to AO | 20d? | 2008-10-06 | 2008-10-31 |  | 361d |  | finish no earlier than 2008-10-31 | Adkins [5%]; Neyman [12.5%]; Lockwood [2.5%]; Kupke [2.5%]; Bell [2.5%] | 40h | 3,000 |
| 222 | 1.3.3.5.2.2 | Generic Science Instrument ICD to NGAO Science Tools | 20d? | 2008-10-06 | 2008-10-31 |  | 361d |  | finish no earlier than 2008-10-31 | Adkins [9.4%]; Le Mignant [9.4%]; Johansson | 40h | 3,000 |
| 223 | 1.3.3.5.2.3 | Interferometer Specific ICD | 20d? | 2008-11-03 | 2008-11-28 |  | 341d |  | finish no earlier than 2008-11-28 | Neyman [7.5%] | 12h | 900 |
| 224 | 1.3.3.5.2.4 | OSIRIS Specific ICD | 20d? | 2008-11-03 | 2008-11-28 |  | 341d |  | start no earlier than 2008-11-03 | Adkins [2.5%]; Kupke [1.2%]; Bell [1.2%] | 8h | 600 |
| 225 | 1.3.3.5.2.5 | NIR Camera Specific ICD | 20d? | 2008-11-03 | 2008-11-28 |  | 341d |  | start no earlier than 2008-11-03 | Adkins [1.2%]; Kupke [0.6%]; Lockwood [0.6%] | 4h | 300 |
| 226 | 1.3.3.5.2.6 | Visible Camera Specific ICD | 20d? | 2008-11-03 | 2008-11-28 |  | 341d |  | start no earlier than 2008-11-03 | Adkins [1.2%]; Kupke [0.6%]; Lockwood [0.6%] | 4h | 300 |
| 227 | 1.3.3.5.2.7 | d-IFS Specific ICD | 20d? | 2008-11-03 | 2008-11-28 |  | 341d |  | start no earlier than 2008-11-03 | Adkins [6.2%]; Wizinowich [2.5%]; Bell [1.2%] | 16h | 1,200 |

Notes:
- 204: EJ
- 205: EJ
- 206: EJ
- 207: EJ
- 208: EJ
- 209: EJ
- 210: DLM
- 215: CN
- 216: CN
- 217: CN
- 218: CN
- 219: DLM
- 220: SA
- 221: CN
- 222: DLM
- 223: CN
- 224: SA
- 225: SA
- 226: SA
- 227: SA

| ID | WBS | Task | Duration | Start | Finish | Total slack | Constraint | Resources | Work | Cost |
| --- | --- | --- | --- | --- | --- | --- | --- | --- | --- | --- |
| 228 | 1.3.3.6 | **Internal Interface Control** | 100d? | 2008-08-04 | 2008-12-19 | 326d |  |  | 280h | 21,000 |
| 229 | 1.3.3.6.1 | Diagram & Document Draft Outline | 40d? | 2008-08-04 | 2008-09-26 | 386d | finish no earlier than 2008-09-26 | Neyman [12.5%]; Wizinowich [3.1%] | 50h | 3,750 |
| 230 | 1.3.3.6.2 | Interface N-Squared Diagram | 25d? | 2008-10-06 | 2008-11-07 | 356d | start no earlier than 2008-10-06 | Other [50%] | 100h | 7,500 |
| 231 | 1.3.3.6.3 | Interface Definition Document | 40d? | 2008-10-27 | 2008-12-19 | 326d | start no earlier than 2008-10-27 | Other [40.6%] | 130h | 9,750 |
| 232 | 1.3.3.7 | **Configuration Control** | 15d? | 2009-10-05 | 2009-10-23 | 106d |  |  | 218h | 16,350 |
| 233 | 1.3.3.7.1 | Change Control Guidelines & Tools Definition | 15d? | 2009-10-05 | 2009-10-23 | 106d | finish no earlier than 2009-10-23 | Wetherell [60.6%]; Johansson; Gavel [50%]; Dekany [50%]; Bell | 218h | 16,350 |
| 234 | 1.3.3.8 | **Documentation Control** | 5d? | 2009-01-12 | 2009-01-16 | 306d |  |  | 20h | 1,500 |
| 235 | 1.3.3.8.1 | Document Control Guidelines & Tools Definition | 5d? | 2009-01-12 | 2009-01-16 | 306d | finish no earlier than 2009-01-16 | Johansson [50%] | 20h | 1,500 |
| 236 | 1.3.3.9 | **Technical Risk Assessment & Mitigation** | 250d? | 2008-09-15 | 2009-08-28 | 146d |  |  | 700h | 52,500 |
| 237 | 1.3.3.9.1 | **Risk Assessment** | 229.2d? | 2008-10-13 | 2009-08-28 | 146d |  |  | 100h | 7,500 |
| 238 | 1.3.3.9.1.1 | Risk Assessment v1 | 13.2d? | 2008-10-13 | 2008-10-30 | 362d | finish no earlier than 2008-10-30 | Wizinowich [28.4%]; Dekany [28.4%] | 50h | 3,750 |
| 239 | 1.3.3.9.1.2 | Risk Assessment v2 | 12d? | 2009-08-13 | 2009-08-28 | 146d | finish no earlier than 2009-08-28 | Wizinowich [31.2%]; Dekany [31.2%] | 50h | 3,750 |
| 240 | 1.3.3.9.2 | **Risk Mitigation Efforts** | 150d? | 2008-09-15 | 2009-04-10 | 246d |  |  | 600h | 45,000 |
| 241 | 1.3.3.9.2.1 | **PSF Calibration** | 100d? | 2008-09-15 | 2009-01-30 | 296d |  |  | 200h | 15,000 |
| 242 | 1.3.3.9.2.1.1 | Support/Monitor Profiler Implementation | 100d? | 2008-09-15 | 2009-01-30 | 296d | start no earlier than 2008-09-15 | Neyman [22.5%]; Wizinowich [2.5%] | 200h | 15,000 |
| 243 | 1.3.3.9.2.2 | **Sky Coverage** | 135d? | 2008-10-06 | 2009-04-10 | 246d |  |  | 400h | 30,000 |
| 244 | 1.3.3.9.2.2.1 | Prototype NIR Tip/tilt Sensor | 135d? | 2008-10-06 | 2009-04-10 | 246d | start no earlier than 2008-10-06 | Zolkower [12%]; Velur [12%]; Britton [13%] | 400h | 30,000 |
| 245 | 1.3.3.10 | Preliminary Design Manual | 101.67d? | 2009-08-03 | 2009-12-22 | 64.33d | start no earlier than 2009-08-03 | Wizinowich [9.8%]; Dekany [4.4%]; Gavel [2.2%]; Reinig [0.2%]; Velur [0.4%]; Neyman [0.2%]; Le Mignant [0.4%]; Johansson [0.4%]; Kupke [0.2%]; Lockwood [0.2%] | 120h | 9,000 |
| 246 | 1.3.4 | **AO System Design** | 425d? | 2008-05-12 | 2009-12-25 | 61d |  |  | 10981h | 823,574.97 |
| 247 | 1.3.4.1 | AO Enclosure | 130d? | 2008-10-01 | 2009-03-31 | 254d | finish no earlier than 2009-03-31 | Bell [28.8%] | 300h | 22,500 |
| 248 | 1.3.4.2 | **Opto-Mechanical** | 371d? | 2008-06-02 | 2009-11-02 | 100d |  |  | 5609h | 420,674.97 |
| 249 | 1.3.4.2.1 | AO Support Structure | 50d? | 2008-11-03 | 2009-01-09 | 311d | start no earlier than 2008-11-03 | Lockwood [40%] | 160h | 12,000 |
| 250 | 1.3.4.2.2 | Rotator | 12.5d? | 2009-03-12 | 2009-03-30 | 255d | finish no earlier than 2009-03-30 | Lockwood; Kupke [20%] | 120h | 9,000 |
| 251 | 1.3.4.2.3 | Optical Relays | 80d? | 2008-12-29 | 2009-04-17 | 241d | start no earlier than 2008-12-28 | Lockwood [33.3%]; Kupke [50%] | 533h | 39,975 |
| 252 | 1.3.4.2.4 | Optical Switchyard | 70d? | 2008-08-04 | 2008-11-07 | 356d | finish no earlier than 2008-11-07 | Lockwood [42.9%]; Kupke [28.6%] | 400h | 30,000 |

Notes:
- 228: CN
- 229: CN
- 232: EJ
- 234: EJ
- 236: PW
- 237: PW
- 238: PW
- 239: PW
- 240: PW
- 242: CN
- 244: VV
- 245: PW
- 246: DG
- 247: JB
- 248: DG
- 249: CL
- 250: CL
- 251: RK
- 252: RK

| ID | WBS | Task | Duration | Start | Finish | Predecessors | Total slack | Free slack | Constraint | Resources | Work | Cost |
| --- | --- | --- | --- | --- | --- | --- | --- | --- | --- | --- | --- | --- |
| 253 | 1.3.4.2.5 | **LGS Wavefront Sensor Assembly** | 201.83d? | 2008-06-02 | 2009-03-10 |  | 269.17d |  |  |  | 1600h | 119,999.98 |
| 254 | 1.3.4.2.5.1 | Review concept design for LGS WFS assembly (includes OSM) | 20d? | 2008-06-02 | 2008-06-27 |  | 269.17d | 0d | start no earlier than 2008-06-02 | Zolkower [25%]; Britton [25%]; Velur [25%] | 120h | 9,000 |
| 255 | 1.3.4.2.5.2 | Develop to preliminary design level the opto-mechanical design for the LGS wavefront sensor unit. | 70d? | 2008-06-30 | 2008-10-03 | 254 | 269.17d | 0d |  | Zolkower [25%]; Velur [25%]; Britton [25%] | 420h | 31,500 |
| 256 | 1.3.4.2.5.3 | Identify the issues with uplink TTM, asterism generation and OSM concepts to ensure it conforms to the dithering requirements. This is important when the LGSs have to move with the source | 19.25d? | 2008-10-06 | 2008-10-31 | 255 | 269.17d | 0d |  | Velur [18.7%]; Britton [50%] | 100h | 7,499.98 |
| 257 | 1.3.4.2.5.4 | Develop to preliminary design level the opto-mechanical design for the LGS OSM. (overlaps with TT(FA) OSMs; hence costed there) | 10d? | 2008-11-03 | 2008-11-14 | 256 | 269.17d | 0d | start no earlier than 2008-09-15 | Zolkower [25%]; Velur [25%] | 40h | 3,000 |
| 258 | 1.3.4.2.5.5 | Package and model the assembly. | 20d? | 2008-11-17 | 2008-12-25 | 257 | 269.17d | 0d |  | Zolkower [50%]; Velur [75%] | 200h | 15,000 |
| 259 | 1.3.4.2.5.6 | Develop background model and work out stray LGS light problems. | 13.33d? | 2008-12-25 | 2009-01-13 | 258 | 309.33d |  |  | Britton [75%] | 80h | 6,000 |
| 260 | 1.3.4.2.5.7 | Identify the motion control needs and specify solutions. | 20d? | 2008-12-25 | 2009-01-22 | 258 | 269.17d | 0d |  | Johansson [50%]; Hale [50%]; Velur [50%] | 240h | 18,000 |
| 261 | 1.3.4.2.5.8 | Identify design risks and mitigation of the identified risks. | 4.5d? | 2009-01-22 | 2009-01-28 | 260 | 269.17d | 0d |  | Zolkower [75%]; Britton [75%]; Velur [75%] | 80h | 6,000 |
| 262 | 1.3.4.2.5.9 | Develop a preliminary integration plan for the assembly. | 9d? | 2009-01-28 | 2009-02-10 | 261 | 269.17d | 0d |  | Britton [75%]; Zolkower [75%]; Velur [75%] | 160h | 12,000 |
| 263 | 1.3.4.2.5.10 | LGS WFS Assembly Documentation | 20d? | 2009-02-10 | 2009-03-10 | 262 | 269.17d |  |  | Zolkower [50%]; Velur [50%] | 160h | 12,000 |
| 264 | 1.3.4.2.6 | **NGS WFS/TWFS Assembly** | 143d? | 2009-04-16 | 2009-11-02 |  | 100d |  |  |  | 712h | 53,400 |
| 265 | 1.3.4.2.6.1 | Review concept design for NGS WFS and TWFS; jointly called NGS WFS assembly. | 10d? | 2009-04-16 | 2009-04-29 |  | 129.17d | 0d |  | Zolkower [25%]; Britton [25%] | 40h | 3,000 |
| 266 | 1.3.4.2.6.2 | Develop to preliminary design level the opto-mechanical design for the NGS wavefront sensor assembly. | 28d? | 2009-04-30 | 2009-06-08 | 265 | 129.17d | 0d | start no earlier than 2009-01-19 | Zolkower [50%]; Velur [50%] | 224h | 16,800 |
| 267 | 1.3.4.2.6.3 | Check compliance of design with the design of the field steering mirror assembly. | 14d? | 2009-06-09 | 2009-06-26 | 266 | 129.17d | 0d |  | Velur [50%]; Zolkower [50%] | 112h | 8,400 |
| 268 | 1.3.4.2.6.4 | Package and model the NGS WFS assembly. | 17.5d? | 2009-06-29 | 2009-08-20 | 267 | 129.17d | 0d |  | Zolkower [50%]; Velur [50%] | 140h | 10,500 |
| 269 | 1.3.4.2.6.5 | Identify the motion control needs and specify solutions. | 7d? | 2009-08-20 | 2009-08-31 | 268 | 129.17d | 0d |  | Hale [50%]; Johansson [50%] | 56h | 4,200 |
| 270 | 1.3.4.2.6.6 | Identify design risks and mitigation of the identified risks. | 4.67d? | 2009-08-31 | 2009-09-07 | 269 | 129.17d | 0d |  | Velur [75%] | 28h | 2,100 |
| 271 | 1.3.4.2.6.7 | Check compliance with alignment plan for the NGS OSM (written as part of opto-mechanical relay sub-system design effort). | 4.67d? | 2009-09-07 | 2009-09-11 | 270 | 129.17d | 29.17d |  | Zolkower [75%]; Velur [75%] | 56h | 4,200 |
| 272 | 1.3.4.2.6.8 | NGS WFS Assembly Documentation | 7d? | 2009-10-23 | 2009-11-02 | 271 | 100d |  | finish no earlier than 2009-11-02 | Velur [50%]; Zolkower [50%] | 56h | 4,200 |
| 273 | 1.3.4.2.7 | **Low Order Wavefront Sensor Assembly** | 321d? | 2008-08-11 | 2009-11-02 |  | 100d |  |  |  | 1636h | 122,700 |
| 274 | 1.3.4.2.7.1 | Review concept design for LOWFS assembly. | 26.67d? | 2008-08-11 | 2008-09-16 |  | 148d | 0d | start no earlier than 2008-08-11 | Zolkower [15%]; Hale [15%] | 64h | 4,800 |
| 275 | 1.3.4.2.7.2 | Investigate optimum method of dithering based on requirements. | 25.33d? | 2008-09-16 | 2008-10-21 | 274 | 148d | 2d |  | Hale [25.2%]; Dekany [25%]; Britton [25.2%] | 152h | 11,400 |
| 276 | 1.3.4.2.7.3 | Develop to preliminary design level the opto-mechanical design for the tip-tilt and the TTFA-TWFS wavefront sensor units | 24d? | 2009-01-12 | 2009-02-12 | 275 | 147d | 0d |  | Hale [50%]; Zolkower [50%]; Dekany [25%] | 240h | 18,000 |
| 277 | 1.3.4.2.7.4 | Develop to preliminary design level the opto-mechanical design for the LOWFS OSM | 13.33d? | 2009-02-13 | 2009-03-04 | 276 | 147d | 0d |  | Hale [75%]; Zolkower [75%]; Velur [75%] | 240h | 18,000 |
| 278 | 1.3.4.2.7.5 | Make sure that the design doesn't preclude the inclusion of a PSF monitor later | 3.33d? | 2009-03-04 | 2009-03-09 | 277 | 147d | 0d |  | Velur [75%] | 20h | 1,500 |
| 279 | 1.3.4.2.7.6 | Package and model the assembly. | 13.33d? | 2009-03-09 | 2009-03-26 | 278 | 147d | 0d |  | Zolkower [75%]; Velur [75%] | 160h | 12,000 |
| 280 | 1.3.4.2.7.7 | Develop thermal model and work emissivity details of the LOWFS assembly and feed into the overall emissivity budget | 10d? | 2009-03-27 | 2009-04-09 | 279 | 147d | 0d |  | Zolkower [50%] | 40h | 3,000 |
| 281 | 1.3.4.2.7.8 | Identify the motion control needs and specify solutions. | 60d? | 2009-04-10 | 2009-07-02 | 280 | 147d | 0d |  | Johansson [25%]; Hale [25%]; Velur [25%] | 360h | 27,000 |
| 282 | 1.3.4.2.7.9 | Identify design risks and mitigation of the identified risks. | 10d? | 2009-07-03 | 2009-07-16 | 281 | 147d | 0d |  | Hale [50%]; Velur [50%] | 80h | 6,000 |
| 283 | 1.3.4.2.7.10 | Develop a preliminary integration plan for the assembly. | 13.33d? | 2009-07-17 | 2009-08-05 | 282 | 147d | 0d |  | Velur [75%] | 80h | 6,000 |
| 284 | 1.3.4.2.7.11 | Develop a test plan based on the design to test performance | 10d? | 2009-08-05 | 2009-08-19 | 283 | 147d | 47d |  | Hale [75%]; Velur [75%] | 120h | 9,000 |
| 285 | 1.3.4.2.7.12 | LOWFS Assembly Documentation | 6.67d? | 2009-10-23 | 2009-11-02 | 284 | 100d |  | finish no earlier than 2009-11-02 | Hale [75%]; Velur [75%] | 80h | 6,000 |

Notes:
- 253: VV
- 264: VV
- 273: VV

| ID | WBS | Task | Type | Duration | Start | Finish | Total slack | Constraint | Resources | Work | Cost |
| --- | --- | --- | --- | --- | --- | --- | --- | --- | --- | --- | --- |
| 286 | 1.3.4.2.8 | **Tip/Tilt Vibration Mitigation** |  | 40d? | 2008-07-07 | 2008-08-29 | 406d |  |  | 80h | 6,000 |
| 287 | 1.3.4.2.8.1 | TT Vibration Mitigation Analysis |  | 40d? | 2008-07-07 | 2008-08-29 | 406d | start no earlier than 2008-07-07 | Neyman [25%] | 80h | 6,000 |
| 288 | 1.3.4.2.9 | **Acquisition Cameras** |  | 305d? | 2008-09-01 | 2009-10-30 | 101d |  |  | 128h | 9,600 |
| 289 | 1.3.4.2.9.1 | Implementation Issues |  | 20d? | 2008-09-01 | 2008-09-26 | 386d | start no earlier than 2008-09-01 | Neyman [12.5%]; Le Mignant [12.5%] | 40h | 3,000 |
| 290 | 1.3.4.2.9.2 | Opto-Mechanical Design |  | 20d? | 2009-10-01 | 2009-10-30 | 101d | start no earlier than 2009-10-01 | Neyman [35%]; Panteleev [10%]; Lockwood [10%] | 88h | 6,600 |
| 291 | 1.3.4.2.10 | **Atmospheric Dispersion Correctors** |  | 96d? | 2008-10-17 | 2009-02-27 | 276d |  |  | 240h | 18,000 |
| 292 | 1.3.4.2.10.1 | LOWFS ADCs |  | 10d? | 2008-10-17 | 2008-10-30 | 362d | finish no earlier than 2008-10-30 | Kupke; Lockwood [75%] | 140h | 10,500 |
| 293 | 1.3.4.2.10.2 | NIR Science ADC |  | 5d? | 2008-12-24 | 2008-12-30 | 319d | finish no earlier than 2008-12-30 | Kupke; Lockwood [25%] | 50h | 3,750 |
| 294 | 1.3.4.2.10.3 | Visible Science & NGS WFS ADC |  | 5d? | 2009-02-23 | 2009-02-27 | 276d | finish no earlier than 2009-02-27 | Kupke; Lockwood [25%] | 50h | 3,750 |
| 295 | 1.3.4.3 | **Alignment, Calibration & Diagnostics** |  | 90d? | 2009-02-02 | 2009-06-05 | 206d |  |  | 505h | 37,875 |
| 296 | 1.3.4.3.1 | **Simulator** |  | 45d? | 2009-02-02 | 2009-04-03 | 251d |  |  | 250h | 18,750 |
| 297 | 1.3.4.3.1.1 | Simulator Requirements & Interfaces |  | 10d? | 2009-02-02 | 2009-02-13 | 286d | finish no earlier than 2009-02-13 | Neyman [50%]; Wizinowich [12.5%] | 50h | 3,750 |
| 298 | 1.3.4.3.1.2 | Simulator Optical Design |  | 10d? | 2009-02-16 | 2009-02-27 | 276d | finish no earlier than 2009-02-27 | Neyman [12.5%]; Wizinowich [50%] | 50h | 3,750 |
| 299 | 1.3.4.3.1.3 | Simulator Mechanical Design |  | 10d? | 2009-03-02 | 2009-03-13 | 266d | finish no earlier than 2009-03-13 | Neyman [12.5%]; Bell [62.5%] | 60h | 4,500 |
| 300 | 1.3.4.3.1.4 | Simulator Electrical Design |  | 10d? | 2009-03-09 | 2009-03-20 | 261d | finish no earlier than 2009-03-20 | Neyman [25%]; Wetherell [37.5%] | 50h | 3,750 |
| 301 | 1.3.4.3.1.5 | Simulator Assembly, Alignment & Test Plans |  | 10d? | 2009-03-23 | 2009-04-03 | 251d | start no earlier than 2009-03-23 | Neyman [50%] | 40h | 3,000 |
| 302 | 1.3.4.3.2 | **System Alignment Tools** |  | 45d? | 2009-04-06 | 2009-06-05 | 206d |  |  | 255h | 19,125 |
| 303 | 1.3.4.3.2.1 | Alignment Requirements & Interfaces |  | 10d? | 2009-04-06 | 2009-04-17 | 241d | finish no earlier than 2009-04-17 | Neyman [50%]; Kupke [12.5%]; Wizinowich [12.5%] | 60h | 4,500 |
| 304 | 1.3.4.3.2.2 | Alignment Optical Design |  | 10d? | 2009-04-20 | 2009-05-01 | 231d | finish no earlier than 2009-05-01 | Neyman [12.5%]; Kupke [50%] | 50h | 3,750 |
| 305 | 1.3.4.3.2.3 | Alignment Mechanical Design |  | 10d? | 2009-05-04 | 2009-05-15 | 221d | finish no earlier than 2009-05-15 | Neyman [12.5%]; Lockwood [50%] | 50h | 3,750 |
| 306 | 1.3.4.3.2.4 | Alignment Electrical Design |  | 10d? | 2009-05-11 | 2009-05-22 | 216d | finish no earlier than 2009-05-22 | Neyman [25%]; Wetherell [18.8%] | 35h | 2,625 |
| 307 | 1.3.4.3.2.5 | Alignment Assembly, Alignment & Test Plans |  | 10d? | 2009-05-25 | 2009-06-05 | 206d | finish no earlier than 2009-06-05 | Neyman [50%]; Kupke [12.5%]; Wizinowich [12.5%] | 60h | 4,500 |
| 308 | 1.3.4.4 | **Non-real-time Control** |  | 140d? | 2009-01-05 | 2009-07-17 | 176d |  |  | 1010h | 75,750 |
| 309 | 1.3.4.4.1 | **AO Sequencer** |  | 20d? | 2009-02-02 | 2009-02-27 | 276d |  |  | 140h | 10,500 |
| 310 | 1.3.4.4.1.1 | AO Sequencer: Architecture |  | 20d? | 2009-02-02 | 2009-02-27 | 276d | finish no earlier than 2009-02-27 | Johansson [50%] | 80h | 6,000 |
| 311 | 1.3.4.4.1.2 | AO Sequencer: Interface Control Document |  | 20d? | 2009-02-02 | 2009-02-27 | 276d | finish no earlier than 2009-02-27 | Johansson [12.5%] | 20h | 1,500 |
| 312 | 1.3.4.4.1.3 | AO Sequencer: Software Module Design |  | 20d? | 2009-02-02 | 2009-02-27 | 276d | finish no earlier than 2009-02-27 | Johansson [18.8%] | 30h | 2,250 |
| 313 | 1.3.4.4.1.4 | AO Sequencer: User Interface Design | milestone | 0d? | 2009-02-02 | 2009-02-02 | 296d | start no earlier than 2009-02-02 |  |  |  |
| 314 | 1.3.4.4.1.5 | AO Sequencer: Technical Specifications | milestone | 0d? | 2009-02-02 | 2009-02-02 | 296d | start no earlier than 2009-02-02 |  |  |  |
| 315 | 1.3.4.4.1.6 | AO Sequencer: Compliance Matrix | milestone | 0d? | 2009-02-02 | 2009-02-02 | 296d | start no earlier than 2009-02-02 |  |  |  |
| 316 | 1.3.4.4.1.7 | AO Sequencer: Test Plan | milestone | 0d? | 2009-02-02 | 2009-02-02 | 296d | start no earlier than 2009-02-02 |  |  |  |
| 317 | 1.3.4.4.1.8 | AO Sequencer: Summary Report |  | 20d? | 2009-02-02 | 2009-02-27 | 276d | finish no earlier than 2009-02-27 | Johansson [6.2%] | 10h | 750 |

Notes:
- 286: CN
- 288: CN
- 291: RK
- 295: CN
- 296: CN
- 302: CN
- 308: EJ
- 309: EJ

| ID | WBS | Task | Type | Duration | Start | Finish | Total slack | Constraint | Resources | Work | Cost |
| --- | --- | --- | --- | --- | --- | --- | --- | --- | --- | --- | --- |
| 318 | 1.3.4.4.2 | **AO Motion Control Software** |  | 40d? | 2009-03-02 | 2009-04-24 | 236d |  |  | 230h | 17,250 |
| 319 | 1.3.4.4.2.1 | Motion Control SW: Architecture |  | 40d? | 2009-03-02 | 2009-04-24 | 236d | start no earlier than 2009-03-02 | Johansson [15.6%]; Morrison [9.4%] | 80h | 6,000 |
| 320 | 1.3.4.4.2.2 | Motion Control SW: ICD |  | 40d? | 2009-03-02 | 2009-04-24 | 236d | start no earlier than 2009-03-02 | Johansson [6.2%]; Morrison [6.2%] | 40h | 3,000 |
| 321 | 1.3.4.4.2.3 | Motion Control SW: Module Design |  | 40d? | 2009-03-02 | 2009-04-24 | 236d | start no earlier than 2009-03-02 | Johansson [6.2%]; Morrison [21.9%] | 90h | 6,750 |
| 322 | 1.3.4.4.2.4 | Motion Control SW: User Interface Design | milestone | 0d? | 2009-03-02 | 2009-03-02 | 276d | start no earlier than 2009-03-02 |  |  |  |
| 323 | 1.3.4.4.2.5 | Motion Control SW: Technical Specifications | milestone | 0d? | 2009-03-02 | 2009-03-02 | 276d | start no earlier than 2009-03-02 |  |  |  |
| 324 | 1.3.4.4.2.6 | Motion Control SW: Compliance Matrix | milestone | 0d? | 2009-03-02 | 2009-03-02 | 276d | start no earlier than 2009-03-02 |  |  |  |
| 325 | 1.3.4.4.2.7 | Motion Control SW: Test Plan | milestone | 0d? | 2009-03-02 | 2009-03-02 | 276d | start no earlier than 2009-03-02 |  |  |  |
| 326 | 1.3.4.4.2.8 | Motion Control SW: Summary Report |  | 40d? | 2009-03-02 | 2009-04-24 | 236d | finish no earlier than 2009-04-24 | Johansson [6.2%] | 20h | 1,500 |
| 327 | 1.3.4.4.3 | **AO Device Control Software** |  | 55d? | 2009-05-04 | 2009-07-17 | 176d |  |  | 240h | 18,000 |
| 328 | 1.3.4.4.3.1 | Device Control: Software Architecture |  | 20d? | 2009-05-04 | 2009-05-29 | 211d | finish no earlier than 2009-05-29 | Morrison [50%] | 80h | 6,000 |
| 329 | 1.3.4.4.3.2 | Device Control: Interface Control Document |  | 15d? | 2009-05-25 | 2009-06-12 | 201d | finish no earlier than 2009-06-12 | Morrison [33.3%] | 40h | 3,000 |
| 330 | 1.3.4.4.3.3 | Device Control: Software Module Design |  | 25d? | 2009-06-15 | 2009-07-17 | 176d | finish no earlier than 2009-07-17 | Morrison [50%] | 100h | 7,500 |
| 331 | 1.3.4.4.3.4 | Device Control: User Interface Design | milestone | 0d? | 2009-06-15 | 2009-06-15 | 201d | start no earlier than 2009-06-15 |  |  |  |
| 332 | 1.3.4.4.3.5 | Device Control: Technical Specifications | milestone | 0d? | 2009-06-15 | 2009-06-15 | 201d | start no earlier than 2009-06-15 |  |  |  |
| 333 | 1.3.4.4.3.6 | Device Control: Compliance Matrix | milestone | 0d? | 2009-06-15 | 2009-06-15 | 201d | start no earlier than 2009-06-15 |  |  |  |
| 334 | 1.3.4.4.3.7 | Device Control: Test Plan | milestone | 0d? | 2009-06-15 | 2009-06-15 | 201d | start no earlier than 2009-06-15 |  |  |  |
| 335 | 1.3.4.4.3.8 | Device Control: Summary Report |  | 25d? | 2009-06-15 | 2009-07-17 | 176d | finish no earlier than 2009-07-17 | Morrison [10%] | 20h | 1,500 |
| 336 | 1.3.4.4.4 | **AO Motion Control Electronics** |  | 40d? | 2009-01-05 | 2009-02-27 | 276d |  |  | 240h | 18,000 |
| 337 | 1.3.4.4.4.1 | Motion Control HW: Architecture Trade Study |  | 30d? | 2009-01-05 | 2009-02-13 | 286d | finish no earlier than 2009-02-13 | Wetherell [50%] | 120h | 9,000 |
| 338 | 1.3.4.4.4.2 | Motion Control HW: Electronics Specification & Selection |  | 30d? | 2009-01-19 | 2009-02-27 | 276d | finish no earlier than 2009-02-27 | Wetherell [25%] | 60h | 4,500 |
| 339 | 1.3.4.4.4.3 | Motion Control HW: Spreadsheet |  | 30d? | 2009-01-19 | 2009-02-27 | 276d | finish no earlier than 2009-02-27 | Wetherell [25%] | 60h | 4,500 |
| 340 | 1.3.4.4.4.4 | Motion Control HW: Compliance Matrix | milestone | 0d? | 2009-01-05 | 2009-01-05 | 316d | start no earlier than 2009-01-05 | Wetherell |  |  |
| 341 | 1.3.4.4.4.5 | Motion Control HW: Test Plan | milestone | 0d? | 2009-01-05 | 2009-01-05 | 316d | start no earlier than 2009-01-05 | Wetherell |  |  |
| 342 | 1.3.4.4.4.6 | Motion Control HW: Summary Report | milestone | 0d? | 2009-01-05 | 2009-01-05 | 316d | start no earlier than 2009-01-05 | Wetherell |  |  |

Notes:
- 318: EJ
- 327: DM
- 336: EW

| ID | WBS | Task | Type | Duration | Start | Finish | Total slack | Constraint | Resources | Work | Cost |
| --- | --- | --- | --- | --- | --- | --- | --- | --- | --- | --- | --- |
| 343 | 1.3.4.4.5 | **Non-RTC Lab System Integration & Test** |  | 0d? | 2009-02-02 | 2009-02-02 | 296d |  |  |  |  |
| 344 | 1.3.4.4.5.1 | Non-RTC I&T: Architecture | milestone | 0d? | 2009-02-02 | 2009-02-02 | 296d | start no earlier than 2009-02-02 |  |  |  |
| 345 | 1.3.4.4.5.2 | Non-RTC I&T: Electronics Specification & Selection | milestone | 0d? | 2009-02-02 | 2009-02-02 | 296d | start no earlier than 2009-02-02 |  |  |  |
| 346 | 1.3.4.4.5.3 | Non-RTC I&T: Test Plan | milestone | 0d? | 2009-02-02 | 2009-02-02 | 296d | start no earlier than 2009-02-02 |  |  |  |
| 347 | 1.3.4.4.5.4 | Non-RTC I&T: Summary Report | milestone | 0d? | 2009-02-02 | 2009-02-02 | 296d | start no earlier than 2009-02-02 |  |  |  |
| 348 | 1.3.4.4.6 | **Acquisition, Guiding & Offload (AGO) Control** |  | 47d? | 2009-04-27 | 2009-06-30 | 189d |  |  | 160h | 12,000 |
| 349 | 1.3.4.4.6.1 | AGO: Architecture |  | 47d? | 2009-04-27 | 2009-06-30 | 189d | finish no earlier than 2009-06-30 | Johansson [16%]; Le Mignant | 80h | 6,000 |
| 350 | 1.3.4.4.6.2 | AGO: ICD |  | 47d? | 2009-04-27 | 2009-06-30 | 189d | start no earlier than 2009-04-27 | Johansson [10.6%] | 40h | 3,000 |
| 351 | 1.3.4.4.6.3 | AGO: Software Module Design |  | 47d? | 2009-04-27 | 2009-06-30 | 189d | start no earlier than 2009-04-27 | Johansson [5.3%] | 20h | 1,500 |
| 352 | 1.3.4.4.6.4 | AGO: User Interface | milestone | 0d? | 2009-04-27 | 2009-04-27 | 236d | start no earlier than 2009-04-27 |  |  |  |
| 353 | 1.3.4.4.6.5 | AGO: Technical Specification | milestone | 0d? | 2009-04-27 | 2009-04-27 | 236d | start no earlier than 2009-04-27 |  |  |  |
| 354 | 1.3.4.4.6.6 | AGO: Compliance Matrix | milestone | 0d? | 2009-04-27 | 2009-04-27 | 236d | start no earlier than 2009-04-27 |  |  |  |
| 355 | 1.3.4.4.6.7 | AGO: Test Plan | milestone | 0d? | 2009-04-27 | 2009-04-27 | 236d | start no earlier than 2009-04-27 |  |  |  |
| 356 | 1.3.4.4.6.8 | AGO: Summary Report |  | 47d? | 2009-04-27 | 2009-06-30 | 189d | finish no earlier than 2009-06-30 | Johansson [5.3%] | 20h | 1,500 |
| 357 | 1.3.4.5 | **Real-time Control** |  | 425d? | 2008-05-12 | 2009-12-25 | 61d |  |  | 3357h | 251,775 |
| 358 | 1.3.4.5.1 | **RTC Processor** |  | 425d? | 2008-05-12 | 2009-12-25 | 61d |  |  | 3037h | 227,775 |
| 359 | 1.3.4.5.1.1 | RTC Technical Management |  | 3400h? | 2008-05-12 | 2009-12-25 | 61d | start no earlier than 2008-05-12 | Reinig [10.4%] | 353h | 26,475 |
| 360 | 1.3.4.5.1.2 | Centroid/Wavefront Reconstruction Coding |  | 105d? | 2008-05-12 | 2008-10-03 | 381d | finish no earlier than 2008-10-03 | Electrical Engineer / Programmer [38.6%] | 324h | 24,300 |
| 361 | 1.3.4.5.1.3 | Centroid/Wavefront Reconstruction Testing |  | 46.5d? | 2008-09-08 | 2008-11-11 | 354.5d | start no earlier than 2008-09-08 | Electrical Engineer / Programmer [25%] | 93h | 6,975 |
| 362 | 1.3.4.5.1.4 | Preconditioning & Scaling Coding |  | 75d? | 2008-10-06 | 2009-01-16 | 306d | start no earlier than 2008-10-06 | Electrical Engineer / Programmer [54%] | 324h | 24,300 |
| 363 | 1.3.4.5.1.5 | Preconditioning & Scaling Testing |  | 29.06d? | 2008-12-29 | 2009-02-06 | 291.94d | start no earlier than 2008-12-28 | Electrical Engineer / Programmer [40%] | 93h | 6,975 |
| 364 | 1.3.4.5.1.6 | Low Order WFS Code Design |  | 65d? | 2009-02-09 | 2009-05-08 | 226d | start no earlier than 2009-02-08 | Electrical Engineer / Programmer [62.3%] | 324h | 24,300 |
| 365 | 1.3.4.5.1.7 | Low Order WFS Code Testing |  | 11.62d? | 2009-05-18 | 2009-06-02 | 209.38d | start no earlier than 2009-05-17 | Electrical Engineer / Programmer | 93h | 6,975 |
| 366 | 1.3.4.5.1.8 | Layer Combining & DM Processing Coding |  | 40.5d? | 2009-06-01 | 2009-07-27 | 170.5d | start no earlier than 2009-05-31 | Electrical Engineer / Programmer | 324h | 24,300 |
| 367 | 1.3.4.5.1.9 | Centroid Distance from Camera Issues |  | 25d? | 2009-07-27 | 2009-08-28 | 146d | start no earlier than 2009-07-26 | Electrical Engineer / Programmer [46.5%] | 93h | 6,975 |
| 368 | 1.3.4.5.1.10 | Radial versus Rectilinear Voxels |  | 72.19d? | 2008-11-03 | 2009-02-11 | 288.81d | start no earlier than 2008-11-03 | Electrical Engineer / Programmer [40%] | 231h | 17,325 |
| 369 | 1.3.4.5.1.11 | Define Required Bit Resolution |  | 21.56d? | 2008-05-19 | 2008-06-17 | 459.44d | start no earlier than 2008-05-18 | Electrical Engineer / Programmer [40%] | 69h | 5,175 |
| 370 | 1.3.4.5.1.12 | Characterize SEU |  | 30d? | 2009-08-24 | 2009-10-02 | 121d | start no earlier than 2009-08-23 | Electrical Engineer / Programmer [28.8%] | 69h | 5,175 |
| 371 | 1.3.4.5.1.13 | Power Characterization and Parameter Estimation |  | 11.62d? | 2009-10-05 | 2009-10-20 | 109.38d | start no earlier than 2009-10-04 | Electrical Engineer / Programmer | 93h | 6,975 |
| 372 | 1.3.4.5.1.14 | Voxel Communication Parameters |  | 11.62d? | 2009-11-30 | 2009-12-15 | 69.38d | start no earlier than 2009-11-30 | Electrical Engineer / Programmer | 93h | 6,975 |
| 373 | 1.3.4.5.1.15 | Diagnostic Control & I/O |  | 30d? | 2009-02-02 | 2009-03-13 | 266d | start no earlier than 2009-02-02 | Electrical Engineer / Programmer [48.3%] | 116h | 8,700 |
| 374 | 1.3.4.5.1.16 | Monitoring Control & I/O |  | 40d? | 2009-10-12 | 2009-12-04 | 76d | start no earlier than 2009-10-11 | Electrical Engineer / Programmer [36.2%] | 116h | 8,700 |
| 375 | 1.3.4.5.1.17 | Testing |  | 45d? | 2008-09-29 | 2008-11-28 | 341d | start no earlier than 2008-09-28 | Electrical Engineer / Programmer [25.8%] | 93h | 6,975 |
| 376 | 1.3.4.5.1.18 | Documentation |  | 145d? | 2009-06-08 | 2009-12-25 | 61d | start no earlier than 2009-06-08 | Electrical Engineer / Programmer [11.7%] | 136h | 10,200 |

Notes:
- 348: EJ
- 357: DG
- 358: DG
- 359: MR

| ID | WBS | Task | Duration | Start | Finish | Total slack | Constraint | Resources | Work | Cost |
| --- | --- | --- | --- | --- | --- | --- | --- | --- | --- | --- |
| 377 | 1.3.4.5.2 | **DMs & Tip/Tilt Stages** | 105d? | 2008-10-06 | 2009-02-27 | 276d |  |  | 320h | 24,000 |
| 378 | 1.3.4.5.2.1 | **Woofer DM/TT** | 105d? | 2008-10-06 | 2009-02-27 | 276d |  |  | 132h | 9,900 |
| 379 | 1.3.4.5.2.1.1 | Define Requirements | 20d? | 2008-10-06 | 2008-10-31 | 361d | start no earlier than 2008-10-06 | Gavel [10%] | 16h | 1,200 |
| 380 | 1.3.4.5.2.1.2 | Evaluate Tip/Tilt Mount Options | 30d? | 2008-12-01 | 2009-01-09 | 311d | finish no earlier than 2009-01-09 | Lockwood [16.7%]; Gavel [50%] | 44h | 3,300 |
| 381 | 1.3.4.5.2.1.3 | Evaluate Combined DM & Tip/Tilt Performance | 10d? | 2009-01-12 | 2009-01-23 | 301d | finish no earlier than 2009-01-23 | Gavel [20%] | 16h | 1,200 |
| 382 | 1.3.4.5.2.1.4 | Select Tip/Tilt Mount | 5d? | 2009-01-26 | 2009-01-30 | 296d | finish no earlier than 2009-01-30 | Gavel [10%]; Lockwood | 8h | 600 |
| 383 | 1.3.4.5.2.1.5 | Design Mechanical Package | 10d? | 2009-02-16 | 2009-02-27 | 276d | finish no earlier than 2009-02-27 | Lockwood [50%] | 40h | 3,000 |
| 384 | 1.3.4.5.2.1.6 | Obtain Quotes | 20d? | 2009-01-05 | 2009-01-30 | 296d | finish no earlier than 2009-01-30 | Lockwood [5%] | 8h | 600 |
| 385 | 1.3.4.5.2.2 | **Tweeter DM/TT** | 95d? | 2008-10-06 | 2009-02-13 | 286d |  |  | 48h | 3,600 |
| 386 | 1.3.4.5.2.2.1 | Define Requirements | 20d? | 2008-10-06 | 2008-10-31 | 361d | finish no earlier than 2008-10-31 | Gavel [5%] | 8h | 600 |
| 387 | 1.3.4.5.2.2.2 | Evaluate Options & Select Tip/Tilt Mount | 20d? | 2008-11-03 | 2008-11-28 | 341d | finish no earlier than 2008-11-28 | Lockwood [12.5%]; Gavel [50%] | 28h | 2,100 |
| 388 | 1.3.4.5.2.2.3 | Design Mechanical Package | 10d? | 2009-02-02 | 2009-02-13 | 286d | finish no earlier than 2009-02-13 | Lockwood [10%] | 8h | 600 |
| 389 | 1.3.4.5.2.2.4 | Obtain Quotes | 20d? | 2008-11-03 | 2008-11-28 | 341d | finish no earlier than 2008-11-28 | Gavel [2.5%] | 4h | 300 |
| 390 | 1.3.4.5.2.3 | **LOWFS DM/TT** | 95d? | 2008-10-06 | 2009-02-13 | 286d |  |  | 140h | 10,500 |
| 391 | 1.3.4.5.2.3.1 | Define Requirements including LOWFS Interface | 20d? | 2008-10-06 | 2008-10-31 | 361d | finish no earlier than 2008-10-31 | Gavel [50%]; Velur [12.5%] | 28h | 2,100 |
| 392 | 1.3.4.5.2.3.2 | Evaluate Options & Select Tip/Tilt Mount | 20d? | 2008-11-03 | 2008-11-28 | 341d | finish no earlier than 2008-11-28 | Lockwood [12.5%]; Gavel [50%] | 28h | 2,100 |
| 393 | 1.3.4.5.2.3.3 | Design Mechanical Package | 25d? | 2009-01-12 | 2009-02-13 | 286d | finish no earlier than 2009-02-13 | Lockwood [40%] | 80h | 6,000 |
| 394 | 1.3.4.5.2.3.4 | Obtain Quotes | 20d? | 2008-11-03 | 2008-11-28 | 341d | finish no earlier than 2008-11-28 | Gavel [2.5%] | 4h | 300 |
| 395 | 1.3.4.6 | **AO System Lab I&T** | 40d? | 2009-07-06 | 2009-08-28 | 146d |  |  | 200h | 15,000 |
| 396 | 1.3.4.6.1 | AO System Lab I&T Scope Definition | 10d? | 2009-07-06 | 2009-07-17 | 176d | finish no earlier than 2009-07-17 | Wizinowich [20%] | 16h | 1,200 |
| 397 | 1.3.4.6.2 | AO System Lab Facility Plan | 30d? | 2009-07-20 | 2009-08-28 | 146d | finish no earlier than 2009-08-28 | Neyman [10%] | 24h | 1,800 |
| 398 | 1.3.4.6.3 | AO System Lab Integration Plan | 30d? | 2009-07-20 | 2009-08-28 | 146d | finish no earlier than 2009-08-28 | Neyman [33.3%] | 80h | 6,000 |
| 399 | 1.3.4.6.4 | AO System Lab Test Plan | 25d? | 2009-07-27 | 2009-08-28 | 146d | finish no earlier than 2009-08-28 | Neyman [40%] | 80h | 6,000 |
| 400 | 1.3.5 | **Laser System Design** | 390d? | 2008-05-05 | 2009-10-30 | 101d |  |  | 2484h | 186,300 |
| 401 | 1.3.5.1 | **Laser Enclosure (LE)** | 40d? | 2009-01-19 | 2009-03-13 | 266d |  |  | 160h | 12,000 |
| 402 | 1.3.5.1.1 | LE Requirements & Interfaces | 20d? | 2009-01-19 | 2009-02-13 | 286d | finish no earlier than 2009-02-13 | Chin [12.5%]; Medeiros [12.5%] | 40h | 3,000 |
| 403 | 1.3.5.1.2 | LE Mechanical Design | 10d? | 2009-02-16 | 2009-02-27 | 276d | finish no earlier than 2009-02-27 | Chin; Medeiros [50%] | 50h | 3,750 |
| 404 | 1.3.5.1.3 | LE Environmental Control Design | 10d? | 2009-02-16 | 2009-02-27 | 276d | finish no earlier than 2009-02-27 | Chin; Nance [50%] | 50h | 3,750 |
| 405 | 1.3.5.1.4 | LE Assembly & Test Plans | 10d? | 2009-03-02 | 2009-03-13 | 266d | finish no earlier than 2009-03-13 | Chin; Nance [10%]; Medeiros [10%] | 20h | 1,500 |

Notes:
- 377: DG
- 378: DG
- 385: DG
- 390: DG
- 395: CN
- 396: PW
- 397: CN
- 398: CN
- 399: CN
- 400: CN
- 401: JC
- 402: JC
- 403: DM
- 404: CN
- 405: JC

| ID | WBS | Task | Duration | Start | Finish | Predecessors | Total slack | Free slack | Constraint | Resources | Work | Cost |
| --- | --- | --- | --- | --- | --- | --- | --- | --- | --- | --- | --- | --- |
| 406 | 1.3.5.2 | **Laser** | 280d? | 2008-05-05 | 2009-05-29 |  | 211d |  |  |  | 820h | 61,500 |
| 407 | 1.3.5.2.1 | Laser Project Management | 280d? | 2008-05-05 | 2009-05-29 |  | 211d |  | finish no earlier than 2009-05-29 | Adkins [6.7%]; Kissner [6.7%] | 300h | 22,500 |
| 408 | 5.2.3.1 | **Laser Requirements** | 110d | 2008-05-05 | 2008-10-03 |  | 211d |  |  |  | 160h | 12,000 |
| 409 | 5.2.3.1.1 | Laser Performance Analysis | 20d | 2008-05-05 | 2008-05-30 |  | 211d | 0d | start no earlier than 2008-05-05 | Adkins [25%] | 40h | 3,000 |
| 410 | 5.2.3.1.2 | Laser Requirements Analysis | 20d | 2008-06-02 | 2008-06-27 | 409 | 211d | 0d |  | Adkins [25%] | 40h | 3,000 |
| 411 | 5.2.3.1.3 | Laser Requirements Development | 20d | 2008-06-30 | 2008-07-25 | 410 | 211d | 0d |  | Adkins [25%] | 40h | 3,000 |
| 412 | 5.2.3.1.4 | Laser Requirements Drafting and Revisions | 50d | 2008-07-28 | 2008-10-03 | 411 | 211d | 0d |  | Adkins [10%] | 40h | 3,000 |
| 413 | 5.2.3.2 | **Laser Preliminary ICD** | 20d | 2008-07-28 | 2008-08-22 |  | 411d |  |  |  | 40h | 3,000 |
| 414 | 5.2.3.2.1 | Laser ICD Drafting and Revisions | 20d | 2008-07-28 | 2008-08-22 | 411 | 411d |  |  | Adkins [25%] | 40h | 3,000 |
| 415 | 5.2.3.3 | **Laser Request for Proposals (RFP)** | 90d | 2008-10-06 | 2009-02-06 |  | 211d |  |  |  | 120h | 9,000 |
| 416 | 5.2.3.3.1 | Laser Proposal Drafting | 20d | 2008-10-06 | 2008-10-31 | 412 | 211d | 0d |  | Adkins [25%] | 40h | 3,000 |
| 417 | 5.2.3.3.2 | Laser Proposal Release | 10d | 2008-11-03 | 2008-11-14 | 416 | 211d | 0d |  | Adkins [25%]; Kissner [30%] | 40h | 3,000 |
| 418 | 5.2.3.3.3 | Laser Proposal Response Period | 3mo | 2008-11-17 | 2009-02-06 | 417 | 211d | 0d |  | Adkins [3.3%]; Kissner [5%] | 40h | 3,000 |
| 419 | 5.2.3.4 | **Laser RFP Response Report** | 40d | 2009-02-09 | 2009-04-03 |  | 211d |  |  |  | 120h | 9,000 |
| 420 | 5.2.3.4.1 | Laser Proposal Evaluation | 20d | 2009-02-09 | 2009-03-06 | 418 | 211d | 0d |  | Adkins [25%] | 40h | 3,000 |
| 421 | 5.2.3.4.2 | Laser Response Discussions | 20d | 2009-03-09 | 2009-04-03 | 420 | 251d |  |  | Adkins [25%] | 40h | 3,000 |
| 422 | 5.2.3.4.3 | Laser Report Drafting and Revisions | 20d | 2009-03-09 | 2009-04-03 | 420 | 211d | 0d |  | Adkins [25%] | 40h | 3,000 |
| 423 | 5.2.3.5 | **Laser Contract** | 40d | 2009-04-06 | 2009-05-29 |  | 211d |  |  |  | 80h | 6,000 |
| 424 | 5.2.3.5.1 | Laser Contract Drafting and Revisions | 20d | 2009-04-06 | 2009-05-01 | 422 | 211d | 0d |  | Adkins [25%] | 40h | 3,000 |
| 425 | 5.2.3.5.2 | Laser Contract Negotiations | 20d | 2009-05-04 | 2009-05-29 | 424 | 211d |  |  | Adkins [25%] | 40h | 3,000 |
| 426 | 1.3.5.3 | **Laser Launch Facility (LLF)** | 170d? | 2009-01-19 | 2009-09-11 |  | 136d |  |  |  | 856h | 64,200 |
| 427 | 1.3.5.3.1 | LLF Requirements & Interfaces | 20d? | 2009-01-19 | 2009-02-13 |  | 286d |  | finish no earlier than 2009-02-13 | Neyman [50%]; Chin | 100h | 7,500 |
| 428 | 1.3.5.3.2 | LLF Optical Design | 53d? | 2009-04-01 | 2009-06-12 |  | 201d |  | finish no earlier than 2009-06-12 | Neyman [14.2%]; Panteleev [47.2%] | 260h | 19,500 |
| 429 | 1.3.5.3.3 | LLF Launch Telescope Preliminary Design Contract | 100d? | 2009-03-16 | 2009-07-31 |  | 166d |  | start no earlier than 2009-03-16 | Neyman [9%]; Chin [3%] | 96h | 7,200 |
| 430 | 1.3.5.3.4 | LLF Mechanical Design | 45d? | 2009-06-01 | 2009-07-31 |  | 166d |  | finish no earlier than 2009-07-31 | Neyman; Medeiros [55.6%] | 220h | 16,500 |
| 431 | 1.3.5.3.5 | LLF Electrical Design | 30d? | 2009-07-20 | 2009-08-28 |  | 146d |  | finish no earlier than 2009-08-28 | Neyman; Wetherell [41.7%] | 120h | 9,000 |
| 432 | 1.3.5.3.6 | LLF Assembly, Alignment & Test Plans | 10d? | 2009-08-31 | 2009-09-11 |  | 136d |  | finish no earlier than 2009-09-11 | Neyman [62.5%]; Chin | 60h | 4,500 |

Notes:
- 406: SA
- 407: SA
- 408: SA
- 413: SA
- 415: SA
- 419: SA
- 423: SA
- 426: CN

| ID | WBS | Task | Duration | Start | Finish | Total slack | Constraint | Resources | Work | Cost |
| --- | --- | --- | --- | --- | --- | --- | --- | --- | --- | --- |
| 433 | 1.3.5.4 | **Laser Safety Systems** | 65d? | 2009-08-03 | 2009-10-30 | 101d |  |  | 170h | 12,750 |
| 434 | 1.3.5.4.1 | **Personnel & Equipment Safety System** | 43d? | 2009-08-03 | 2009-09-30 | 123d |  |  | 130h | 9,750 |
| 435 | 1.3.5.4.1.1 | Safety Requirements & Interfaces | 10d? | 2009-08-03 | 2009-08-14 | 156d | start no earlier than 2009-08-03 | Chin [50%] | 40h | 3,000 |
| 436 | 1.3.5.4.1.2 | Safety Algorithms, Diagrams & Dataflow | 33d? | 2009-08-17 | 2009-09-30 | 123d | start no earlier than 2009-08-17 | Wetherell [7.6%] | 20h | 1,500 |
| 437 | 1.3.5.4.1.3 | Safety Communication Protocols & Methods | 33d? | 2009-08-17 | 2009-09-30 | 123d | start no earlier than 2009-08-17 | Wetherell [7.6%] | 20h | 1,500 |
| 438 | 1.3.5.4.1.4 | Safety Performance Estimate | 33d? | 2009-08-17 | 2009-09-30 | 123d | start no earlier than 2009-08-17 | Wetherell [7.6%] | 20h | 1,500 |
| 439 | 1.3.5.4.1.5 | Safety Electronics, Shutter & Interlocks | 33d? | 2009-08-17 | 2009-09-30 | 123d | start no earlier than 2009-08-17 | Wetherell [3.8%] | 10h | 750 |
| 440 | 1.3.5.4.1.6 | Safety Test Plans | 33d? | 2009-08-17 | 2009-09-30 | 123d | start no earlier than 2009-08-17 | Chin [3.8%]; Wetherell [3.8%] | 20h | 1,500 |
| 441 | 1.3.5.4.2 | **Laser Traffic Control System (LTCS) Modifications** | 20d? | 2009-10-05 | 2009-10-30 | 101d |  |  | 40h | 3,000 |
| 442 | 1.3.5.4.2.1 | LTCS Requirements & Interfaces | 20d? | 2009-10-05 | 2009-10-30 | 101d | start no earlier than 2009-10-05 | Summers [5%] | 8h | 600 |
| 443 | 1.3.5.4.2.2 | LTCS Algorithms, Diagrams & Dataflow | 20d? | 2009-10-05 | 2009-10-30 | 101d | start no earlier than 2009-10-05 | Summers [5%] | 8h | 600 |
| 444 | 1.3.5.4.2.3 | LTCS Communication Protocols & Methods | 20d? | 2009-10-05 | 2009-10-30 | 101d | start no earlier than 2009-10-05 | Summers [5%] | 8h | 600 |
| 445 | 1.3.5.4.2.4 | LTCS Performance Estimate | 20d? | 2009-10-05 | 2009-10-30 | 101d | start no earlier than 2009-10-05 | Summers [5%] | 8h | 600 |
| 446 | 1.3.5.4.2.5 | LTCS Test Plans | 20d? | 2009-10-05 | 2009-10-30 | 101d | start no earlier than 2009-10-05 | Summers [5%] | 8h | 600 |
| 447 | 1.3.5.5 | **Laser System Control (LSC)** | 95d? | 2009-05-04 | 2009-09-11 | 136d |  |  | 430h | 32,250 |
| 448 | 1.3.5.5.1 | **LSC Software** | 53d? | 2009-07-01 | 2009-09-11 | 136d |  |  | 220h | 16,500 |
| 449 | 1.3.5.5.1.1 | LSC Software Requirements & Interfaces | 8d? | 2009-07-01 | 2009-07-10 | 181d | finish no earlier than 2009-07-10 | Johansson; Neyman [46.9%]; Chin | 60h | 4,500 |
| 450 | 1.3.5.5.1.2 | LSC Sequencer Software | 25d? | 2009-07-13 | 2009-08-14 | 156d | finish no earlier than 2009-08-14 | Johansson [40%] | 80h | 6,000 |
| 451 | 1.3.5.5.1.3 | LSC Motion Control Software | 10d? | 2009-08-17 | 2009-08-28 | 146d | finish no earlier than 2009-08-28 | Morrison [50%] | 40h | 3,000 |
| 452 | 1.3.5.5.1.4 | LSC Device Control Software | 10d? | 2009-08-31 | 2009-09-11 | 136d | finish no earlier than 2009-09-11 | Morrison [50%] | 40h | 3,000 |
| 453 | 1.3.5.5.2 | **LSC Hardware** | 30d? | 2009-05-04 | 2009-06-12 | 201d |  |  | 210h | 15,750 |
| 454 | 1.3.5.5.2.1 | LSC Hardware Requirements & Interfaces | 10d? | 2009-05-04 | 2009-05-15 | 221d | finish no earlier than 2009-05-15 | Neyman [37.5%]; Wetherell; Chin | 60h | 4,500 |
| 455 | 1.3.5.5.2.2 | LSC Motion Control Hardware | 10d? | 2009-05-18 | 2009-05-29 | 211d | start no earlier than 2009-05-18 | Wetherell | 80h | 6,000 |
| 456 | 1.3.5.5.2.3 | LSC Device Control Hardware | 10d? | 2009-06-01 | 2009-06-12 | 201d | finish no earlier than 2009-06-12 | Wetherell [87.5%] | 70h | 5,250 |
| 457 | 1.3.5.6 | Laser System Lab I&T Plan | 20d? | 2009-10-05 | 2009-10-30 | 101d | finish no earlier than 2009-10-30 | Neyman [20%]; Chin; Nance | 48h | 3,600 |

Notes:
- 433: JC
- 434: JC
- 441: DS
- 447: EJ
- 448: EJ
- 449: EJ
- 450: EJ
- 451: EJ
- 453: EW
- 454: EW
- 455: EW
- 456: EW
- 457: CN

| ID | WBS | Task | Duration | Start | Finish | Total slack | Constraint | Resources | Work | Cost |
| --- | --- | --- | --- | --- | --- | --- | --- | --- | --- | --- |
| 458 | 1.3.6 | **Science Operations Tools Design** | 349d? | 2008-07-01 | 2009-10-30 | 101d |  |  | 1800h | 135,000 |
| 459 | 1.3.6.1 | **Multi-Systems Command Sequencer (MCS)** | 155d? | 2008-07-01 | 2009-02-02 | 295d |  |  | 620h | 46,500 |
| 460 | 1.3.6.1.1 | **MCS Infrastructure** | 80d? | 2008-07-07 | 2008-10-24 | 366d |  |  | 180h | 13,500 |
| 461 | 1.3.6.1.1.1 | **MCS Infrastructure Architecture** | 80d? | 2008-07-07 | 2008-10-24 | 366d |  |  | 140h | 10,500 |
| 462 | 1.3.6.1.1.1.1 | MCS Architecture | 80d? | 2008-07-07 | 2008-10-24 | 366d | finish no earlier than 2008-10-24 | Johansson [4.7%]; Le Mignant | 40h | 3,000 |
| 463 | 1.3.6.1.1.1.2 | MCS Operations Concept Document | 80d? | 2008-07-07 | 2008-10-24 | 366d | start no earlier than 2008-07-07 | Johansson [6.2%] | 40h | 3,000 |
| 464 | 1.3.6.1.1.1.3 | MCS Software Requirements | 80d? | 2008-07-07 | 2008-10-24 | 366d | start no earlier than 2008-07-07 | Johansson [6.2%] | 40h | 3,000 |
| 465 | 1.3.6.1.1.1.4 | MCS Module Definitions | 80d? | 2008-07-07 | 2008-10-24 | 366d | start no earlier than 2008-07-07 | Johansson [3.1%] | 20h | 1,500 |
| 466 | 1.3.6.1.1.2 | **Coordination Sequence Support Library** | 80d? | 2008-07-07 | 2008-10-24 | 366d |  |  | 20h | 1,500 |
| 467 | 1.3.6.1.1.2.1 | Functional Requirements | 80d? | 2008-07-07 | 2008-10-24 | 366d | start no earlier than 2008-07-07 | Johansson [3.1%] | 20h | 1,500 |
| 468 | 1.3.6.1.1.2.2 | Interface Definitions | 1d? | 2008-07-07 | 2008-07-07 | 445d | start no earlier than 2008-07-07 |  |  |  |
| 469 | 1.3.6.1.1.3 | **Command Interface** | 80d? | 2008-07-07 | 2008-10-24 | 366d |  |  | 10h | 750 |
| 470 | 1.3.6.1.1.3.1 | Functional Requirements | 80d? | 2008-07-07 | 2008-10-24 | 366d | start no earlier than 2008-07-07 | Johansson [1.6%] | 10h | 750 |
| 471 | 1.3.6.1.1.3.2 | Interface Definitions | 1d? | 2008-07-07 | 2008-07-07 | 445d | finish no earlier than 2008-07-07 |  |  |  |
| 472 | 1.3.6.1.1.4 | **System Health** | 80d? | 2008-07-07 | 2008-10-24 | 366d |  |  | 10h | 750 |
| 473 | 1.3.6.1.1.4.1 | Functional Requirements | 80d? | 2008-07-07 | 2008-10-24 | 366d | start no earlier than 2008-07-07 | Johansson [1.6%] | 10h | 750 |
| 474 | 1.3.6.1.1.4.2 | Interface Definitions | 1d? | 2008-07-07 | 2008-07-07 | 445d | start no earlier than 2008-07-07 |  |  |  |
| 475 | 1.3.6.1.2 | **Setup Sequences: Configuration & Calibration** | 89d? | 2008-07-01 | 2008-10-31 | 361d |  |  | 100h | 7,500 |
| 476 | 1.3.6.1.2.1 | **Setup Sequences Common Structure** | 89d? | 2008-07-01 | 2008-10-31 | 361d |  |  | 60h | 4,500 |
| 477 | 1.3.6.1.2.1.1 | Setup Sequences Operations Concept Document | 89d? | 2008-07-01 | 2008-10-31 | 361d | finish no earlier than 2008-10-31 | Johansson [2.8%] | 20h | 1,500 |
| 478 | 1.3.6.1.2.1.2 | Setup Sequences Software Requirements | 89d? | 2008-07-01 | 2008-10-31 | 361d | finish no earlier than 2008-10-31 | Johansson [2.8%] | 20h | 1,500 |
| 479 | 1.3.6.1.2.1.3 | Setup Sequences Module Definitions | 89d? | 2008-07-01 | 2008-10-31 | 361d | finish no earlier than 2008-10-31 | Johansson [2.8%] | 20h | 1,500 |
| 480 | 1.3.6.1.2.2 | **Configuration Sequences** | 89d? | 2008-07-01 | 2008-10-31 | 361d |  |  | 20h | 1,500 |
| 481 | 1.3.6.1.2.2.1 | Functional Requirements | 89d? | 2008-07-01 | 2008-10-31 | 361d | finish no earlier than 2008-10-31 | Le Mignant [2.8%] | 20h | 1,500 |
| 482 | 1.3.6.1.2.2.2 | Interface Definitions | 1d? | 2008-07-01 | 2008-07-01 | 449d | start no earlier than 2008-07-01 |  |  |  |

Notes:
- 458: DLM
- 459: EJ

| ID | WBS | Task | Duration | Start | Finish | Total slack | Constraint | Resources | Work | Cost |
| --- | --- | --- | --- | --- | --- | --- | --- | --- | --- | --- |
| 483 | 1.3.6.1.2.3 | **Calibration Sequences** | 89d? | 2008-07-01 | 2008-10-31 | 361d |  |  | 20h | 1,500 |
| 484 | 1.3.6.1.2.3.1 | Functional Requirements | 89d? | 2008-07-01 | 2008-10-31 | 361d | finish no earlier than 2008-10-31 | Le Mignant [2.8%] | 20h | 1,500 |
| 485 | 1.3.6.1.2.3.2 | Interface Definitions | 1d? | 2008-07-01 | 2008-07-01 | 449d | start no earlier than 2008-07-01 |  |  |  |
| 486 | 1.3.6.1.3 | **Observing Sequences** | 89d? | 2008-10-01 | 2009-02-02 | 295d |  |  | 240h | 18,000 |
| 487 | 1.3.6.1.3.1 | **Observing Sequences Common Structure** | 89d? | 2008-10-01 | 2009-02-02 | 295d |  |  | 120h | 9,000 |
| 488 | 1.3.6.1.3.1.1 | Observing Sequences Operations Concept Document | 89d? | 2008-10-01 | 2009-02-02 | 295d | finish no earlier than 2009-02-02 | Le Mignant [4.2%]; Johansson [1.4%] | 40h | 3,000 |
| 489 | 1.3.6.1.3.1.2 | Observing Sequences Software Requirements | 89d? | 2008-10-01 | 2009-02-02 | 295d | start no earlier than 2008-10-01 | Johansson [5.6%] | 40h | 3,000 |
| 490 | 1.3.6.1.3.1.3 | Observing Sequences Module Definitions | 89d? | 2008-10-01 | 2009-02-02 | 295d | finish no earlier than 2009-02-02 | Johansson [2.8%]; Le Mignant [2.8%] | 40h | 3,000 |
| 491 | 1.3.6.1.3.2 | **Acquisition Sequences** | 89d? | 2008-10-01 | 2009-02-02 | 295d |  |  | 60h | 4,500 |
| 492 | 1.3.6.1.3.2.1 | Functional Requirements | 89d? | 2008-10-01 | 2009-02-02 | 295d | finish no earlier than 2009-02-02 | Le Mignant [4.2%]; Johansson [1.4%] | 40h | 3,000 |
| 493 | 1.3.6.1.3.2.2 | Interface Definitions | 89d? | 2008-10-01 | 2009-02-02 | 295d | finish no earlier than 2009-02-02 | Johansson [2.8%] | 20h | 1,500 |
| 494 | 1.3.6.1.3.3 | **Observing Sequences** | 89d? | 2008-10-01 | 2009-02-02 | 295d |  |  | 20h | 1,500 |
| 495 | 1.3.6.1.3.3.1 | Functional Requirements | 89d? | 2008-10-01 | 2009-02-02 | 295d | finish no earlier than 2009-02-02 | Le Mignant [2.8%] | 20h | 1,500 |
| 496 | 1.3.6.1.3.3.2 | Interface Definitions | 1d? | 2008-10-01 | 2008-10-01 | 383d | start no earlier than 2008-10-01 |  |  |  |
| 497 | 1.3.6.1.3.4 | **Quality Monitoring Sequences** | 89d? | 2008-10-01 | 2009-02-02 | 295d |  |  | 20h | 1,500 |
| 498 | 1.3.6.1.3.4.1 | Functional Requirements | 89d? | 2008-10-01 | 2009-02-02 | 295d | finish no earlier than 2009-02-02 | Le Mignant [2.8%] | 20h | 1,500 |
| 499 | 1.3.6.1.3.4.2 | Interface Definitions | 1d? | 2008-10-01 | 2008-10-01 | 383d | start no earlier than 2008-10-01 |  |  |  |
| 500 | 1.3.6.1.3.5 | **Optimization Sequences** | 89d? | 2008-10-01 | 2009-02-02 | 295d |  |  | 20h | 1,500 |
| 501 | 1.3.6.1.3.5.1 | Functional Requirements | 89d? | 2008-10-01 | 2009-02-02 | 295d | finish no earlier than 2009-02-02 | Le Mignant [2.8%] | 20h | 1,500 |
| 502 | 1.3.6.1.3.5.2 | Interface Definitions | 1d? | 2008-10-01 | 2008-10-01 | 383d | start no earlier than 2008-10-01 |  |  |  |
| 503 | 1.3.6.1.4 | **Alarm Handler & Troubleshooting Sequences** | 89d? | 2008-10-01 | 2009-02-02 | 295d |  |  | 100h | 7,500 |
| 504 | 1.3.6.1.4.1 | **Alarm Handler & Troubleshooting Common Structure** | 89d? | 2008-10-01 | 2009-02-02 | 295d |  |  | 100h | 7,500 |
| 505 | 1.3.6.1.4.1.1 | Alarm & Troubleshooting Operations Concept Document | 89d? | 2008-10-01 | 2009-02-02 | 295d | finish no earlier than 2009-02-02 | Le Mignant [4.2%]; Johansson [1.4%] | 40h | 3,000 |
| 506 | 1.3.6.1.4.1.2 | Alarm & Troubleshooting Software Requirements | 89d? | 2008-10-01 | 2009-02-02 | 295d | finish no earlier than 2009-02-02 | Johansson [2.8%] | 20h | 1,500 |
| 507 | 1.3.6.1.4.1.3 | Alarm & Troubleshooting Module Definitions | 89d? | 2008-10-01 | 2009-02-02 | 295d | finish no earlier than 2009-02-02 | Johansson [2.8%]; Le Mignant [2.8%] | 40h | 3,000 |

| ID | WBS | Task | Duration | Start | Finish | Total slack | Constraint | Resources | Work | Cost |
| --- | --- | --- | --- | --- | --- | --- | --- | --- | --- | --- |
| 508 | 1.3.6.1.4.2 | **Alarm Handler Sequences** | 1d? | 2008-10-01 | 2008-10-01 | 383d |  |  |  |  |
| 509 | 1.3.6.1.4.2.1 | Functional Requirements | 1d? | 2008-10-01 | 2008-10-01 | 383d | start no earlier than 2008-10-01 |  |  |  |
| 510 | 1.3.6.1.4.2.2 | Interface Definitions | 1d? | 2008-10-01 | 2008-10-01 | 383d | start no earlier than 2008-10-01 |  |  |  |
| 511 | 1.3.6.1.4.3 | **Troubleshooting Sequences** | 1d? | 2008-10-01 | 2008-10-01 | 383d |  |  |  |  |
| 512 | 1.3.6.1.4.3.1 | Functional Requirements | 1d? | 2008-10-01 | 2008-10-01 | 383d | start no earlier than 2008-10-01 |  |  |  |
| 513 | 1.3.6.1.4.3.2 | Interface Definitions | 1d? | 2008-10-01 | 2008-10-01 | 383d | start no earlier than 2008-10-01 |  |  |  |
| 514 | 1.3.6.2 | **User Interfaces** | 239d? | 2008-07-01 | 2009-05-29 | 211d |  |  | 500h | 37,500 |
| 515 | 1.3.6.2.1 | **User Interface (UI) Infrastructure** | 89d? | 2008-07-01 | 2008-10-31 | 361d |  |  | 180h | 13,500 |
| 516 | 1.3.6.2.1.1 | **UI Infrastructure Architecture** | 89d? | 2008-07-01 | 2008-10-31 | 361d |  |  | 120h | 9,000 |
| 517 | 1.3.6.2.1.1.1 | UI Architecture | 89d? | 2008-07-01 | 2008-10-31 | 361d | finish no earlier than 2008-10-31 | Johansson [4.9%]; Le Mignant | 40h | 3,000 |
| 518 | 1.3.6.2.1.1.2 | UI Operations Concept Document | 89d? | 2008-07-01 | 2008-10-31 | 361d | finish no earlier than 2008-10-31 | Le Mignant [2.8%]; Johansson [2.8%] | 40h | 3,000 |
| 519 | 1.3.6.2.1.1.3 | UI Software Requirements | 89d? | 2008-07-01 | 2008-10-31 | 361d | finish no earlier than 2008-10-31 | Johansson [2.8%] | 20h | 1,500 |
| 520 | 1.3.6.2.1.1.4 | UI Module Definitions | 89d? | 2008-07-01 | 2008-10-31 | 361d | finish no earlier than 2008-10-31 | Johansson [2.8%] | 20h | 1,500 |
| 521 | 1.3.6.2.1.2 | **UI Command Interface to MCS** | 89d? | 2008-07-01 | 2008-10-31 | 361d |  |  | 40h | 3,000 |
| 522 | 1.3.6.2.1.2.1 | Functional Requirements | 89d? | 2008-07-01 | 2008-10-31 | 361d | finish no earlier than 2008-10-31 | Johansson [2.8%] | 20h | 1,500 |
| 523 | 1.3.6.2.1.2.2 | Interface Definitions | 89d? | 2008-07-01 | 2008-10-31 | 361d | finish no earlier than 2008-10-31 | Johansson [2.8%] | 20h | 1,500 |
| 524 | 1.3.6.2.1.3 | **UI Command Interface to Pre- & Post-Observing Tools** | 89d? | 2008-07-01 | 2008-10-31 | 361d |  |  | 20h | 1,500 |
| 525 | 1.3.6.2.1.3.1 | Functional Requirements | 89d? | 2008-07-01 | 2008-10-31 | 361d | finish no earlier than 2008-10-31 | Johansson [2.8%] | 20h | 1,500 |
| 526 | 1.3.6.2.1.3.2 | Interface Definitions | 89d? | 2008-07-01 | 2008-10-31 | 361d | finish no earlier than 2008-10-31 |  |  |  |
| 527 | 1.3.6.2.2 | **Setup User Interfaces** | 130d? | 2008-10-01 | 2009-03-31 | 254d |  |  | 80h | 6,000 |
| 528 | 1.3.6.2.2.1 | **Setup UI Common Structure** | 130d? | 2008-10-01 | 2009-03-31 | 254d |  |  | 50h | 3,750 |
| 529 | 1.3.6.2.2.1.1 | Setup UI Operations Concept Document | 130d? | 2008-10-01 | 2009-03-31 | 254d | start no earlier than 2008-10-01 | Le Mignant [1.9%] | 20h | 1,500 |
| 530 | 1.3.6.2.2.1.2 | Setup UI Software Requirements | 130d? | 2008-10-01 | 2009-03-31 | 254d | finish no earlier than 2009-03-31 | Johansson [1%] | 10h | 750 |
| 531 | 1.3.6.2.2.1.3 | Setup UI Module Definitions | 130d? | 2008-10-01 | 2009-03-31 | 254d | finish no earlier than 2009-03-31 | Johansson [1.9%] | 20h | 1,500 |

Notes:
- 514: DLM

| ID | WBS | Task | Duration | Start | Finish | Total slack | Constraint | Resources | Work | Cost |
| --- | --- | --- | --- | --- | --- | --- | --- | --- | --- | --- |
| 532 | 1.3.6.2.2.2 | **Setup UI Configurations** | 130d? | 2008-10-01 | 2009-03-31 | 254d |  |  | 15h | 1,125 |
| 533 | 1.3.6.2.2.2.1 | Functional Requirements | 130d? | 2008-10-01 | 2009-03-31 | 254d | finish no earlier than 2009-03-31 | Le Mignant [1.4%] | 15h | 1,125 |
| 534 | 1.3.6.2.2.2.2 | Interface Definitions | 130d? | 2008-10-01 | 2009-03-31 | 254d | finish no earlier than 2009-03-31 |  |  |  |
| 535 | 1.3.6.2.2.3 | **Setup UI Calibrations** | 130d? | 2008-10-01 | 2009-03-31 | 254d |  |  | 15h | 1,125 |
| 536 | 1.3.6.2.2.3.1 | Functional Requirements | 130d? | 2008-10-01 | 2009-03-31 | 254d | finish no earlier than 2009-03-31 | Le Mignant [1.4%] | 15h | 1,125 |
| 537 | 1.3.6.2.2.3.2 | Interface Definitions | 130d? | 2008-10-01 | 2009-03-31 | 254d | finish no earlier than 2009-03-31 |  |  |  |
| 538 | 1.3.6.2.3 | **Observations User Interfaces** | 173d? | 2008-10-01 | 2009-05-29 | 211d |  |  | 240h | 18,000 |
| 539 | 1.3.6.2.3.1 | **Observations UI Common Structure** | 173d? | 2008-10-01 | 2009-05-29 | 211d |  |  | 130h | 9,750 |
| 540 | 1.3.6.2.3.1.1 | Observations UI Operations Concept Document | 173d? | 2008-10-01 | 2009-05-29 | 211d | finish no earlier than 2009-05-29 | Le Mignant [2.2%]; Johansson | 40h | 3,000 |
| 541 | 1.3.6.2.3.1.2 | Observations UI Software Requirements | 173d? | 2008-10-01 | 2009-05-29 | 211d | finish no earlier than 2009-05-29 | Johansson [0.7%] | 10h | 750 |
| 542 | 1.3.6.2.3.1.3 | Observations UI Module Definitions | 173d? | 2008-10-01 | 2009-05-29 | 211d | finish no earlier than 2009-05-29 | Johansson [2.9%]; Le Mignant [2.9%] | 80h | 6,000 |
| 543 | 1.3.6.2.3.2 | **Acquisition & AO Control UI** | 173d? | 2008-10-01 | 2009-05-29 | 211d |  |  | 30h | 2,250 |
| 544 | 1.3.6.2.3.2.1 | Functional Requirements | 173d? | 2008-10-01 | 2009-05-29 | 211d | finish no earlier than 2009-05-29 | Le Mignant [1.4%] | 20h | 1,500 |
| 545 | 1.3.6.2.3.2.2 | Interface Definitions | 173d? | 2008-10-01 | 2009-05-29 | 211d | finish no earlier than 2009-05-29 | Johansson [0.7%] | 10h | 750 |
| 546 | 1.3.6.2.3.3 | **Observing Sequences UI** | 173d? | 2008-10-01 | 2009-05-29 | 211d |  |  | 20h | 1,500 |
| 547 | 1.3.6.2.3.3.1 | Functional Requirements | 173d? | 2008-10-01 | 2009-05-29 | 211d | finish no earlier than 2009-05-29 | Le Mignant [1.4%] | 20h | 1,500 |
| 548 | 1.3.6.2.3.3.2 | Interface Definitions | 173d? | 2008-10-01 | 2009-05-29 | 211d | finish no earlier than 2009-05-29 |  |  |  |
| 549 | 1.3.6.2.3.4 | **Status & Graph UI** | 173d? | 2008-10-01 | 2009-05-29 | 211d |  |  | 20h | 1,500 |
| 550 | 1.3.6.2.3.4.1 | Functional Requirements | 173d? | 2008-10-01 | 2009-05-29 | 211d | finish no earlier than 2009-05-29 | Le Mignant [1.4%] | 20h | 1,500 |
| 551 | 1.3.6.2.3.4.2 | Interface Definitions | 173d? | 2008-10-01 | 2009-05-29 | 211d | finish no earlier than 2009-05-29 |  |  |  |
| 552 | 1.3.6.2.3.5 | **Advanced Monitoring UI** | 173d? | 2008-10-01 | 2009-05-29 | 211d |  |  | 20h | 1,500 |
| 553 | 1.3.6.2.3.5.1 | Functional Requirements | 173d? | 2008-10-01 | 2009-05-29 | 211d | finish no earlier than 2009-05-29 | Le Mignant [1.4%] | 20h | 1,500 |
| 554 | 1.3.6.2.3.5.2 | Interface Definitions | 173d? | 2008-10-01 | 2009-05-29 | 211d | finish no earlier than 2009-05-29 |  |  |  |
| 555 | 1.3.6.2.3.6 | **Optimization & Troubleshooting UI** | 173d? | 2008-10-01 | 2009-05-29 | 211d |  |  | 20h | 1,500 |
| 556 | 1.3.6.2.3.6.1 | Functional Requirements | 173d? | 2008-10-01 | 2009-05-29 | 211d | finish no earlier than 2009-05-29 | Le Mignant [1.4%] | 20h | 1,500 |
| 557 | 1.3.6.2.3.6.2 | Interface Definitions | 173d? | 2008-10-01 | 2009-05-29 | 211d | finish no earlier than 2009-05-29 |  |  |  |

| ID | WBS | Task | Duration | Start | Finish | Total slack | Constraint | Resources | Work | Cost |
| --- | --- | --- | --- | --- | --- | --- | --- | --- | --- | --- |
| 558 | 1.3.6.3 | **Pre- & Post-Observing Science Support Tools** | 217d? | 2009-01-01 | 2009-10-30 | 101d |  |  | 610h | 45,750 |
| 559 | 1.3.6.3.1 | **User Documentation** | 174d? | 2009-01-01 | 2009-09-01 | 144d |  |  | 20h | 1,500 |
| 560 | 1.3.6.3.1.1 | User Documentation Operations Concept | 174d? | 2009-01-01 | 2009-09-01 | 144d | finish no earlier than 2009-09-01 | Le Mignant [0.7%] | 10h | 750 |
| 561 | 1.3.6.3.1.2 | User Documentation Functional Requirements | 174d? | 2009-01-01 | 2009-09-01 | 144d | finish no earlier than 2009-09-01 | Le Mignant [0.7%] | 10h | 750 |
| 562 | 1.3.6.3.2 | **Science Observations Planning Tools** | 148d? | 2009-01-07 | 2009-07-31 | 166d |  |  | 340h | 25,500 |
| 563 | 1.3.6.3.2.1 | **NGS Star Finder** | 148d? | 2009-01-07 | 2009-07-31 | 166d |  |  | 60h | 4,500 |
| 564 | 1.3.6.3.2.1.1 | Operations Concept | 148d? | 2009-01-07 | 2009-07-31 | 166d | finish no earlier than 2009-07-31 | Le Mignant [1.7%] | 20h | 1,500 |
| 565 | 1.3.6.3.2.1.2 | Functional Requirements & Use Case Definitions | 148d? | 2009-01-07 | 2009-07-31 | 166d | finish no earlier than 2009-07-31 | Le Mignant [3.4%] | 40h | 3,000 |
| 566 | 1.3.6.3.2.1.3 | Interface Definitions | 148d? | 2009-01-07 | 2009-07-31 | 166d | finish no earlier than 2009-07-31 |  |  |  |
| 567 | 1.3.6.3.2.1.4 | Module Definitions | 148d? | 2009-01-07 | 2009-07-31 | 166d | finish no earlier than 2009-07-31 |  |  |  |
| 568 | 1.3.6.3.2.2 | **Performance Prediction Tool** | 148d? | 2009-01-07 | 2009-07-31 | 166d |  |  | 140h | 10,500 |
| 569 | 1.3.6.3.2.2.1 | Operations Concept | 148d? | 2009-01-07 | 2009-07-31 | 166d | finish no earlier than 2009-07-31 | Le Mignant [3.4%] | 40h | 3,000 |
| 570 | 1.3.6.3.2.2.2 | Functional Requirements & Use Case Definitions | 148d? | 2009-01-07 | 2009-07-31 | 166d | finish no earlier than 2009-07-31 | Le Mignant [3.4%] | 40h | 3,000 |
| 571 | 1.3.6.3.2.2.3 | Interface Definitions | 148d? | 2009-01-07 | 2009-07-31 | 166d | finish no earlier than 2009-07-31 | Johansson [1.7%] | 20h | 1,500 |
| 572 | 1.3.6.3.2.2.4 | Module Definitions | 148d? | 2009-01-07 | 2009-07-31 | 166d | finish no earlier than 2009-07-31 | Johansson [1.7%]; Le Mignant [1.7%] | 40h | 3,000 |
| 573 | 1.3.6.3.2.3 | **Observation Planning & Efficiency Tool** | 148d? | 2009-01-07 | 2009-07-31 | 166d |  |  | 140h | 10,500 |
| 574 | 1.3.6.3.2.3.1 | Operations Concept | 148d? | 2009-01-07 | 2009-07-31 | 166d | finish no earlier than 2009-07-31 | Le Mignant [3.4%] | 40h | 3,000 |
| 575 | 1.3.6.3.2.3.2 | Functional Requirements & Use Case Definitions | 148d? | 2009-01-07 | 2009-07-31 | 166d | finish no earlier than 2009-07-31 | Le Mignant [3.4%] | 40h | 3,000 |
| 576 | 1.3.6.3.2.3.3 | Interface Definitions | 148d? | 2009-01-07 | 2009-07-31 | 166d | finish no earlier than 2009-07-31 | Johansson [1.7%] | 20h | 1,500 |
| 577 | 1.3.6.3.2.3.4 | Module Definitions | 148d? | 2009-01-07 | 2009-07-31 | 166d | finish no earlier than 2009-07-31 | Johansson [1.7%]; Le Mignant [1.7%] | 40h | 3,000 |
| 578 | 1.3.6.3.2.4 | **Laser Clearinghouse Coordination Tool** | 148d? | 2009-01-07 | 2009-07-31 | 166d |  |  |  |  |
| 579 | 1.3.6.3.2.4.1 | Operations Concept | 148d? | 2009-01-07 | 2009-07-31 | 166d | finish no earlier than 2009-07-31 |  |  |  |
| 580 | 1.3.6.3.2.4.2 | Functional Requirements & Use Case Definitions | 148d? | 2009-01-07 | 2009-07-31 | 166d | finish no earlier than 2009-07-31 |  |  |  |
| 581 | 1.3.6.3.2.4.3 | Interface Definitions | 148d? | 2009-01-07 | 2009-07-31 | 166d | finish no earlier than 2009-07-31 |  |  |  |
| 582 | 1.3.6.3.2.4.4 | Module Definitions | 148d? | 2009-01-07 | 2009-07-31 | 166d | finish no earlier than 2009-07-31 |  |  |  |

Notes:
- 558: DLM

| ID | WBS | Task | Type | Duration | Start | Finish | Total slack | Constraint | Resources | Work | Cost |
| --- | --- | --- | --- | --- | --- | --- | --- | --- | --- | --- | --- |
| 583 | 1.3.6.3.3 | **Data Products** |  | 195d? | 2009-02-02 | 2009-10-30 | 101d |  |  | 250h | 18,750 |
| 584 | 1.3.6.3.3.1 | **Generic Data Products** |  | 152d? | 2009-02-02 | 2009-09-01 | 144d |  |  | 80h | 6,000 |
| 585 | 1.3.6.3.3.1.1 | Operations Concept |  | 152d? | 2009-02-02 | 2009-09-01 | 144d | finish no earlier than 2009-09-01 | Le Mignant [1.6%] | 20h | 1,500 |
| 586 | 1.3.6.3.3.1.2 | Functional Requirements & Use Case Definitions |  | 152d? | 2009-02-02 | 2009-09-01 | 144d | finish no earlier than 2009-09-01 | Le Mignant [3.3%] | 40h | 3,000 |
| 587 | 1.3.6.3.3.1.3 | Interface Definitions |  | 152d? | 2009-02-02 | 2009-09-01 | 144d | finish no earlier than 2009-09-01 | Johansson [1.6%] | 20h | 1,500 |
| 588 | 1.3.6.3.3.2 | **Science Data Quality Assessment** |  | 195d? | 2009-02-02 | 2009-10-30 | 101d |  |  | 160h | 12,000 |
| 589 | 1.3.6.3.3.2.1 | **Quality Metrics & Logged Information** |  | 152d? | 2009-02-02 | 2009-09-01 | 144d |  |  | 80h | 6,000 |
| 590 | 1.3.6.3.3.2.1.1 | Operations Concept |  | 152d? | 2009-02-02 | 2009-09-01 | 144d | finish no earlier than 2009-09-01 | Le Mignant [3.3%] | 40h | 3,000 |
| 591 | 1.3.6.3.3.2.1.2 | Functional Requirements & Use Case Definitions |  | 152d? | 2009-02-02 | 2009-09-01 | 144d | finish no earlier than 2009-09-01 | Le Mignant [3.3%] | 40h | 3,000 |
| 592 | 1.3.6.3.3.2.1.3 | Interface Definitions |  | 152d? | 2009-02-02 | 2009-09-01 | 144d | finish no earlier than 2009-09-01 |  |  |  |
| 593 | 1.3.6.3.3.2.2 | **PSF Calibration** |  | 195d? | 2009-02-02 | 2009-10-30 | 101d |  |  | 80h | 6,000 |
| 594 | 1.3.6.3.3.2.2.1 | Operations Concept |  | 195d? | 2009-02-02 | 2009-10-30 | 101d | finish no earlier than 2009-10-30 | Le Mignant [2.6%] | 40h | 3,000 |
| 595 | 1.3.6.3.3.2.2.2 | Functional Requirements & Use Case Definitions |  | 195d? | 2009-02-02 | 2009-10-30 | 101d | finish no earlier than 2009-10-30 | Le Mignant [2.6%] | 40h | 3,000 |
| 596 | 1.3.6.3.3.2.2.3 | Interface Definitions |  | 195d? | 2009-02-02 | 2009-10-30 | 101d | finish no earlier than 2009-10-30 |  |  |  |
| 597 | 1.3.6.3.3.2.2.4 | Module Definitions |  | 195d? | 2009-02-02 | 2009-10-30 | 101d | finish no earlier than 2009-10-30 |  |  |  |
| 598 | 1.3.6.3.3.3 | **Science Data Archiving** |  | 195d? | 2009-02-02 | 2009-10-30 | 101d |  |  | 10h | 750 |
| 599 | 1.3.6.3.3.3.1 | Operations Concept |  | 195d? | 2009-02-02 | 2009-10-30 | 101d | finish no earlier than 2009-10-30 | Le Mignant [0.6%] | 10h | 750 |
| 600 | 1.3.6.3.3.3.2 | Functional Requirements & Use Case Definitions |  | 195d? | 2009-02-02 | 2009-10-30 | 101d | finish no earlier than 2009-10-30 |  |  |  |
| 601 | 1.3.6.3.3.3.3 | Interface Definitions |  | 195d? | 2009-02-02 | 2009-10-30 | 101d | finish no earlier than 2009-10-30 |  |  |  |
| 602 | 1.3.6.4 | **Data Server** |  | 195d? | 2009-02-02 | 2009-10-30 | 101d |  |  | 70h | 5,250 |
| 603 | 1.3.6.4.1 | Data Server: Architecture |  | 195d? | 2009-02-02 | 2009-10-30 | 101d | finish no earlier than 2009-10-30 | Johansson [2.6%] | 40h | 3,000 |
| 604 | 1.3.6.4.2 | Data Server: HW & SW Specification & Selection |  | 195d? | 2009-02-02 | 2009-10-30 | 101d | finish no earlier than 2009-10-30 | Johansson [1.3%] | 20h | 1,500 |
| 605 | 1.3.6.4.3 | Data Server: Software Design | milestone | 0d? | 2009-02-02 | 2009-02-02 | 296d | start no earlier than 2009-02-02 |  |  |  |
| 606 | 1.3.6.4.4 | Data Server: Compliance Matrix | milestone | 0d? | 2009-02-02 | 2009-02-02 | 296d | start no earlier than 2009-02-02 |  |  |  |
| 607 | 1.3.6.4.5 | Data Server: Test Plan | milestone | 0d? | 2009-02-02 | 2009-02-02 | 296d | start no earlier than 2009-02-02 |  |  |  |
| 608 | 1.3.6.4.6 | Data Server: Summary Report |  | 195d? | 2009-02-02 | 2009-10-30 | 101d | finish no earlier than 2009-10-30 | Johansson [0.6%] | 10h | 750 |

Notes:
- 602: EJ

| ID | WBS | Task | Duration | Start | Finish | Total slack | Constraint | Resources | Work | Cost |
| --- | --- | --- | --- | --- | --- | --- | --- | --- | --- | --- |
| 609 | 1.3.7 | **Telescope & Summit Engineering Design** | 215d? | 2008-12-08 | 2009-10-02 | 121d |  |  | 1101h | 82,575 |
| 610 | 1.3.7.1 | Telescope Performance | 1d? | 2009-05-04 | 2009-05-04 | 230d | start no earlier than 2009-05-04 |  |  |  |
| 611 | 1.3.7.2 | **Infrastructure Modifications for AO** | 110d? | 2009-05-04 | 2009-10-02 | 121d |  |  | 660h | 49,500 |
| 612 | 1.3.7.2.1 | Infrastructure Requirements & Interfaces | 20d? | 2009-05-04 | 2009-05-29 | 211d | finish no earlier than 2009-05-29 | Bell [37.5%]; Wetherell; Wizinowich [60%] | 90h | 6,750 |
| 613 | 1.3.7.2.2 | Infrastructure Mechanical Modifications | 45d? | 2009-06-01 | 2009-07-31 | 166d | finish no earlier than 2009-07-31 | Bell; Medeiros [33.3%]; Mogensen | 160h | 12,000 |
| 614 | 1.3.7.2.3 | Infrastructure Electrical Modifications | 45d? | 2009-07-06 | 2009-09-04 | 141d | finish no earlier than 2009-09-04 | Nance [33.3%] | 120h | 9,000 |
| 615 | 1.3.7.2.4 | Infrastructure Glycol Cooling Modifications | 45d? | 2009-07-13 | 2009-09-11 | 136d | finish no earlier than 2009-09-11 | Nance [38.9%] | 140h | 10,500 |
| 616 | 1.3.7.2.5 | Infrastructure CCR Modifications | 45d? | 2009-07-13 | 2009-09-11 | 136d | finish no earlier than 2009-09-11 | Nance [11.1%] | 40h | 3,000 |
| 617 | 1.3.7.2.6 | Infrastructure Implementation & Test Plans | 25d? | 2009-08-31 | 2009-10-02 | 121d | finish no earlier than 2009-10-02 | Bell [25%]; Medeiros; Nance; Chin | 110h | 8,250 |
| 618 | 1.3.7.3 | **Infrastructure modifications for Laser System** | 110d? | 2009-05-04 | 2009-10-02 | 121d |  |  | 280h | 21,000 |
| 619 | 1.3.7.3.1 | Infrastructure Requirements & Interfaces | 20d? | 2009-05-04 | 2009-05-29 | 211d | finish no earlier than 2009-05-29 | Bell [25%]; Chin; Nance | 70h | 5,250 |
| 620 | 1.3.7.3.2 | Infrastructure Mechanical Modifications | 45d? | 2009-06-29 | 2009-08-28 | 146d | finish no earlier than 2009-08-28 | Medeiros [13.9%] | 50h | 3,750 |
| 621 | 1.3.7.3.3 | Infrastructure Electrical Modifications | 45d? | 2009-07-06 | 2009-09-04 | 141d | finish no earlier than 2009-09-04 | Nance [11.1%] | 40h | 3,000 |
| 622 | 1.3.7.3.4 | Infrastructure Glycol Cooling Modifications | 45d? | 2009-07-13 | 2009-09-11 | 136d | finish no earlier than 2009-09-11 | Nance [13.9%] | 50h | 3,750 |
| 623 | 1.3.7.3.5 | Infrastructure Implementation & Test Plans | 25d? | 2009-08-31 | 2009-10-02 | 121d | finish no earlier than 2009-10-02 | Bell [20%]; Chin; Medeiros; Nance | 70h | 5,250 |
| 624 | 1.3.7.4 | OSIRIS Modifications | 15d? | 2009-01-12 | 2009-01-30 | 296d | start no earlier than 2009-01-12 | Adkins [16.7%]; Wetherell [33.3%]; Medeiros [33.3%] | 100h | 7,500 |
| 625 | 1.3.7.5 | **Interferometer Modifications** | 40d? | 2008-12-08 | 2009-01-30 | 296d |  |  | 61h | 4,575 |
| 626 | 1.3.7.5.1 | Optical Design of Post Field Selector Optics | 40d? | 2008-12-08 | 2009-01-30 | 296d | finish no earlier than 2009-01-30 | Wizinowich [7.8%]; Kupke [6.2%] | 45h | 3,375 |
| 627 | 1.3.7.5.2 | Evaluation of Optical Design Impact on Interferometer | 40d? | 2008-12-08 | 2009-01-30 | 296d | start no earlier than 2008-12-08 | Wizinowich [5%] | 16h | 1,200 |
| 628 | 1.3.8 | **Telescope Integration & Test** | 55d? | 2009-10-05 | 2009-12-18 | 66d |  |  | 622h | 46,650 |
| 629 | 1.3.8.1 | **Old AO/Laser Removal** | 20d? | 2009-10-05 | 2009-10-30 | 101d |  |  | 120h | 9,000 |
| 630 | 1.3.8.1.1 | AO Removal Plan | 20d? | 2009-10-05 | 2009-10-30 | 101d | start no earlier than 2009-10-05 | Nance [7.5%]; Bell [15%]; Wetherell [12.5%]; Wizinowich [2.5%]; Doyle | 60h | 4,500 |
| 631 | 1.3.8.1.2 | Laser Removal Plan | 20d? | 2009-10-05 | 2009-10-30 | 101d | start no earlier than 2009-10-05 | Chin [2.5%]; Medeiros [12.5%]; Doyle [5%]; Grace [10%]; Nance [7.5%] | 60h | 4,500 |
| 632 | 1.3.8.2 | Laser Enclosure Integration | 1d? | 2009-10-05 | 2009-10-05 | 120d | start no earlier than 2009-10-05 |  |  |  |
| 633 | 1.3.8.3 | AO Enclosure Integration | 1d? | 2009-10-05 | 2009-10-05 | 120d | start no earlier than 2009-10-05 |  |  |  |

Notes:
- 609: CN
- 611: JB
- 612: JB
- 613: DM
- 614: CN
- 615: CN
- 616: CN
- 617: JB
- 618: JB
- 619: JB
- 620: DM
- 621: CN
- 622: CN
- 623: JB
- 624: SA
- 625: PW
- 626: PW
- 627: PW
- 628: CN
- 629: JB
- 630: JB
- 631: DM

| ID | WBS | Task | Duration | Start | Finish | Total slack | Constraint | Resources | Work | Cost |
| --- | --- | --- | --- | --- | --- | --- | --- | --- | --- | --- |
| 634 | 1.3.8.4 | **AO System Install + I&T** | 35d? | 2009-11-02 | 2009-12-18 | 66d |  |  | 170h | 12,750 |
| 635 | 1.3.8.4.1 | Opto-Mechanical Integration Plan | 27d? | 2009-11-02 | 2009-12-08 | 74d | start no earlier than 2009-11-02 | Wizinowich [1.9%]; Bell [9.3%]; Neyman [16.7%] | 60h | 4,500 |
| 636 | 1.3.8.4.2 | Electronics Integration Plan | 35d? | 2009-11-02 | 2009-12-18 | 66d | start no earlier than 2009-11-02 | Wetherell [14.3%] | 40h | 3,000 |
| 637 | 1.3.8.4.3 | Computer Integration Plan | 35d? | 2009-11-02 | 2009-12-18 | 66d | start no earlier than 2009-11-02 | Chock [7.1%] | 20h | 1,500 |
| 638 | 1.3.8.4.4 | AO System Integration Plan | 35d? | 2009-11-02 | 2009-12-18 | 66d | start no earlier than 2009-11-02 | Neyman [14.3%] | 40h | 3,000 |
| 639 | 1.3.8.4.5 | AO System Test Plan | 35d? | 2009-11-02 | 2009-12-18 | 66d | start no earlier than 2009-11-02 | Neyman [3.6%] | 10h | 750 |
| 640 | 1.3.8.5 | **Laser System Install + I&T** | 35d? | 2009-11-02 | 2009-12-18 | 66d |  |  | 212h | 15,900 |
| 641 | 1.3.8.5.1 | Laser System Installation & Integration Plan | 35d? | 2009-11-02 | 2009-12-18 | 66d | finish no earlier than 2009-12-18 | Chin [21.4%]; Nance [7.1%]; Medeiros [7.1%]; Wetherell [7.1%]; Neyman [7.1%]; Adkins [2.9%] | 148h | 11,100 |
| 642 | 1.3.8.5.2 | Laser System Test Plan | 35d? | 2009-11-02 | 2009-12-18 | 66d | start no earlier than 2009-11-02 | Neyman [14.3%]; Wetherell [1.4%]; Johansson [2.9%]; Chin [2.9%]; Adkins [1.4%] | 64h | 4,800 |
| 643 | 1.3.8.6 | LGS AO System On-sky I&T Plan | 10d? | 2009-11-02 | 2009-11-13 | 91d | finish no earlier than 2009-11-13 | Le Mignant [25%]; Wizinowich [25%] | 40h | 3,000 |
| 644 | 1.3.8.7 | Performance Characterization | 1d? | 2009-11-02 | 2009-11-02 | 100d | start no earlier than 2009-11-02 |  |  |  |
| 645 | 1.3.8.8 | Science Verification Plan | 20d? | 2009-11-02 | 2009-11-27 | 81d | finish no earlier than 2009-11-27 | Le Mignant [37.5%]; Wizinowich [12.5%] | 80h | 6,000 |
| 646 | 1.3.9 | **Operations Transition** | 232d? | 2009-01-09 | 2009-11-30 | 80d |  |  | 166h | 12,450 |
| 647 | 1.3.9.1 | **Operations Plans** | 65d? | 2009-09-01 | 2009-11-30 | 80d |  |  | 96h | 7,200 |
| 648 | 1.3.9.1.1 | Operations Support Plan | 65d? | 2009-09-01 | 2009-11-30 | 80d | finish no earlier than 2009-11-30 | Le Mignant [7.7%] | 40h | 3,000 |
| 649 | 1.3.9.1.2 | Operations Maintenance & Spares Plan Template | 65d? | 2009-09-01 | 2009-11-30 | 80d | start no earlier than 2009-09-01 | Wetherell [5.4%]; Bell [3.1%]; Lockwood [1.2%]; Velur [1.2%] | 56h | 4,200 |
| 650 | 1.3.9.2 | **Operations Handover** | 232d? | 2009-01-09 | 2009-11-30 | 80d |  |  | 70h | 5,250 |
| 651 | 1.3.9.2.1 | Operations Personnel Training Plan | 65d? | 2009-09-01 | 2009-11-30 | 80d | finish no earlier than 2009-11-30 | Le Mignant [7.7%]; Wizinowich [1.9%] | 50h | 3,750 |
| 652 | 1.3.9.2.2 | Documentation Transition Plan | 232d? | 2009-01-09 | 2009-11-30 | 80d | finish no earlier than 2009-11-30 | Le Mignant [1.1%] | 20h | 1,500 |

Notes:
- 634: CN
- 635: CN
- 636: EW
- 637: JC
- 638: CN
- 639: CN
- 640: JC
- 641: JC
- 642: CN
- 643: DLM
- 645: DLM
- 646: DLM
- 647: DLM
- 648: DLM
- 649: EW
- 650: DLM
- 651: DLM
- 652: DLM
