# NGAO Design v3

Schedule from MS Project, 2005-10-03 to 2011-05-27.
CARA

## Calendars

- Standard: Mon-Fri 08:00-12:00, 13:00-17:00; Sat-Sun off.

## Resources

| Resource |
| --- |
| Dekany |
| Gavel |
| Max |
| Wizinowich |
| Other |
| Adkins |

## Schedule

| ID | WBS | Task | Duration | Start | Finish | Total slack | Constraint | Resources | Work |
| --- | --- | --- | --- | --- | --- | --- | --- | --- | --- |
| 1 | 1 | **NGAO Design** | 1475d? | 2005-10-03 | 2011-05-27 | 0d |  |  | 16644.2h |
| 2 | 1.1 | Proposal | 195d? | 2005-10-03 | 2006-06-30 | 1280d | finish no earlier than 2006-06-30 |  |  |
| 3 | 1.2 | System Design | 413d? | 2006-10-02 | 2008-04-30 | 802d | finish no earlier than 2008-04-30 |  |  |
| 4 | 1.3 | **Preliminary Design** | 434d? | 2008-04-01 | 2009-11-27 | 390d |  |  | 6899.24h |
| 5 | 1.3.1 | Reserved | 1d? | 2008-04-01 | 2008-04-01 | 823d |  |  |  |
| 6 | 1.3.2 | **PD Phase Management** | 434d? | 2008-04-01 | 2009-11-27 | 390d |  |  | 6229.24h |
| 7 | 1.3.2.1 | **Planning** | 361d? | 2008-05-02 | 2009-09-18 | 440d |  |  | 1730h |
| 8 | 1.3.2.1.1 | **Replans (PD phase)** | 260d? | 2008-05-02 | 2009-04-30 | 541d |  |  | 190h |
| 9 | 1.3.2.1.1.1 | Replan based on SDR | 6d? | 2008-05-02 | 2008-05-09 | 795d | finish no earlier than 2008-05-09 | Dekany [12.5%]; Gavel [12.5%]; Wizinowich [25%]; Other [12.5%] | 30h |
| 10 | 1.3.2.1.1.2 | Replan 1 | 13.2d? | 2008-10-13 | 2008-10-30 | 671d | finish no earlier than 2008-10-30 | Dekany [15.2%]; Gavel [15.2%]; Wizinowich [34.1%]; Other [11.4%] | 80h |
| 11 | 1.3.2.1.1.3 | Replan 2 | 14d? | 2009-04-13 | 2009-04-30 | 541d | start no earlier than 2009-04-13 | Dekany [14.3%]; Gavel [14.3%]; Wizinowich [28.6%]; Other [14.3%] | 80h |
| 12 | 1.3.2.1.2 | **WMKO FY Plans** | 280d? | 2008-05-05 | 2009-05-29 | 520d |  |  | 40h |
| 13 | 1.3.2.1.2.1 | Support WMKO FY09 Planning | 20d? | 2008-05-05 | 2008-05-30 | 780d | start no earlier than 2008-05-05 | Wizinowich [6.2%] | 10h |
| 14 | 1.3.2.1.2.2 | Support WMKO FY10 Planning | 85d? | 2009-02-02 | 2009-05-29 | 520d | start no earlier than 2009-02-02 | Wizinowich [4.4%] | 30h |
| 15 | 1.3.2.1.3 | **Systems Engineering Management Plan** | 123d? | 2009-04-01 | 2009-09-18 | 440d |  |  | 1500h |
| 16 | 1.3.2.1.3.1 | **Project Plan** | 50d? | 2009-07-06 | 2009-09-11 | 445d |  |  | 1020h |
| 17 | 1.3.2.1.3.1.1 | PBS, WBS & Task Definition | 15d? | 2009-07-06 | 2009-07-24 | 480d | finish no earlier than 2009-07-24 | Dekany [33.3%]; Gavel [33.3%]; Wizinowich [33.3%]; Max [8.3%]; Other [108.3%] | 260h |
| 18 | 1.3.2.1.3.1.2 | Cost Estimation | 20d? | 2009-07-27 | 2009-08-21 | 460d | start no earlier than 2009-07-27 | Dekany [50%]; Gavel [37.5%]; Max [6.2%]; Wizinowich [37.5%]; Other [168.8%] | 480h |
| 19 | 1.3.2.1.3.1.3 | Full Schedule (MS Project Plan) | 25d? | 2009-08-10 | 2009-09-11 | 445d | start no earlier than 2009-08-10 | Wizinowich [30%]; Dekany [15%]; Gavel [15%]; Max [5%]; Other [75%] | 280h |
| 20 | 1.3.2.1.3.2 | **Detailed Design Phase Plan** | 112d? | 2009-04-01 | 2009-09-03 | 451d |  |  | 400h |
| 21 | 1.3.2.1.3.2.1 | Detailed Design Plan v1 (FY10 planning) | 33d? | 2009-04-01 | 2009-05-15 | 530d | finish no earlier than 2009-05-15 | Wizinowich [15.2%] | 40h |
| 22 | 1.3.2.1.3.2.2 | Detailed Design Plan v2 (TSIP proposal) | 18d? | 2009-07-15 | 2009-08-07 | 470d | start no earlier than 2009-07-15 | Wizinowich [22.2%]; Dekany [27.8%]; Gavel [27.8%] | 40h |
| 23 | 1.3.2.1.3.2.3 | Detailed Design Plan Final Version | 19d? | 2009-08-10 | 2009-09-03 | 451d | start no earlier than 2009-08-10 | Wizinowich [52.6%]; Dekany [26.3%]; Gavel [26.3%]; Max [6.6%]; Other [98.7%] | 320h |
| 24 | 1.3.2.1.3.3 | SEMP Document | 15d? | 2009-08-31 | 2009-09-18 | 440d | finish no earlier than 2009-09-18 | Wizinowich [30%]; Dekany [66.7%]; Gavel [66.7%]; Max [66.7%] | 80h |

Notes:
- 6: PW
- 7: PW
- 15: PW
- 17: PW
- 18: RD
- 19: PW
- 20: PW
- 21: PW
- 22: PW
- 23: PW
- 24: PW

| ID | WBS | Task | Type | Duration | Start | Finish | Total slack | Constraint | Resources | Work |
| --- | --- | --- | --- | --- | --- | --- | --- | --- | --- | --- |
| 25 | 1.3.2.2 | **Project Management & Meetings** |  | 363d? | 2008-04-30 | 2009-09-18 | 440d |  |  | 2500h |
| 26 | 1.3.2.2.1 | **Executive Committee** |  | 15.62d? | 2008-05-01 | 2008-05-22 | 786.38d |  |  | 600h |
| 27 | 1.3.2.2.1.1 | Executive Committee Management Activities |  | 15.62d? | 2008-05-01 | 2008-05-22 | 786.38d | start no earlier than 2008-05-01 | Dekany; Gavel; Max; Wizinowich | 300h |
| 28 | 1.3.2.2.1.2 | Executive Committee Telecons |  | 9.38d? | 2008-05-01 | 2008-05-14 | 792.62d | start no earlier than 2008-05-01 | Dekany; Gavel; Max; Wizinowich | 300h |
| 29 | 1.3.2.2.2 | **Team Meetings** |  | 363d? | 2008-04-30 | 2009-09-18 | 440d |  |  | 1900h |
| 30 | 1.3.2.2.2.1 | Team Meeting #1 (CIT) |  | 2d? | 2008-04-30 | 2008-05-01 | 801d | start no earlier than 2008-04-30 | Dekany; Gavel; Max; Wizinowich; Other | 80h |
| 31 | 1.3.2.2.2.2 | Team Meeting #2 (telecon) |  | 1d? | 2008-06-13 | 2008-06-13 | 770d | start no earlier than 2008-06-13 |  | 60h |
| 32 | 1.3.2.2.2.3 | Team Meeting #3 (telecon) |  | 1d? | 2008-07-11 | 2008-07-11 | 750d | start no earlier than 2008-07-11 |  | 80h |
| 33 | 1.3.2.2.2.4 | Team Meeting #4 (telecon) |  | 1d? | 2008-08-15 | 2008-08-15 | 725d | start no earlier than 2008-08-15 |  | 60h |
| 34 | 1.3.2.2.2.5 | Team Meeting #5 (UC) |  | 3d? | 2008-09-16 | 2008-09-18 | 701d | finish no earlier than 2008-09-18 |  | 240h |
| 35 | 1.3.2.2.2.6 | Team Meeting #6 (telecon) |  | 1d? | 2008-10-17 | 2008-10-17 | 680d | start no earlier than 2008-10-17 |  | 60h |
| 36 | 1.3.2.2.2.7 | Team Meeting #7 (telecon) |  | 1d? | 2008-11-14 | 2008-11-14 | 660d | start no earlier than 2008-11-14 |  | 80h |
| 37 | 1.3.2.2.2.8 | Team Meeting #8 (telecon) |  | 1d? | 2008-12-12 | 2008-12-12 | 640d | start no earlier than 2008-12-12 |  | 60h |
| 38 | 1.3.2.2.2.9 | Team Meeting #9 (WMKO) |  | 4d? | 2009-01-20 | 2009-01-23 | 610d | start no earlier than 2009-01-20 |  | 320h |
| 39 | 1.3.2.2.2.10 | Team Meeting #10 (telecon) |  | 1d? | 2009-02-13 | 2009-02-13 | 595d | start no earlier than 2009-02-13 |  | 60h |
| 40 | 1.3.2.2.2.11 | Team Meeting #11 (telecon) |  | 1d? | 2009-03-13 | 2009-03-13 | 575d | start no earlier than 2009-03-13 |  | 80h |
| 41 | 1.3.2.2.2.12 | Team Meeting #12 (telecon) |  | 1d? | 2009-04-17 | 2009-04-17 | 550d | start no earlier than 2009-04-17 |  | 60h |
| 42 | 1.3.2.2.2.13 | Team Meeting #13 (CIT) |  | 3d? | 2009-05-15 | 2009-05-19 | 528d | start no earlier than 2009-05-15 |  | 240h |
| 43 | 1.3.2.2.2.14 | Team Meeting #14 (telecon) |  | 1d? | 2009-06-12 | 2009-06-12 | 510d | finish no earlier than 2009-06-12 |  | 60h |
| 44 | 1.3.2.2.2.15 | Team Meeting #15 (telecon) |  | 1d? | 2009-07-17 | 2009-07-17 | 485d | start no earlier than 2009-07-17 |  | 60h |
| 45 | 1.3.2.2.2.16 | Team Meeting #16 (UC) |  | 3d? | 2009-08-18 | 2009-08-20 | 461d | finish no earlier than 2009-08-20 |  | 240h |
| 46 | 1.3.2.2.2.17 | Team Meeting #17 (telecon) |  | 1d? | 2009-09-18 | 2009-09-18 | 440d | start no earlier than 2009-09-18 |  | 60h |
| 47 | 1.3.2.2.3 | **Director Telecons** |  | 325d | 2008-05-09 | 2009-08-07 | 471d |  |  |  |
| 48 | 1.3.2.2.3.1 | Director Telecon #1 | milestone | 0d | 2008-05-09 | 2008-05-09 | 796d | start no earlier than 2008-05-09 |  |  |
| 49 | 1.3.2.2.3.2 | Director Telecon #2 | milestone | 0d | 2008-10-03 | 2008-10-03 | 691d | start no earlier than 2008-10-03 |  |  |
| 50 | 1.3.2.2.3.3 | Director Telecon #3 | milestone | 0d | 2009-03-06 | 2009-03-06 | 581d | start no earlier than 2009-03-06 |  |  |
| 51 | 1.3.2.2.3.4 | Director Telecon #4 | milestone | 0d | 2009-08-07 | 2009-08-07 | 471d | start no earlier than 2009-08-07 |  |  |

Notes:
- 25: PW
- 26: PW
- 29: PW

| ID | WBS | Task | Type | Duration | Start | Finish | Total slack | Constraint | Resources | Work |
| --- | --- | --- | --- | --- | --- | --- | --- | --- | --- | --- |
| 52 | 1.3.2.3 | **Tracking & Reporting** |  | 413d? | 2008-04-30 | 2009-11-27 | 390d |  |  | 1067h |
| 53 | 1.3.2.3.1 | **Monthly Status Reports** |  | 412d? | 2008-05-01 | 2009-11-27 | 390d |  |  | 585h |
| 54 | 1.3.2.3.1.1 | Monthly Team Status Reports |  | 362d? | 2008-05-01 | 2009-09-18 | 440d | finish no earlier than 2009-09-18 | Other [6.9%]; Wizinowich; Max; Gavel; Dekany | 340h |
| 55 | 1.3.2.3.1.2 | Monthly Project Reports (TSIP, Directors) |  | 402d? | 2008-05-15 | 2009-11-27 | 390d | start no earlier than 2008-05-15 | Wizinowich [4.5%]; Dekany; Gavel; Adkins; Max | 215h |
| 56 | 1.3.2.3.1.3 | TSIP Project Report Telecons |  | 399d? | 2008-05-20 | 2009-11-27 | 390d | start no earlier than 2008-05-20 | Adkins [0.5%]; Wizinowich [0.5%] | 30h |
| 57 | 1.3.2.3.2 | **SSC Meetings** |  | 397d | 2008-04-30 | 2009-11-05 | 406d |  |  | 162h |
| 58 | 1.3.2.3.2.1 | SSC Meeting (CIT) - SDR report | milestone | 0d | 2008-04-30 | 2008-04-30 | 803d | start no earlier than 2008-04-30 |  |  |
| 59 | 1.3.2.3.2.2 | SSC Meeting (Keck) |  | 1.12d | 2008-06-18 | 2008-06-19 | 766.88d | start no earlier than 2008-06-18 | Dekany; Gavel; Max; Wizinowich | 18h |
| 60 | 1.3.2.3.2.3 | SSC Meeting (UCSC) |  | 1.12d | 2008-11-03 | 2008-11-04 | 668.88d | start no earlier than 2008-11-03 | Dekany; Gavel; Max; Wizinowich | 18h |
| 61 | 1.3.2.3.2.4 | SSC Meeting (Keck) |  | 1.12d | 2009-02-19 | 2009-02-20 | 590.88d | start no earlier than 2009-02-19 | Dekany; Gavel; Max; Wizinowich | 18h |
| 62 | 1.3.2.3.2.5 | SSC Meeting (CIT) |  | 1.12d | 2009-04-29 | 2009-04-30 | 541.88d | start no earlier than 2009-04-29 | Dekany; Gavel; Max; Wizinowich | 18h |
| 63 | 1.3.2.3.2.6 | SSC Meeting (Keck) |  | 1.12d | 2009-06-17 | 2009-06-18 | 506.88d | start no earlier than 2009-06-17 | Dekany; Gavel; Max; Wizinowich | 18h |
| 64 | 1.3.2.3.2.7 | SSC Meeting (UCSC) |  | 3d | 2009-11-03 | 2009-11-05 | 406d | start no earlier than 2009-11-03 | Dekany; Gavel; Max; Wizinowich | 72h |
| 65 | 1.3.2.3.3 | **Other Presentations** |  | 350d? | 2008-06-02 | 2009-10-02 | 430d |  |  | 320h |
| 66 | 1.3.2.3.3.1 | SPIE AO Conference Presentations/Papers |  | 15d? | 2008-06-02 | 2008-06-20 | 765d | start no earlier than 2008-06-02 | Dekany [33.3%]; Gavel [33.3%]; Max [33.3%]; Wizinowich [33.3%] | 160h |
| 67 | 1.3.2.3.3.2 | SPIE AO Conference (Marseille) |  | 5d? | 2008-06-23 | 2008-06-28 | 760d | finish no earlier than 2008-06-28 |  |  |
| 68 | 1.3.2.3.3.3 | Keck Science Meeting 08 |  | 3d | 2008-09-18 | 2008-09-22 | 699d | start no earlier than 2008-09-18 | Dekany; Gavel; Max; Wizinowich | 80h |
| 69 | 1.3.2.3.3.4 | Keck Science Meeting 09 |  | 3d | 2009-09-17 | 2009-09-21 | 439d | start no earlier than 2009-09-17 | Dekany; Gavel; Max; Wizinowich | 80h |
| 70 | 1.3.2.3.3.5 | Other |  | 195d? | 2009-01-05 | 2009-10-02 | 430d | finish no earlier than 2009-10-02 |  |  |
| 71 | 1.3.2.4 | **Proposals & Fundraising** |  | 31.5d? | 2009-08-20 | 2009-10-02 | 430d |  |  | 380h |
| 72 | 1.3.2.4.1 | Support Advancement Office |  | 5d? | 2009-09-28 | 2009-10-02 | 430d | finish no earlier than 2009-10-02 | Dekany; Gavel; Max; Wizinowich; Other | 120h |
| 73 | 1.3.2.4.2 | TSIP proposal for DDR |  | 7.5d? | 2009-08-20 | 2009-08-31 | 454d | finish no earlier than 2009-08-31 | Adkins; Dekany; Gavel; Max; Wizinowich; Other | 260h |
| 74 | 1.3.2.5 | **Programmatic Risk Assessment & Mitigation** |  | 326d? | 2008-04-01 | 2009-06-30 | 498d |  |  | 142.24h |
| 75 | 1.3.2.5.1 | **Risk Assessment** |  | 326d? | 2008-04-01 | 2009-06-30 | 498d |  |  | 60h |
| 76 | 1.3.2.5.1.1 | Programmatic Risk Assessment v1 |  | 2d? | 2008-04-01 | 2008-04-02 | 822d |  | Wizinowich; Dekany; Gavel; Adkins; Other | 32h |
| 77 | 1.3.2.5.1.2 | Programmatic Risk Assessment v2 |  | 2d? | 2009-06-29 | 2009-06-30 | 498d | finish no earlier than 2009-06-30 | Wizinowich; Dekany; Gavel; Adkins | 28h |

Notes:
- 52: PW
- 71: PW
- 74: PW

| ID | WBS | Task | Type | Duration | Start | Finish | Total slack | Constraint | Resources | Work |
| --- | --- | --- | --- | --- | --- | --- | --- | --- | --- | --- |
| 78 | 1.3.2.5.2 | **Risk Mitigation** |  | 326d? | 2008-04-01 | 2009-06-30 | 498d |  | Adkins [2.1%]; Other [2.1%] | 82.24h |
| 79 | 1.3.2.5.2.1 | Determine Laser Progress/Availability |  | 65d? | 2008-10-01 | 2008-12-30 | 628d | start no earlier than 2008-10-01 |  |  |
| 80 | 1.3.2.5.2.2 | Determine Procurement Options |  | 127d? | 2009-01-05 | 2009-06-30 | 498d | start no earlier than 2009-01-05 |  |  |
| 81 | 1.3.2.5.2.3 | Science Instruments |  | 1d? | 2008-04-01 | 2008-04-01 | 823d |  |  |  |
| 82 | 1.3.2.5.2.4 | Funding |  | 1d? | 2008-04-01 | 2008-04-01 | 823d |  |  |  |
| 83 | 1.3.2.6 | **Preliminary Design Review** |  | 143d? | 2009-05-04 | 2009-11-18 | 397d |  |  | 410h |
| 84 | 1.3.2.6.1 | Review Setup (Date, Participants, Charter) |  | 5d? | 2009-05-04 | 2009-05-08 | 535d | start no earlier than 2009-05-04 | Wizinowich [20%]; Other [20%] | 16h |
| 85 | 1.3.2.6.2 | Preliminary Design Report |  | 6d? | 2009-09-17 | 2009-09-24 | 436d | finish no earlier than 2009-09-24 | Wizinowich [83.3%]; Dekany [83.3%]; Gavel [83.3%]; Max [83.3%] | 52h |
| 86 | 1.3.2.6.3 | Review Package Distributed |  | 1d? | 2009-09-25 | 2009-09-25 | 435d | start no earlier than 2009-09-25 | Wizinowich [75%] | 6h |
| 87 | 1.3.2.6.4 | Reviewer Comments Received | milestone | 0d | 2009-10-09 | 2009-10-09 | 426d | start no earlier than 2009-10-09 |  |  |
| 88 | 1.3.2.6.5 | Reviewer Comments Addressed |  | 5d? | 2009-10-12 | 2009-10-16 | 420d | start no earlier than 2009-10-11 | Wizinowich [40%]; Dekany [40%]; Gavel [40%]; Max [40%]; Other [40%] | 80h |
| 89 | 1.3.2.6.6 | PDR Presentation Preparation |  | 15d? | 2009-09-28 | 2009-10-16 | 420d | finish no earlier than 2009-10-16 | Wizinowich [16.7%]; Dekany [10%]; Gavel [10%]; Max [10%]; Other [20%] | 80h |
| 90 | 1.3.2.6.7 | Preliminary Design Review |  | 0.12d? | 2009-10-21 | 2009-10-21 | 417.88d | start no earlier than 2009-10-21 | Wizinowich [1250%]; Dekany [1250%]; Max [1250%]; Other [8333.3%]; Gavel [1250%] | 128h |
| 91 | 1.3.2.6.8 | Reviewer Report Received | milestone | 0d | 2009-11-11 | 2009-11-11 | 403d | start no earlier than 2009-11-11 |  |  |
| 92 | 1.3.2.6.9 | Response to Reviewer Report |  | 5d? | 2009-11-12 | 2009-11-18 | 397d | start no earlier than 2009-11-12 | Wizinowich [40%]; Dekany [20%]; Gavel [20%]; Max [20%]; Other [20%] | 48h |
| 93 | 1.3.2.7 | **Management Support** |  | 1d? | 2008-04-01 | 2008-04-01 | 823d |  |  |  |
| 94 | 1.3.2.7.1 | Administrative Support |  | 1d? | 2008-04-01 | 2008-04-01 | 823d |  |  |  |
| 95 | 1.3.2.7.2 | Shared Infrastructure |  | 1d? | 2008-04-01 | 2008-04-01 | 823d |  |  |  |
| 96 | 1.3.2.7.3 | Research Time |  | 1d? | 2008-04-01 | 2008-04-01 | 823d |  |  |  |
| 97 | 1.3.3 | **Systems Engineering** |  | 414d? | 2008-04-01 | 2009-10-30 | 410d |  |  |  |
| 98 | 1.3.3.1 | **Science Case Development** |  | 1d? | 2008-04-01 | 2008-04-01 | 823d |  |  |  |
| 99 | 1.3.3.1.1 | Science Case Requirements |  | 1d? | 2008-04-01 | 2008-04-01 | 823d |  |  |  |
| 100 | 1.3.3.1.2 | Science Performance Input |  | 1d? | 2008-04-01 | 2008-04-01 | 823d |  |  |  |
| 101 | 1.3.3.1.3 | Science Competitiveness |  | 1d? | 2008-04-01 | 2008-04-01 | 823d |  |  |  |
| 102 | 1.3.3.1.4 | User Community Liaison |  | 1d? | 2008-04-01 | 2008-04-01 | 823d |  |  |  |
| 103 | 1.3.3.1.5 | Science Advisory Team Meetings |  | 1d? | 2008-04-01 | 2008-04-01 | 823d |  |  |  |
| 104 | 1.3.3.1.6 | Science Observing Planning & Execution |  | 1d? | 2008-04-01 | 2008-04-01 | 823d |  |  |  |

Notes:
- 80: SA
- 83: PW

| ID | WBS | Task | Duration | Start | Finish | Total slack | Free slack | Constraint |
| --- | --- | --- | --- | --- | --- | --- | --- | --- |
| 105 | 1.3.3.2 | **Requirements** | 349d? | 2008-04-01 | 2009-07-31 | 475d |  |  |
| 106 | 1.3.3.2.1 | Operations Concept Document | 152d? | 2008-05-01 | 2008-11-28 | 650d |  | start no earlier than 2008-05-01 |
| 107 | 1.3.3.2.2 | System Requirements | 152d? | 2008-05-01 | 2008-11-28 | 650d |  | start no earlier than 2008-05-01 |
| 108 | 1.3.3.2.3 | Functional Requirements | 175d? | 2008-12-01 | 2009-07-31 | 475d |  | finish no earlier than 2009-07-31 |
| 109 | 1.3.3.2.4 | Software Standards | 1d? | 2008-04-01 | 2008-04-01 | 823d |  |  |
| 110 | 1.3.3.2.5 | Component Standards | 1d? | 2008-04-01 | 2008-04-01 | 823d |  |  |
| 111 | 1.3.3.3 | **Systems Engineering Analysis** | 369d? | 2008-04-01 | 2009-08-28 | 455d |  |  |
| 112 | 1.3.3.3.1 | **Performance Budgets** | 325d? | 2008-06-02 | 2009-08-28 | 455d |  |  |
| 113 | 1.3.3.3.1.1 | **Throughput & Background** | 325d? | 2008-06-02 | 2009-08-28 | 455d |  |  |
| 114 | 1.3.3.3.1.1.1 | Throughput & Background Budget v1 | 21d? | 2008-06-02 | 2008-06-30 | 759d |  | finish no earlier than 2008-06-30 |
| 115 | 1.3.3.3.1.1.2 | Throughput & Background Budget v2 | 20d? | 2009-08-03 | 2009-08-28 | 455d |  | finish no earlier than 2009-08-28 |
| 116 | 1.3.3.3.1.2 | Wavefront & Encircled Energy | 65d? | 2009-05-04 | 2009-07-31 | 475d |  | finish no earlier than 2009-07-31 |
| 117 | 1.3.3.3.1.3 | Astrometric | 195d? | 2008-06-02 | 2009-02-27 | 585d | 0d | finish no earlier than 2009-02-27 |
| 118 | 1.3.3.3.1.4 | Photometric | 185d? | 2008-08-11 | 2009-04-24 | 545d | 0d | finish no earlier than 2009-04-24 |
| 119 | 1.3.3.3.1.5 | Companion Sensitivity | 44d? | 2009-06-01 | 2009-07-30 | 476d |  | finish no earlier than 2009-07-30 |
| 120 | 1.3.3.3.1.6 | Polarimetry | 21d? | 2009-05-01 | 2009-05-29 | 520d |  | finish no earlier than 2009-05-29 |
| 121 | 1.3.3.3.1.7 | **Observing Efficiency** | 282d? | 2008-06-02 | 2009-06-30 | 498d |  |  |
| 122 | 1.3.3.3.1.7.1 | Observing Efficiency Budget v1 | 21d? | 2008-06-02 | 2008-06-30 | 759d |  | finish no earlier than 2008-06-30 |
| 123 | 1.3.3.3.1.7.2 | Observing Efficiency Budget v2 | 22d? | 2009-06-01 | 2009-06-30 | 498d |  | finish no earlier than 2009-06-30 |
| 124 | 1.3.3.3.1.8 | **Observing Uptime** | 283d? | 2008-07-01 | 2009-07-30 | 476d |  |  |
| 125 | 1.3.3.3.1.8.1 | Observing Uptime Budget v1 | 22d? | 2008-07-01 | 2008-07-30 | 737d |  | finish no earlier than 2008-07-30 |
| 126 | 1.3.3.3.1.8.2 | Observing Uptime Budget v2 | 22d? | 2009-07-01 | 2009-07-30 | 476d |  | finish no earlier than 2009-07-30 |
| 127 | 1.3.3.3.2 | Modeling & Analysis | 325d? | 2008-06-02 | 2009-08-28 | 455d |  | finish no earlier than 2009-08-28 |
| 128 | 1.3.3.3.3 | PSF Calibration | 1d? | 2008-04-01 | 2008-04-01 | 823d |  |  |

| ID | WBS | Task | Duration | Start | Finish | Predecessors | Total slack | Free slack | Constraint |
| --- | --- | --- | --- | --- | --- | --- | --- | --- | --- |
| 129 | 1.3.3.4 | **System Architecture** | 392d? | 2008-04-01 | 2009-09-30 |  | 432d |  |  |
| 130 | 1.3.3.4.1 | **Hardware Architecture Design Support** | 370d? | 2008-05-01 | 2009-09-30 |  | 432d |  |  |
| 131 | 1.3.3.4.1.1 | Design Support | 370d? | 2008-05-01 | 2009-09-30 |  | 432d |  | finish no earlier than 2009-09-30 |
| 132 | 1.3.3.4.1.2 | **Motion Control / Electronics Architecture** | 261d? | 2008-10-01 | 2009-09-30 |  | 432d |  |  |
| 133 | 1.3.3.4.1.2.1 | Evaluate MC/Electronics Arch Options | 33d? | 2008-10-01 | 2008-11-14 |  | 624d | 0d | finish no earlier than 2008-11-14 |
| 134 | 1.3.3.4.1.2.2 | Determine/Document MC/Electronics Arch | 36d? | 2008-11-17 | 2009-01-05 | 133 | 624d |  | start no earlier than 2008-11-17 |
| 135 | 1.3.3.4.1.2.3 | MC/Electronics Architecture Design Support | 228d? | 2008-11-17 | 2009-09-30 |  | 432d |  | finish no earlier than 2009-09-30 |
| 136 | 1.3.3.4.2 | **Software Architecture** | 327d? | 2008-07-01 | 2009-09-30 |  | 432d |  |  |
| 137 | 1.3.3.4.2.1 | Evaluate Software Architecture Options | 34d? | 2008-07-01 | 2008-08-15 |  | 693d | 0d | finish no earlier than 2008-08-15 |
| 138 | 1.3.3.4.2.2 | Determine/Document Software Arch Approach | 32d? | 2008-08-18 | 2008-09-30 | 137 | 693d |  | start no earlier than 2008-08-18 |
| 139 | 1.3.3.4.2.3 | Software Architecture Design Support | 293d? | 2008-08-18 | 2009-09-30 |  | 432d |  | finish no earlier than 2009-09-30 |
| 140 | 1.3.3.4.3 | **Operations Sequences Architecture** | 1d? | 2008-04-01 | 2008-04-01 |  | 823d |  |  |
| 141 | 1.3.3.4.3.1 | Procedures | 1d? | 2008-04-01 | 2008-04-01 |  | 823d |  |  |
| 142 | 1.3.3.4.3.2 | Calibrations | 1d? | 2008-04-01 | 2008-04-01 |  | 823d |  |  |
| 143 | 1.3.3.5 | **External Interface Control** | 370d? | 2008-05-01 | 2009-09-30 |  | 432d |  |  |
| 144 | 1.3.3.5.1 | **Observatory Interfaces** | 283d? | 2008-09-01 | 2009-09-30 |  | 432d |  |  |
| 145 | 1.3.3.5.1.1 | **AO System ICD** | 283d? | 2008-09-01 | 2009-09-30 |  | 432d |  |  |
| 146 | 1.3.3.5.1.1.1 | AO System ICD v1 | 22d? | 2008-09-01 | 2008-09-30 |  | 693d |  | finish no earlier than 2008-09-30 |
| 147 | 1.3.3.5.1.1.2 | AO System ICD v2 | 22d? | 2009-09-01 | 2009-09-30 |  | 432d |  | finish no earlier than 2009-09-30 |
| 148 | 1.3.3.5.1.2 | **Laser System ICD** | 261d? | 2008-10-01 | 2009-09-30 |  | 432d |  |  |
| 149 | 1.3.3.5.1.2.1 | Laser System ICD v1 | 22d? | 2008-10-01 | 2008-10-30 |  | 671d |  | finish no earlier than 2008-10-30 |
| 150 | 1.3.3.5.1.2.2 | Laser System ICD v2 | 22d? | 2009-09-01 | 2009-09-30 |  | 432d |  | finish no earlier than 2009-09-30 |
| 151 | 1.3.3.5.2 | Science Instrument Requirements Input & Review | 368d? | 2008-05-05 | 2009-09-30 |  | 432d |  | finish no earlier than 2009-09-30 |
| 152 | 1.3.3.5.3 | **Science Instrument Interfaces** | 347d? | 2008-05-01 | 2009-08-28 |  | 455d |  |  |
| 153 | 1.3.3.5.3.1 | **Generic Science Instrument ICD** | 347d? | 2008-05-01 | 2009-08-28 |  | 455d |  |  |
| 154 | 1.3.3.5.3.1.1 | Generic Science Instrument ICD v1 | 87d? | 2008-05-01 | 2008-08-29 |  | 715d |  | finish no earlier than 2008-08-29 |
| 155 | 1.3.3.5.3.1.2 | Generic Science Instrument ICD v2 | 86d? | 2009-05-01 | 2009-08-28 |  | 455d |  | finish no earlier than 2009-08-28 |

| ID | WBS | Task | Duration | Start | Finish | Total slack | Constraint |
| --- | --- | --- | --- | --- | --- | --- | --- |
| 156 | 1.3.3.5.3.2 | **Interferometer & OHANA ICD** | 283d? | 2008-07-01 | 2009-07-30 | 476d |  |
| 157 | 1.3.3.5.3.2.1 | Interferometer & OHANA ICD v1 | 22d? | 2008-07-01 | 2008-07-30 | 737d | finish no earlier than 2008-07-30 |
| 158 | 1.3.3.5.3.2.2 | Interferometer & OHANA ICD v2 | 22d? | 2009-07-01 | 2009-07-30 | 476d | finish no earlier than 2009-07-30 |
| 159 | 1.3.3.5.3.3 | **OSIRIS ICD** | 281d? | 2008-08-01 | 2009-08-28 | 455d |  |
| 160 | 1.3.3.5.3.3.1 | OSIRIS ICD v1 | 21d? | 2008-08-01 | 2008-08-29 | 715d | finish no earlier than 2008-08-29 |
| 161 | 1.3.3.5.3.3.2 | OSIRIS ICD v2 | 20d? | 2009-08-03 | 2009-08-28 | 455d | finish no earlier than 2009-08-28 |
| 162 | 1.3.3.5.3.4 | **NIR Camera ICD** | 282d? | 2008-06-02 | 2009-06-30 | 498d |  |
| 163 | 1.3.3.5.3.4.1 | NIR Camera ICD v1 | 21d? | 2008-06-02 | 2008-06-30 | 759d | finish no earlier than 2008-06-30 |
| 164 | 1.3.3.5.3.4.2 | NIR Camera ICD v2 | 22d? | 2009-06-01 | 2009-06-30 | 498d | finish no earlier than 2009-06-30 |
| 165 | 1.3.3.5.3.5 | **Visible Camera ICD** | 239d? | 2008-07-01 | 2009-05-29 | 520d |  |
| 166 | 1.3.3.5.3.5.1 | Visible Camera ICD v1 | 22d? | 2008-07-01 | 2008-07-30 | 737d | finish no earlier than 2008-07-30 |
| 167 | 1.3.3.5.3.5.2 | Visible Camera ICD v2 | 21d? | 2009-05-01 | 2009-05-29 | 520d | finish no earlier than 2009-05-29 |
| 168 | 1.3.3.5.3.6 | **Deployabe IFS ICD** | 326d? | 2008-05-01 | 2009-07-30 | 476d |  |
| 169 | 1.3.3.5.3.6.1 | Deployable IFS ICD v1 | 22d? | 2008-05-01 | 2008-05-30 | 780d | finish no earlier than 2008-05-30 |
| 170 | 1.3.3.5.3.6.2 | Deployable IFS ICD v2 | 22d? | 2009-07-01 | 2009-07-30 | 476d | finish no earlier than 2009-07-30 |
| 171 | 1.3.3.6 | Internal Interface Control | 1d? | 2008-04-01 | 2008-04-01 | 823d |  |
| 172 | 1.3.3.7 | Configuration Control | 1d? | 2008-04-01 | 2008-04-01 | 823d |  |
| 173 | 1.3.3.8 | Documentation Control | 1d? | 2008-04-01 | 2008-04-01 | 823d |  |
| 174 | 1.3.3.9 | **Technical Risk Assessment & Mitigation** | 414d? | 2008-04-01 | 2009-10-30 | 410d |  |
| 175 | 1.3.3.9.1 | **Risk Assessment** | 238d? | 2008-10-01 | 2009-08-28 | 455d |  |
| 176 | 1.3.3.9.1.1 | Risk Assessment v1 | 22d? | 2008-10-01 | 2008-10-30 | 671d | finish no earlier than 2008-10-30 |
| 177 | 1.3.3.9.1.2 | Risk Assessment v2 | 20d? | 2009-08-03 | 2009-08-28 | 455d | finish no earlier than 2009-08-28 |
| 178 | 1.3.3.9.2 | **Risk Mitigation Efforts** | 414d? | 2008-04-01 | 2009-10-30 | 410d |  |
| 179 | 1.3.3.9.2.1 | **PSF Calibration** | 392d? | 2008-05-01 | 2009-10-30 | 410d |  |
| 180 | 1.3.3.9.2.1.1 | Support/Monitor CfAO-funded Project | 392d? | 2008-05-01 | 2009-10-30 | 410d | finish no earlier than 2009-10-30 |

| ID | WBS | Task | Type | Duration | Start | Finish | Predecessors | Total slack | Free slack | Constraint |
| --- | --- | --- | --- | --- | --- | --- | --- | --- | --- | --- |
| 181 | 1.3.3.9.2.1.2 | **Implement Atmospheric Profiler** |  | 347d? | 2008-05-01 | 2009-08-28 |  | 455d |  |  |
| 182 | 1.3.3.9.2.1.2.1 | Define & Procure Profiler |  | 131d? | 2008-05-01 | 2008-10-30 |  | 524d | 46d | finish no earlier than 2008-10-30 |
| 183 | 1.3.3.9.2.1.2.2 | Implement Profiler |  | 61d? | 2009-01-05 | 2009-03-30 | 182, 229 | 478d | 23d | finish no earlier than 2009-03-30 |
| 184 | 1.3.3.9.2.1.2.3 | Evaluate Profiler Results |  | 86d? | 2009-05-01 | 2009-08-28 | 183 | 455d |  | finish no earlier than 2009-08-28 |
| 185 | 1.3.3.9.2.2 | **Astrometry Performance** |  | 217d? | 2008-05-01 | 2009-02-27 |  | 585d |  |  |
| 186 | 1.3.3.9.2.2.1 | Support/Monitor UCLA/CIT Astrometry Results |  | 197d? | 2008-05-01 | 2009-01-30 |  | 605d |  | finish no earlier than 2009-01-30 |
| 187 | 1.3.3.9.2.2.2 | Develop Error Budget (1.3.2.4.3) | milestone | 0d | 2009-02-27 | 2009-02-27 | 117 | 585d |  |  |
| 188 | 1.3.3.9.2.3 | **Tomographic Reconstruction** |  | 304d? | 2008-07-01 | 2009-08-28 |  | 455d |  |  |
| 189 | 1.3.3.9.2.3.1 | Summarize On-sky Tomography Results |  | 85d? | 2009-02-02 | 2009-05-29 |  | 520d |  | finish no earlier than 2009-05-29 |
| 190 | 1.3.3.9.2.3.2 | Support/Monitor LAO Tomography Expts |  | 239d? | 2008-07-01 | 2009-05-29 |  | 520d |  | finish no earlier than 2009-05-29 |
| 191 | 1.3.3.9.2.3.3 | Test Single Laser Tomography at Keck |  | 86d? | 2009-05-01 | 2009-08-28 | 183 | 455d |  | finish no earlier than 2009-08-28 |
| 192 | 1.3.3.9.2.4 | **Sky Coverage** |  | 236d? | 2008-06-02 | 2009-04-27 |  | 544d |  |  |
| 193 | 1.3.3.9.2.4.1 | **Prototype NIR Tip/tilt Sensor** |  | 236d? | 2008-06-02 | 2009-04-27 |  | 544d |  |  |
| 194 | 1.3.3.9.2.4.1.1 | Define & Procure Components |  | 130d? | 2008-06-02 | 2008-11-28 |  | 544d | 0d | finish no earlier than 2008-11-28 |
| 195 | 1.3.3.9.2.4.1.2 | Assemble & Perform Lab Testing |  | 106d? | 2008-12-01 | 2009-04-27 | 194 | 544d |  | finish no earlier than 2009-03-30 |
| 196 | 1.3.3.9.2.5 | **Photometry Performance** |  | 0d | 2009-04-24 | 2009-04-24 |  | 545d |  |  |
| 197 | 1.3.3.9.2.5.1 | Develop Error Budget (1.3.2.4.4) | milestone | 0d | 2009-04-24 | 2009-04-24 | 118 | 545d |  |  |
| 198 | 1.3.3.9.2.6 | **Science Requirements** |  | 0d | 2008-04-01 | 2008-04-01 |  | 824d |  |  |
| 199 | 1.3.3.9.2.6.1 | Update Science Case Requirements | milestone | 0d | 2008-04-01 | 2008-04-01 |  | 824d |  |  |
| 200 | 1.3.3.9.2.7 | **Woofer DM Tip/tilt Performance** |  | 0d | 2008-04-01 | 2008-04-01 |  | 824d |  |  |
| 201 | 1.3.3.9.2.7.1 | Complete Woofer Tip/Tilt Design | milestone | 0d | 2008-04-01 | 2008-04-01 |  | 824d |  |  |
| 202 | 1.3.3.9.2.8 | **Wavefront Error Budget** |  | 53d? | 2009-01-15 | 2009-03-30 |  | 564d |  |  |
| 203 | 1.3.3.9.2.8.1 | Determine CCID-56 Status |  | 20d? | 2009-02-02 | 2009-02-27 |  | 585d |  | finish no earlier than 2009-02-27 |
| 204 | 1.3.3.9.2.8.2 | Tip/tilt Vibration Analysis |  | 53d? | 2009-01-15 | 2009-03-30 |  | 564d |  | finish no earlier than 2009-03-30 |
| 205 | 1.3.3.9.2.9 | Other Risk Mitigation |  | 105d? | 2009-02-02 | 2009-06-26 |  | 500d |  | finish no earlier than 2009-06-26 |
| 206 | 1.3.3.10 | Preliminary Design Manual |  | 50d? | 2009-07-06 | 2009-09-11 |  | 445d |  | finish no earlier than 2009-09-11 |

Notes:
- 182: RF
- 184: RF
- 199: CM

| ID | WBS | Task | Duration | Start | Finish | Total slack | Free slack | Constraint | Work |
| --- | --- | --- | --- | --- | --- | --- | --- | --- | --- |
| 207 | 1.3.4 | **AO System Design** | 348d? | 2008-04-01 | 2009-07-30 | 476d |  |  | 200h |
| 208 | 1.3.4.1 | AO Enclosure | 130d? | 2008-10-01 | 2009-03-31 | 563d |  | finish no earlier than 2009-03-31 |  |
| 209 | 1.3.4.2 | **Opto-Mechanical** | 239d? | 2008-07-01 | 2009-05-29 | 520d |  |  |  |
| 210 | 1.3.4.2.1 | AO Support Structure | 65d? | 2008-11-03 | 2009-01-30 | 605d |  | start no earlier than 2008-11-03 |  |
| 211 | 1.3.4.2.2 | Rotator | 151d? | 2008-09-01 | 2009-03-30 | 564d |  | finish no earlier than 2009-03-30 |  |
| 212 | 1.3.4.2.3 | Optical Relays | 131d? | 2008-08-01 | 2009-01-30 | 605d |  | finish no earlier than 2009-01-30 |  |
| 213 | 1.3.4.2.4 | Optical Switchyard | 131d? | 2008-08-01 | 2009-01-30 | 605d |  | start no earlier than 2008-08-01 |  |
| 214 | 1.3.4.2.5 | LGS Wavefront Sensor Assembly | 65d? | 2008-09-01 | 2008-11-28 | 650d |  | finish no earlier than 2008-11-28 |  |
| 215 | 1.3.4.2.6 | NGS WFS/TWFS Assembly | 45d? | 2008-12-01 | 2009-01-30 | 605d |  | finish no earlier than 2009-01-30 |  |
| 216 | 1.3.4.2.7 | Low Order Wavefront Sensor Assembly | 84d? | 2008-07-07 | 2008-10-30 | 671d |  | finish no earlier than 2008-10-30 |  |
| 217 | 1.3.4.2.8 | Tip/Tilt Vibration Mitigation | 43d? | 2009-04-01 | 2009-05-29 | 520d |  | finish no earlier than 2009-05-29 |  |
| 218 | 1.3.4.2.9 | **Acquisition Cameras** | 110d? | 2008-09-01 | 2009-01-30 | 605d |  |  |  |
| 219 | 1.3.4.2.9.1 | NGS Acquisition Camera | 45d? | 2008-12-01 | 2009-01-30 | 605d |  | finish no earlier than 2009-01-30 |  |
| 220 | 1.3.4.2.9.2 | LGS Acquisition Camera | 65d? | 2008-09-01 | 2008-11-28 | 650d |  | finish no earlier than 2008-11-28 |  |
| 221 | 1.3.4.2.10 | **Atmospheric Dispersion Correctors** | 174d? | 2008-07-01 | 2009-02-27 | 585d |  |  |  |
| 222 | 1.3.4.2.10.1 | LOWFS ADCs | 88d? | 2008-07-01 | 2008-10-30 | 671d |  | finish no earlier than 2008-10-30 |  |
| 223 | 1.3.4.2.10.2 | NIR Science ADC | 65d? | 2008-10-01 | 2008-12-30 | 628d |  | finish no earlier than 2008-12-30 |  |
| 224 | 1.3.4.2.10.3 | Visible Science ADC | 40d? | 2009-01-05 | 2009-02-27 | 585d |  | finish no earlier than 2009-02-27 |  |
| 225 | 1.3.4.2.10.4 | NGS Wavefront Sensor ADC | 40d? | 2009-01-05 | 2009-02-27 | 585d |  | start no earlier than 2009-01-05 |  |
| 226 | 1.3.4.3 | **Alignment, Calibration & Diagnostics** | 326d? | 2008-05-01 | 2009-07-30 | 476d |  |  |  |
| 227 | 1.3.4.3.1 | Simulator | 88d? | 2008-07-01 | 2008-10-30 | 671d |  | finish no earlier than 2008-10-30 |  |
| 228 | 1.3.4.3.2 | System Alignment Tools | 64d? | 2009-05-04 | 2009-07-30 | 476d |  | finish no earlier than 2009-07-30 |  |
| 229 | 1.3.4.3.3 | Atmospheric Profiler | 65d? | 2008-05-01 | 2008-07-30 | 590d | 112d | finish no earlier than 2008-07-30 |  |
| 230 | 1.3.4.3.4 | PSF Monitoring Camera | 54d? | 2008-11-03 | 2009-01-15 | 616d |  | finish no earlier than 2009-01-15 |  |

| ID | WBS | Task | Duration | Start | Finish | Total slack | Constraint | Work |
| --- | --- | --- | --- | --- | --- | --- | --- | --- |
| 231 | 1.3.4.4 | **Non-real-time Control** | 1d? | 2008-04-01 | 2008-04-01 | 823d |  |  |
| 232 | 1.3.4.4.1 | **Non-RTC Software** | 1d? | 2008-04-01 | 2008-04-01 | 823d |  |  |
| 233 | 1.3.4.4.1.1 | **AO System Sequencer** | 1d? | 2008-04-01 | 2008-04-01 | 823d |  |  |
| 234 | 1.3.4.4.1.1.1 | Coordination Sequence | 1d? | 2008-04-01 | 2008-04-01 | 823d |  |  |
| 235 | 1.3.4.4.1.1.2 | Command Interface | 1d? | 2008-04-01 | 2008-04-01 | 823d |  |  |
| 236 | 1.3.4.4.1.1.3 | Data Interface | 1d? | 2008-04-01 | 2008-04-01 | 823d |  |  |
| 237 | 1.3.4.4.1.1.4 | Health Monitor | 1d? | 2008-04-01 | 2008-04-01 | 823d |  |  |
| 238 | 1.3.4.4.1.2 | **Low Level AO System Control** | 1d? | 2008-04-01 | 2008-04-01 | 823d |  |  |
| 239 | 1.3.4.4.1.2.1 | **Motion Control** | 1d? | 2008-04-01 | 2008-04-01 | 823d |  |  |
| 240 | 1.3.4.4.1.2.1.1 | High-level Motion Control | 1d? | 2008-04-01 | 2008-04-01 | 823d |  |  |
| 241 | 1.3.4.4.1.2.1.2 | Low-Level Motion Control | 1d? | 2008-04-01 | 2008-04-01 | 823d |  |  |
| 242 | 1.3.4.4.1.2.2 | Camera Control | 1d? | 2008-04-01 | 2008-04-01 | 823d |  |  |
| 243 | 1.3.4.4.1.2.3 | DM & TT Mirror Control | 1d? | 2008-04-01 | 2008-04-01 | 823d |  |  |
| 244 | 1.3.4.4.1.2.4 | RTC Control | 1d? | 2008-04-01 | 2008-04-01 | 823d |  |  |
| 245 | 1.3.4.4.1.2.5 | Environmental Control | 1d? | 2008-04-01 | 2008-04-01 | 823d |  |  |
| 246 | 1.3.4.4.2 | **Non-RTC Hardware** | 1d? | 2008-04-01 | 2008-04-01 | 823d |  |  |
| 247 | 1.3.4.4.2.1 | Motion Control Electronics | 1d? | 2008-04-01 | 2008-04-01 | 823d |  |  |
| 248 | 1.3.4.4.2.2 | Power Distribution & Control | 1d? | 2008-04-01 | 2008-04-01 | 823d |  |  |
| 249 | 1.3.4.4.2.3 | Other Electronics | 1d? | 2008-04-01 | 2008-04-01 | 823d |  |  |
| 250 | 1.3.4.5 | **Real-time Control** | 190d? | 2008-05-12 | 2009-01-30 | 605d |  |  |
| 251 | 1.3.4.5.1 | RTC Software | 156d? | 2008-05-12 | 2008-12-15 | 639d | finish no earlier than 2008-12-15 |  |
| 252 | 1.3.4.5.2 | RTC Hardware | 165d? | 2008-06-16 | 2009-01-30 | 605d | finish no earlier than 2009-01-30 |  |
| 253 | 1.3.4.6 | **AO System Lab I&T** | 1d? | 2008-04-01 | 2008-04-01 | 823d |  | 200h |
| 254 | 1.3.4.6.1 | AO System Lab I&T Scope Definition | 1d? | 2008-04-01 | 2008-04-01 | 823d |  | 16h |
| 255 | 1.3.4.6.2 | AO System Lab Facility Plan | 1d? | 2008-04-01 | 2008-04-01 | 823d |  | 24h |
| 256 | 1.3.4.6.3 | AO System Lab Integration Plan | 1d? | 2008-04-01 | 2008-04-01 | 823d |  | 80h |
| 257 | 1.3.4.6.4 | AO System Lab Test Plan | 1d? | 2008-04-01 | 2008-04-01 | 823d |  | 80h |

| ID | WBS | Task | Duration | Start | Finish | Total slack | Constraint |
| --- | --- | --- | --- | --- | --- | --- | --- |
| 258 | 1.3.5 | **Laser System Design** | 368d? | 2008-04-01 | 2009-08-27 | 456d |  |
| 259 | 1.3.5.1 | Laser Enclosure | 85d? | 2009-05-01 | 2009-08-27 | 456d | start no earlier than 2009-05-01 |
| 260 | 1.3.5.2 | Laser | 84d? | 2009-01-05 | 2009-04-30 | 541d | finish no earlier than 2009-04-30 |
| 261 | 1.3.5.3 | **Laser Launch Facility** | 176d? | 2008-05-15 | 2009-01-15 | 616d |  |
| 262 | 1.3.5.3.1 | Beam Transport | 121d? | 2008-05-15 | 2008-10-30 | 671d | finish no earlier than 2008-10-30 |
| 263 | 1.3.5.3.2 | Laser Pointing & Diagnostics | 99d? | 2008-05-15 | 2008-09-30 | 693d | finish no earlier than 2008-09-30 |
| 264 | 1.3.5.3.3 | Launch Telescope | 54d? | 2008-11-03 | 2009-01-15 | 616d | finish no earlier than 2009-01-15 |
| 265 | 1.3.5.4 | **Laser Safety Systems** | 108d? | 2008-10-01 | 2009-02-27 | 585d |  |
| 266 | 1.3.5.4.1 | Personnel & Equipment Safety System | 65d? | 2008-10-01 | 2008-12-30 | 628d | finish no earlier than 2008-12-30 |
| 267 | 1.3.5.4.2 | Aircraft, Satellite & Laser Traffic Control | 40d? | 2009-01-05 | 2009-02-27 | 585d | finish no earlier than 2009-02-27 |
| 268 | 1.3.5.5 | **Laser System Control** | 109d? | 2009-03-02 | 2009-07-30 | 476d |  |
| 269 | 1.3.5.5.1 | Laser System Software | 87d? | 2009-03-02 | 2009-06-30 | 498d | finish no earlier than 2009-06-30 |
| 270 | 1.3.5.5.2 | Laser System Hardware | 87d? | 2009-04-01 | 2009-07-30 | 476d | finish no earlier than 2009-07-30 |
| 271 | 1.3.5.6 | Laser System Lab I&T | 1d? | 2008-04-01 | 2008-04-01 | 823d |  |
| 272 | 1.3.6 | **Science Operations Tools Design** | 369d? | 2008-04-01 | 2009-08-28 | 455d |  |
| 273 | 1.3.6.1 | **Multi-Systems Command Sequencer** | 1d? | 2008-04-01 | 2008-04-01 | 823d |  |
| 274 | 1.3.6.1.1 | Sequencer Infrastructure | 1d? | 2008-04-01 | 2008-04-01 | 823d |  |
| 275 | 1.3.6.1.2 | Setup Sequences: Configurations & Calibrations | 1d? | 2008-04-01 | 2008-04-01 | 823d |  |
| 276 | 1.3.6.1.3 | **Observing Sequences** | 1d? | 2008-04-01 | 2008-04-01 | 823d |  |
| 277 | 1.3.6.1.3.1 | Acquisition | 1d? | 2008-04-01 | 2008-04-01 | 823d |  |
| 278 | 1.3.6.1.3.2 | Observing Sequences | 1d? | 2008-04-01 | 2008-04-01 | 823d |  |
| 279 | 1.3.6.1.3.3 | Performance Monitoring & Optimization | 1d? | 2008-04-01 | 2008-04-01 | 823d |  |
| 280 | 1.3.6.1.4 | Data Logging & Troubleshooting | 1d? | 2008-04-01 | 2008-04-01 | 823d |  |
| 281 | 1.3.6.2 | **User Interfaces** | 369d? | 2008-04-01 | 2009-08-28 | 455d |  |
| 282 | 1.3.6.2.1 | User Interface Infrastructure | 347d? | 2008-05-01 | 2009-08-28 | 455d | start no earlier than 2008-05-01 |
| 283 | 1.3.6.2.2 | Setup User Interfaces | 1d? | 2008-04-01 | 2008-04-01 | 823d |  |
| 284 | 1.3.6.2.3 | Observation User Interfaces | 1d? | 2008-04-01 | 2008-04-01 | 823d |  |

| ID | WBS | Task | Duration | Start | Finish | Total slack | Constraint | Work |
| --- | --- | --- | --- | --- | --- | --- | --- | --- |
| 285 | 1.3.6.3 | **Pre- & Post-Observing Science Support Tools** | 1d? | 2008-04-01 | 2008-04-01 | 823d |  |  |
| 286 | 1.3.6.3.1 | User Documentation | 1d? | 2008-04-01 | 2008-04-01 | 823d |  |  |
| 287 | 1.3.6.3.2 | **Planning Tools** | 1d? | 2008-04-01 | 2008-04-01 | 823d |  |  |
| 288 | 1.3.6.3.2.1 | Science Observations Planning Tools | 1d? | 2008-04-01 | 2008-04-01 | 823d |  |  |
| 289 | 1.3.6.3.2.2 | Laser Clearinghouse Coordination Tool | 1d? | 2008-04-01 | 2008-04-01 | 823d |  |  |
| 290 | 1.3.6.3.3 | **Data Products** | 1d? | 2008-04-01 | 2008-04-01 | 823d |  |  |
| 291 | 1.3.6.3.3.1 | Generic Data Products | 1d? | 2008-04-01 | 2008-04-01 | 823d |  |  |
| 292 | 1.3.6.3.3.2 | Science Data Quality Assessment | 1d? | 2008-04-01 | 2008-04-01 | 823d |  |  |
| 293 | 1.3.6.3.3.3 | Science Data Archiving | 1d? | 2008-04-01 | 2008-04-01 | 823d |  |  |
| 294 | 1.3.6.4 | Data Server | 1d? | 2008-04-01 | 2008-04-01 | 823d |  |  |
| 295 | 1.3.7 | **Telescope & Summit Engineering Design** | 348d? | 2008-04-01 | 2009-07-30 | 476d |  | 200h |
| 296 | 1.3.7.1 | **Telescope Performance** | 1d? | 2008-04-01 | 2008-04-01 | 823d |  | 200h |
| 297 | 1.3.7.1.1 | Telescope Performance Improvement Trade Study | 1d? | 2008-04-01 | 2008-04-01 | 823d |  | 120h |
| 298 | 1.3.7.1.2 | Telescope Performance Improvement Design | 1d? | 2008-04-01 | 2008-04-01 | 823d |  | 80h |
| 299 | 1.3.7.2 | Infrastructure Modifications for AO | 108d? | 2008-10-01 | 2009-02-27 | 585d | finish no earlier than 2009-02-27 |  |
| 300 | 1.3.7.3 | Infrastructure modifications for Laser System | 65d? | 2009-05-01 | 2009-07-30 | 476d | finish no earlier than 2009-07-30 |  |
| 301 | 1.3.7.4 | OSIRIS Modifications | 88d? | 2008-10-01 | 2009-01-30 | 605d | finish no earlier than 2009-01-30 |  |
| 302 | 1.3.7.5 | Interferometer & OHANA Modifications | 64d? | 2009-02-02 | 2009-04-30 | 541d | finish no earlier than 2009-04-30 |  |
| 303 | 1.3.8 | **Telescope Integration & Test** | 1d? | 2008-04-01 | 2008-04-01 | 823d |  | 270h |
| 304 | 1.3.8.1 | **Old AO/Laser Removal** | 1d? | 2008-04-01 | 2008-04-01 | 823d |  | 120h |
| 305 | 1.3.8.1.1 | AO Removal Plan | 1d? | 2008-04-01 | 2008-04-01 | 823d |  | 60h |
| 306 | 1.3.8.1.2 | Laser Removal Plan | 1d? | 2008-04-01 | 2008-04-01 | 823d |  | 60h |
| 307 | 1.3.8.2 | Laser Enclosure Integration | 1d? | 2008-04-01 | 2008-04-01 | 823d |  |  |
| 308 | 1.3.8.3 | AO Enclosure Integration | 1d? | 2008-04-01 | 2008-04-01 | 823d |  |  |

| ID | WBS | Task | Duration | Start | Finish | Total slack | Constraint | Work |
| --- | --- | --- | --- | --- | --- | --- | --- | --- |
| 309 | 1.3.8.4 | **AO System Install + I&T** | 1d? | 2008-04-01 | 2008-04-01 | 823d |  | 150h |
| 310 | 1.3.8.4.1 | AO System Install | 1d? | 2008-04-01 | 2008-04-01 | 823d |  | 100h |
| 311 | 1.3.8.4.2 | AO System Integration | 1d? | 2008-04-01 | 2008-04-01 | 823d |  | 40h |
| 312 | 1.3.8.4.3 | AO System Test | 1d? | 2008-04-01 | 2008-04-01 | 823d |  | 10h |
| 313 | 1.3.8.5 | Laser System Install + I&T | 1d? | 2008-04-01 | 2008-04-01 | 823d |  |  |
| 314 | 1.3.8.6 | LGS AO System On-sky I&T | 1d? | 2008-04-01 | 2008-04-01 | 823d |  |  |
| 315 | 1.3.8.7 | Performance Characterization | 1d? | 2008-04-01 | 2008-04-01 | 823d |  |  |
| 316 | 1.3.8.8 | Science Verification | 1d? | 2008-04-01 | 2008-04-01 | 823d |  |  |
| 317 | 1.3.9 | **Operations Transition** | 1d? | 2008-04-01 | 2008-04-01 | 823d |  |  |
| 318 | 1.3.9.1 | Operations Plans | 1d? | 2008-04-01 | 2008-04-01 | 823d |  |  |
| 319 | 1.3.9.2 | Operations Handover | 1d? | 2008-04-01 | 2008-04-01 | 823d |  |  |
| 320 | 1.4 | **Detailed Design** | 824d? | 2008-04-01 | 2011-05-27 | 0d |  | 9745h |
| 321 | 1.4.1 | Placeholder | 1d? | 2008-04-01 | 2008-04-01 | 823d |  |  |
| 322 | 1.4.2 | **DD Phase Management** | 824d? | 2008-04-01 | 2011-05-27 | 0d |  | 8615h |
| 323 | 1.4.2.1 | **Planning** | 824d? | 2008-04-01 | 2011-05-27 | 0d |  | 1980h |
| 324 | 1.4.2.1.1 | **Replans** | 449d? | 2008-04-01 | 2009-12-18 | 375d |  | 380h |
| 325 | 1.4.2.1.1.1 | Replan based on PDR | 20d? | 2009-11-23 | 2009-12-18 | 375d | finish no earlier than 2009-12-18 | 60h |
| 326 | 1.4.2.1.1.2 | Replan 1 | 1d? | 2008-04-01 | 2008-04-01 | 823d |  | 160h |
| 327 | 1.4.2.1.1.3 | Replan 2 | 1d? | 2008-04-01 | 2008-04-01 | 823d |  | 160h |
| 328 | 1.4.2.1.2 | **WMKO FY Plans** | 345d? | 2010-02-01 | 2011-05-27 | 0d |  | 80h |
| 329 | 1.4.2.1.2.1 | Support WMKO FY11 Planning | 85d? | 2010-02-01 | 2010-05-28 | 260d | start no earlier than 2010-02-01 | 40h |
| 330 | 1.4.2.1.2.2 | Support WMKO FY12 Planning | 84d? | 2011-02-01 | 2011-05-27 | 0d | finish no earlier than 2011-05-27 | 40h |
| 331 | 1.4.2.1.3 | **Systems Engineering Management Plan** | 1d? | 2008-04-01 | 2008-04-01 | 823d |  | 1520h |
| 332 | 1.4.2.1.3.1 | **Project Plan** | 1d? | 2008-04-01 | 2008-04-01 | 823d |  | 1400h |
| 333 | 1.4.2.1.3.1.1 | PBS, WBS & Task Definition | 1d? | 2008-04-01 | 2008-04-01 | 823d |  | 200h |
| 334 | 1.4.2.1.3.1.2 | Cost Estimation | 1d? | 2008-04-01 | 2008-04-01 | 823d |  | 560h |
| 335 | 1.4.2.1.3.1.3 | Full Schedule | 1d? | 2008-04-01 | 2008-04-01 | 823d |  | 640h |
| 336 | 1.4.2.1.3.2 | SEMP Document | 1d? | 2008-04-01 | 2008-04-01 | 823d |  | 120h |

| ID | WBS | Task | Type | Duration | Start | Finish | Total slack | Constraint | Work |
| --- | --- | --- | --- | --- | --- | --- | --- | --- | --- |
| 337 | 1.4.2.2 | **Project Management & Meetings** |  | 1d? | 2008-04-01 | 2008-04-01 | 823d |  | 3600h |
| 338 | 1.4.2.2.1 | Executive Committee |  | 1d? | 2008-04-01 | 2008-04-01 | 823d |  | 700h |
| 339 | 1.4.2.2.2 | Team Meetings |  | 1d? | 2008-04-01 | 2008-04-01 | 823d |  | 2900h |
| 340 | 1.4.2.2.3 | Director Telecons |  | 1d? | 2008-04-01 | 2008-04-01 | 823d |  |  |
| 341 | 1.4.2.3 | **Tracking & Reporting** |  | 1d? | 2008-04-01 | 2008-04-01 | 823d |  | 1535h |
| 342 | 1.4.2.3.1 | Monthly Team Status Reports |  | 1d? | 2008-04-01 | 2008-04-01 | 823d |  | 855h |
| 343 | 1.4.2.3.2 | SSC Meetings |  | 1d? | 2008-04-01 | 2008-04-01 | 823d |  | 180h |
| 344 | 1.4.2.3.3 | Other Presentations |  | 1d? | 2008-04-01 | 2008-04-01 | 823d |  | 500h |
| 345 | 1.4.2.4 | **Proposals & Fundraising** |  | 1d? | 2008-04-01 | 2008-04-01 | 823d |  | 380h |
| 346 | 1.4.2.4.1 | Support Advancement Office |  | 1d? | 2008-04-01 | 2008-04-01 | 823d |  | 120h |
| 347 | 1.4.2.4.2 | Proposal(s) for Fabrication |  | 1d? | 2008-04-01 | 2008-04-01 | 823d |  | 260h |
| 348 | 1.4.2.5 | **Programmatic Risk Assessment & Mitigation** |  | 1d? | 2008-04-01 | 2008-04-01 | 823d |  | 560h |
| 349 | 1.4.2.5.1 | Risk Assessment |  | 1d? | 2008-04-01 | 2008-04-01 | 823d |  | 60h |
| 350 | 1.4.2.5.2 | Risk Mitigation |  | 1d? | 2008-04-01 | 2008-04-01 | 823d |  | 500h |
| 351 | 1.4.2.6 | **Detailed Design Review** |  | 131d? | 2010-11-17 | 2011-05-18 | 7d |  | 560h |
| 352 | 1.4.2.6.1 | Review Setup |  | 3d? | 2010-11-17 | 2010-11-19 | 135d | finish no earlier than 2010-11-19 | 16h |
| 353 | 1.4.2.6.2 | Detailed Design Report |  | 14d? | 2011-03-07 | 2011-03-24 | 46d | finish no earlier than 2011-03-24 | 80h |
| 354 | 1.4.2.6.3 | Review Package Distributed |  | 1d? | 2011-03-25 | 2011-03-25 | 45d | finish no earlier than 2011-03-25 | 4h |
| 355 | 1.4.2.6.4 | Review Comments Received | milestone | 0d | 2011-04-08 | 2011-04-08 | 36d | start no earlier than 2011-04-08 |  |
| 356 | 1.4.2.6.5 | Reviewer Comments Addressed |  | 5d? | 2011-04-11 | 2011-04-15 | 30d | finish no earlier than 2011-04-15 | 120h |
| 357 | 1.4.2.6.6 | DDR Presentation Preparation |  | 15d? | 2011-03-28 | 2011-04-15 | 30d | finish no earlier than 2011-04-15 | 120h |
| 358 | 1.4.2.6.7 | Detailed Design Review |  | 1d? | 2011-04-20 | 2011-04-20 | 27d | start no earlier than 2011-04-20 | 160h |
| 359 | 1.4.2.6.8 | Reviewer Report Received | milestone | 0d | 2011-05-11 | 2011-05-11 | 13d | start no earlier than 2011-05-11 |  |
| 360 | 1.4.2.6.9 | Response to Reviewer Report |  | 5d? | 2011-05-12 | 2011-05-18 | 7d | finish no earlier than 2011-05-18 | 60h |

| ID | WBS | Task | Duration | Start | Finish | Total slack |
| --- | --- | --- | --- | --- | --- | --- |
| 361 | 1.4.2.7 | **Management Support** | 1d? | 2008-04-01 | 2008-04-01 | 823d |
| 362 | 1.4.2.7.1 | Administrative Support | 1d? | 2008-04-01 | 2008-04-01 | 823d |
| 363 | 1.4.2.7.2 | Shared Infrastructure | 1d? | 2008-04-01 | 2008-04-01 | 823d |
| 364 | 1.4.2.7.3 | Research Time | 1d? | 2008-04-01 | 2008-04-01 | 823d |
| 365 | 1.4.3 | **Systems Engineering** | 1d? | 2008-04-01 | 2008-04-01 | 823d |
| 366 | 1.4.3.1 | Science Case Development | 1d? | 2008-04-01 | 2008-04-01 | 823d |
| 367 | 1.4.3.2 | **Requirements** | 1d? | 2008-04-01 | 2008-04-01 | 823d |
| 368 | 1.4.3.2.1 | Science Requirements | 1d? | 2008-04-01 | 2008-04-01 | 823d |
| 369 | 1.4.3.2.2 | Operations Concept Document | 1d? | 2008-04-01 | 2008-04-01 | 823d |
| 370 | 1.4.3.2.3 | System Requirements | 1d? | 2008-04-01 | 2008-04-01 | 823d |
| 371 | 1.4.3.2.4 | Functional Requirements | 1d? | 2008-04-01 | 2008-04-01 | 823d |
| 372 | 1.4.3.3 | **System Architecture** | 1d? | 2008-04-01 | 2008-04-01 | 823d |
| 373 | 1.4.3.3.1 | Opto-Mechanical Architecture | 1d? | 2008-04-01 | 2008-04-01 | 823d |
| 374 | 1.4.3.3.2 | Software Architecture | 1d? | 2008-04-01 | 2008-04-01 | 823d |
| 375 | 1.4.3.3.3 | Motion Control / Electronics Architecture | 1d? | 2008-04-01 | 2008-04-01 | 823d |
| 376 | 1.4.3.4 | Modeling & Analysis | 1d? | 2008-04-01 | 2008-04-01 | 823d |
| 377 | 1.4.3.5 | **Performance Budgets** | 1d? | 2008-04-01 | 2008-04-01 | 823d |
| 378 | 1.4.3.5.1 | Throughput & Background | 1d? | 2008-04-01 | 2008-04-01 | 823d |
| 379 | 1.4.3.5.2 | Wavefront & Encircled Energy | 1d? | 2008-04-01 | 2008-04-01 | 823d |
| 380 | 1.4.3.5.3 | Astrometric | 1d? | 2008-04-01 | 2008-04-01 | 823d |
| 381 | 1.4.3.5.4 | Photometric | 1d? | 2008-04-01 | 2008-04-01 | 823d |
| 382 | 1.4.3.5.5 | Companion Sensitivity | 1d? | 2008-04-01 | 2008-04-01 | 823d |
| 383 | 1.4.3.5.6 | Polarimetry | 1d? | 2008-04-01 | 2008-04-01 | 823d |
| 384 | 1.4.3.5.7 | Observing Efficiency | 1d? | 2008-04-01 | 2008-04-01 | 823d |
| 385 | 1.4.3.5.8 | Observing Uptime | 1d? | 2008-04-01 | 2008-04-01 | 823d |

| ID | WBS | Task | Duration | Start | Finish | Total slack | Work |
| --- | --- | --- | --- | --- | --- | --- | --- |
| 386 | 1.4.3.6 | **External Interface Control** | 1d? | 2008-04-01 | 2008-04-01 | 823d |  |
| 387 | 1.4.3.6.1 | **Observatory Interfaces** | 1d? | 2008-04-01 | 2008-04-01 | 823d |  |
| 388 | 1.4.3.6.1.1 | AO System | 1d? | 2008-04-01 | 2008-04-01 | 823d |  |
| 389 | 1.4.3.6.1.2 | Laser System | 1d? | 2008-04-01 | 2008-04-01 | 823d |  |
| 390 | 1.4.3.6.2 | Science Instrument Requirements Input & Review | 1d? | 2008-04-01 | 2008-04-01 | 823d |  |
| 391 | 1.4.3.6.3 | **Science Instrument Interfaces** | 1d? | 2008-04-01 | 2008-04-01 | 823d |  |
| 392 | 1.4.3.6.3.1 | Generic Science Instrument ICD | 1d? | 2008-04-01 | 2008-04-01 | 823d |  |
| 393 | 1.4.3.6.3.2 | Interferometer & OHANA ICD | 1d? | 2008-04-01 | 2008-04-01 | 823d |  |
| 394 | 1.4.3.6.3.3 | OSIRIS ICD | 1d? | 2008-04-01 | 2008-04-01 | 823d |  |
| 395 | 1.4.3.6.3.4 | NIR Camera ICD | 1d? | 2008-04-01 | 2008-04-01 | 823d |  |
| 396 | 1.4.3.6.3.5 | Visible Camera ICD | 1d? | 2008-04-01 | 2008-04-01 | 823d |  |
| 397 | 1.4.3.6.3.6 | Deployabe IFS ICD | 1d? | 2008-04-01 | 2008-04-01 | 823d |  |
| 398 | 1.4.3.7 | Internal Interface Control | 1d? | 2008-04-01 | 2008-04-01 | 823d |  |
| 399 | 1.4.3.8 | Configuration Control | 1d? | 2008-04-01 | 2008-04-01 | 823d |  |
| 400 | 1.4.3.9 | Documentation Control | 1d? | 2008-04-01 | 2008-04-01 | 823d |  |
| 401 | 1.4.3.10 | **Technical Risk Assessment & Mitigation** | 1d? | 2008-04-01 | 2008-04-01 | 823d |  |
| 402 | 1.4.3.10.1 | Risk Assessment | 1d? | 2008-04-01 | 2008-04-01 | 823d |  |
| 403 | 1.4.3.10.2 | Risk Mitigation Efforts | 1d? | 2008-04-01 | 2008-04-01 | 823d |  |
| 404 | 1.4.3.11 | Detailed Design Manual | 1d? | 2008-04-01 | 2008-04-01 | 823d |  |
| 405 | 1.4.4 | **AO System Design** | 1d? | 2008-04-01 | 2008-04-01 | 823d | 200h |
| 406 | 1.4.4.1 | AO Enclosure | 1d? | 2008-04-01 | 2008-04-01 | 823d |  |
| 407 | 1.4.4.2 | **Opto-Mechanical** | 1d? | 2008-04-01 | 2008-04-01 | 823d |  |
| 408 | 1.4.4.2.1 | **AO Support Structure** | 1d? | 2008-04-01 | 2008-04-01 | 823d |  |
| 409 | 1.4.4.2.1.1 | Optics Bench | 1d? | 2008-04-01 | 2008-04-01 | 823d |  |
| 410 | 1.4.4.2.1.2 | Interface to Nasmyth Platform | 1d? | 2008-04-01 | 2008-04-01 | 823d |  |
| 411 | 1.4.4.2.1.3 | Level 2 Support | 1d? | 2008-04-01 | 2008-04-01 | 823d |  |
| 412 | 1.4.4.2.2 | Rotator | 1d? | 2008-04-01 | 2008-04-01 | 823d |  |

| ID | WBS | Task | Duration | Start | Finish | Total slack |
| --- | --- | --- | --- | --- | --- | --- |
| 413 | 1.4.4.2.3 | **Optical Relays** | 1d? | 2008-04-01 | 2008-04-01 | 823d |
| 414 | 1.4.4.2.3.1 | Entrance Window & Mount | 1d? | 2008-04-01 | 2008-04-01 | 823d |
| 415 | 1.4.4.2.3.2 | OAP1 & Mount | 1d? | 2008-04-01 | 2008-04-01 | 823d |
| 416 | 1.4.4.2.3.3 | Fold Mirror & Mount | 1d? | 2008-04-01 | 2008-04-01 | 823d |
| 417 | 1.4.4.2.3.4 | Woofer DM Mount | 1d? | 2008-04-01 | 2008-04-01 | 823d |
| 418 | 1.4.4.2.3.5 | OAP2 & Mount | 1d? | 2008-04-01 | 2008-04-01 | 823d |
| 419 | 1.4.4.2.3.6 | OAP3 & Mount | 1d? | 2008-04-01 | 2008-04-01 | 823d |
| 420 | 1.4.4.2.3.7 | Tweeter DM Mount | 1d? | 2008-04-01 | 2008-04-01 | 823d |
| 421 | 1.4.4.2.3.8 | OAP4 & Mount | 1d? | 2008-04-01 | 2008-04-01 | 823d |
| 422 | 1.4.4.2.4 | Optical Switchyard | 1d? | 2008-04-01 | 2008-04-01 | 823d |
| 423 | 1.4.4.2.5 | LGS Wavefront Sensor Assembly | 1d? | 2008-04-01 | 2008-04-01 | 823d |
| 424 | 1.4.4.2.6 | NGS WFS/TWFS Assembly | 1d? | 2008-04-01 | 2008-04-01 | 823d |
| 425 | 1.4.4.2.7 | Low Order Wavefront Sensor Assembly | 1d? | 2008-04-01 | 2008-04-01 | 823d |
| 426 | 1.4.4.2.8 | Tip/Tilt Vibration Mitigation | 1d? | 2008-04-01 | 2008-04-01 | 823d |
| 427 | 1.4.4.2.9 | **Acquisition Cameras** | 1d? | 2008-04-01 | 2008-04-01 | 823d |
| 428 | 1.4.4.2.9.1 | NGS Acquisition Camera | 1d? | 2008-04-01 | 2008-04-01 | 823d |
| 429 | 1.4.4.2.9.2 | LGS Acquisition Camera | 1d? | 2008-04-01 | 2008-04-01 | 823d |
| 430 | 1.4.4.2.10 | **Atmospheric Dispersion Correctors** | 1d? | 2008-04-01 | 2008-04-01 | 823d |
| 431 | 1.4.4.2.10.1 | LOWFS ADCs | 1d? | 2008-04-01 | 2008-04-01 | 823d |
| 432 | 1.4.4.2.10.2 | NIR Science ADC | 1d? | 2008-04-01 | 2008-04-01 | 823d |
| 433 | 1.4.4.2.10.3 | Visible Science ADC | 1d? | 2008-04-01 | 2008-04-01 | 823d |
| 434 | 1.4.4.2.10.4 | NGS Wavefront Sensor ADC | 1d? | 2008-04-01 | 2008-04-01 | 823d |
| 435 | 1.4.4.3 | **Alignment, Calibration & Diagnostics** | 1d? | 2008-04-01 | 2008-04-01 | 823d |
| 436 | 1.4.4.3.1 | Simulator | 1d? | 2008-04-01 | 2008-04-01 | 823d |
| 437 | 1.4.4.3.2 | System Alignment Tools | 1d? | 2008-04-01 | 2008-04-01 | 823d |
| 438 | 1.4.4.3.3 | Atmospheric Profiler | 1d? | 2008-04-01 | 2008-04-01 | 823d |
| 439 | 1.4.4.3.4 | PSF Monitoring Camera | 1d? | 2008-04-01 | 2008-04-01 | 823d |

| ID | WBS | Task | Duration | Start | Finish | Total slack | Work |
| --- | --- | --- | --- | --- | --- | --- | --- |
| 440 | 1.4.4.4 | **Non-real-time Control** | 1d? | 2008-04-01 | 2008-04-01 | 823d |  |
| 441 | 1.4.4.4.1 | **Non-RTC Software** | 1d? | 2008-04-01 | 2008-04-01 | 823d |  |
| 442 | 1.4.4.4.1.1 | **AO System Sequencer** | 1d? | 2008-04-01 | 2008-04-01 | 823d |  |
| 443 | 1.4.4.4.1.1.1 | Coordination Sequence | 1d? | 2008-04-01 | 2008-04-01 | 823d |  |
| 444 | 1.4.4.4.1.1.2 | Command Interface | 1d? | 2008-04-01 | 2008-04-01 | 823d |  |
| 445 | 1.4.4.4.1.1.3 | Data Interface | 1d? | 2008-04-01 | 2008-04-01 | 823d |  |
| 446 | 1.4.4.4.1.1.4 | Health Monitor | 1d? | 2008-04-01 | 2008-04-01 | 823d |  |
| 447 | 1.4.4.4.1.2 | **Low Level AO Control** | 1d? | 2008-04-01 | 2008-04-01 | 823d |  |
| 448 | 1.4.4.4.1.2.1 | **Motion Control** | 1d? | 2008-04-01 | 2008-04-01 | 823d |  |
| 449 | 1.4.4.4.1.2.1.1 | High-level Motion Control | 1d? | 2008-04-01 | 2008-04-01 | 823d |  |
| 450 | 1.4.4.4.1.2.1.2 | Low-Level Motion Control | 1d? | 2008-04-01 | 2008-04-01 | 823d |  |
| 451 | 1.4.4.4.1.2.2 | Camera Control | 1d? | 2008-04-01 | 2008-04-01 | 823d |  |
| 452 | 1.4.4.4.1.2.3 | DM & TT Mirror Control | 1d? | 2008-04-01 | 2008-04-01 | 823d |  |
| 453 | 1.4.4.4.1.2.4 | RTC Control | 1d? | 2008-04-01 | 2008-04-01 | 823d |  |
| 454 | 1.4.4.4.1.2.5 | Environmental Control | 1d? | 2008-04-01 | 2008-04-01 | 823d |  |
| 455 | 1.4.4.4.2 | **Non-RTC Hardware** | 1d? | 2008-04-01 | 2008-04-01 | 823d |  |
| 456 | 1.4.4.4.2.1 | Motion Control Electronics | 1d? | 2008-04-01 | 2008-04-01 | 823d |  |
| 457 | 1.4.4.4.2.2 | Power Distribution & Control | 1d? | 2008-04-01 | 2008-04-01 | 823d |  |
| 458 | 1.4.4.4.2.3 | Other Electronics | 1d? | 2008-04-01 | 2008-04-01 | 823d |  |
| 459 | 1.4.4.5 | Real-time Control | 1d? | 2008-04-01 | 2008-04-01 | 823d |  |
| 460 | 1.4.4.6 | **AO System Lab I&T** | 1d? | 2008-04-01 | 2008-04-01 | 823d | 200h |
| 461 | 1.4.4.6.1 | AO System Lab Facility Plan | 1d? | 2008-04-01 | 2008-04-01 | 823d | 120h |
| 462 | 1.4.4.6.2 | AO System Lab Integration Plan | 1d? | 2008-04-01 | 2008-04-01 | 823d | 40h |
| 463 | 1.4.4.6.3 | AO System Lab Test Plan | 1d? | 2008-04-01 | 2008-04-01 | 823d | 40h |

| ID | WBS | Task | Duration | Start | Finish | Total slack |
| --- | --- | --- | --- | --- | --- | --- |
| 464 | 1.4.5 | **Laser System Design** | 1d? | 2008-04-01 | 2008-04-01 | 823d |
| 465 | 1.4.5.1 | Laser Enclosure | 1d? | 2008-04-01 | 2008-04-01 | 823d |
| 466 | 1.4.5.2 | Laser | 1d? | 2008-04-01 | 2008-04-01 | 823d |
| 467 | 1.4.5.3 | **Laser Launch Facility** | 1d? | 2008-04-01 | 2008-04-01 | 823d |
| 468 | 1.4.5.3.1 | Beam Transport | 1d? | 2008-04-01 | 2008-04-01 | 823d |
| 469 | 1.4.5.3.2 | Laser Pointing & Diagnostics | 1d? | 2008-04-01 | 2008-04-01 | 823d |
| 470 | 1.4.5.3.3 | Launch Telescope | 1d? | 2008-04-01 | 2008-04-01 | 823d |
| 471 | 1.4.5.4 | Laser Safety Systems | 1d? | 2008-04-01 | 2008-04-01 | 823d |
| 472 | 1.4.5.5 | Laser System Control | 1d? | 2008-04-01 | 2008-04-01 | 823d |
| 473 | 1.4.5.6 | Laser System Lab I&T | 1d? | 2008-04-01 | 2008-04-01 | 823d |
| 474 | 1.4.6 | **Science Operations Tools Design** | 1d? | 2008-04-01 | 2008-04-01 | 823d |
| 475 | 1.4.6.1 | **Multi-Systems Command Sequencer** | 1d? | 2008-04-01 | 2008-04-01 | 823d |
| 476 | 1.4.6.1.1 | Sequencer Infrastructure | 1d? | 2008-04-01 | 2008-04-01 | 823d |
| 477 | 1.4.6.1.2 | Setup Sequences: Configurations & Calibrations | 1d? | 2008-04-01 | 2008-04-01 | 823d |
| 478 | 1.4.6.1.3 | **Observing Sequences** | 1d? | 2008-04-01 | 2008-04-01 | 823d |
| 479 | 1.4.6.1.3.1 | Acquisition | 1d? | 2008-04-01 | 2008-04-01 | 823d |
| 480 | 1.4.6.1.3.2 | Observing Sequences | 1d? | 2008-04-01 | 2008-04-01 | 823d |
| 481 | 1.4.6.1.3.3 | Performance Monitoring & Optimization | 1d? | 2008-04-01 | 2008-04-01 | 823d |
| 482 | 1.4.6.1.4 | Data Logging & Troubleshooting | 1d? | 2008-04-01 | 2008-04-01 | 823d |
| 483 | 1.4.6.2 | **User Interfaces** | 1d? | 2008-04-01 | 2008-04-01 | 823d |
| 484 | 1.4.6.2.1 | User Interface Infrastructure | 1d? | 2008-04-01 | 2008-04-01 | 823d |
| 485 | 1.4.6.2.2 | Setup User Interfaces | 1d? | 2008-04-01 | 2008-04-01 | 823d |
| 486 | 1.4.6.2.3 | Observation User Interfaces | 1d? | 2008-04-01 | 2008-04-01 | 823d |
| 487 | 1.4.6.3 | **Pre- & Post-Observing Science Support Tools** | 1d? | 2008-04-01 | 2008-04-01 | 823d |
| 488 | 1.4.6.3.1 | User Documentation | 1d? | 2008-04-01 | 2008-04-01 | 823d |

| ID | WBS | Task | Duration | Start | Finish | Total slack | Work |
| --- | --- | --- | --- | --- | --- | --- | --- |
| 489 | 1.4.6.3.2 | **Planning Tools** | 1d? | 2008-04-01 | 2008-04-01 | 823d |  |
| 490 | 1.4.6.3.2.1 | Science Observations Planning Tools | 1d? | 2008-04-01 | 2008-04-01 | 823d |  |
| 491 | 1.4.6.3.2.2 | Laser Clearinghouse Coordination Tool | 1d? | 2008-04-01 | 2008-04-01 | 823d |  |
| 492 | 1.4.6.3.3 | **Data Products** | 1d? | 2008-04-01 | 2008-04-01 | 823d |  |
| 493 | 1.4.6.3.3.1 | Generic Data Products | 1d? | 2008-04-01 | 2008-04-01 | 823d |  |
| 494 | 1.4.6.3.3.2 | Science Data Quality Assessment | 1d? | 2008-04-01 | 2008-04-01 | 823d |  |
| 495 | 1.4.6.3.3.3 | Science Data Archiving | 1d? | 2008-04-01 | 2008-04-01 | 823d |  |
| 496 | 1.4.6.4 | Data Server | 1d? | 2008-04-01 | 2008-04-01 | 823d |  |
| 497 | 1.4.7 | **Telescope & Summit Engineering Design** | 1d? | 2008-04-01 | 2008-04-01 | 823d | 240h |
| 498 | 1.4.7.1 | Telescope Performance | 1d? | 2008-04-01 | 2008-04-01 | 823d | 240h |
| 499 | 1.4.7.2 | Infrastructure Modifications for AO | 1d? | 2008-04-01 | 2008-04-01 | 823d |  |
| 500 | 1.4.7.3 | Infrastructure modifications for Laser System | 1d? | 2008-04-01 | 2008-04-01 | 823d |  |
| 501 | 1.4.7.4 | OSIRIS Modifications | 1d? | 2008-04-01 | 2008-04-01 | 823d |  |
| 502 | 1.4.7.5 | Interferometer & OHANA Modifications | 1d? | 2008-04-01 | 2008-04-01 | 823d |  |
| 503 | 1.4.8 | **Telescope Integration & Test** | 1d? | 2008-04-01 | 2008-04-01 | 823d | 690h |
| 504 | 1.4.8.1 | **Old AO/Laser Removal** | 1d? | 2008-04-01 | 2008-04-01 | 823d | 480h |
| 505 | 1.4.8.1.1 | AO Removal Plan | 1d? | 2008-04-01 | 2008-04-01 | 823d | 240h |
| 506 | 1.4.8.1.2 | Laser Removal Plan | 1d? | 2008-04-01 | 2008-04-01 | 823d | 240h |
| 507 | 1.4.8.2 | Laser Enclosure Integration | 1d? | 2008-04-01 | 2008-04-01 | 823d |  |
| 508 | 1.4.8.3 | AO Enclosure Integration | 1d? | 2008-04-01 | 2008-04-01 | 823d |  |
| 509 | 1.4.8.4 | **AO System Install + I&T** | 1d? | 2008-04-01 | 2008-04-01 | 823d | 210h |
| 510 | 1.4.8.4.1 | AO System Install | 1d? | 2008-04-01 | 2008-04-01 | 823d | 160h |
| 511 | 1.4.8.4.2 | AO System Integration | 1d? | 2008-04-01 | 2008-04-01 | 823d | 40h |
| 512 | 1.4.8.4.3 | AO System Test | 1d? | 2008-04-01 | 2008-04-01 | 823d | 10h |
| 513 | 1.4.8.5 | Laser System Install + I&T | 1d? | 2008-04-01 | 2008-04-01 | 823d |  |
| 514 | 1.4.8.6 | LGS AO System On-sky I&T | 1d? | 2008-04-01 | 2008-04-01 | 823d |  |
| 515 | 1.4.8.7 | Performance Characterization | 1d? | 2008-04-01 | 2008-04-01 | 823d |  |
| 516 | 1.4.8.8 | Science Verification | 1d? | 2008-04-01 | 2008-04-01 | 823d |  |

| ID | WBS | Task | Duration | Start | Finish | Total slack |
| --- | --- | --- | --- | --- | --- | --- |
| 517 | 1.4.9 | **Operations Transition** | 1d? | 2008-04-01 | 2008-04-01 | 823d |
| 518 | 1.4.9.1 | Operations Plans | 1d? | 2008-04-01 | 2008-04-01 | 823d |
| 519 | 1.4.9.2 | Operations Handover | 1d? | 2008-04-01 | 2008-04-01 | 823d |
