# NGAO Design v4

Schedule from MS Project, 2005-10-03 to 2011-05-27.
CARA

## Calendars

- Standard: Mon-Fri 08:00-12:00, 13:00-17:00; Sat-Sun off.

## Resources

| Resource |
| --- |
| Dekany |
| Gavel |
| Max |
| Wizinowich |
| Other |
| Adkins |
| McGrath |
| Tyau |
| Le Mignant |
| Bell |
| Chin |
| Johannson |
| Kupke |
| Lockwood |
| Neyman |
| Reinig |
| Velur |
| Free |
| Student |
| Scientist |
| LeMignant |
| M |
| Sc |
| Johansson |
| Johansso |
| Wetherell |
| Medeiros |
| C |
| Nance |
| Summers |
| Weterell |
| Chinl |
| Tech |
| Bouchez |
| Kissner |
| Chock |

## Schedule

| ID | WBS | Task | Duration | Start | Finish | Total slack | Constraint | Resources | Work |
| --- | --- | --- | --- | --- | --- | --- | --- | --- | --- |
| 1 | 1 | **NGAO Design** | 1475d? | 2005-10-03 | 2011-05-27 | 0d |  |  | 44297h |
| 2 | 1.1 | Proposal | 195d? | 2005-10-03 | 2006-06-30 | 1280d | finish no earlier than 2006-06-30 |  |  |
| 3 | 1.2 | System Design | 413d? | 2006-10-02 | 2008-04-30 | 802d | finish no earlier than 2008-04-30 |  |  |
| 4 | 1.3 | **Preliminary Design** | 434d? | 2008-04-01 | 2009-11-27 | 390d |  |  | 34552h |
| 5 | 1.3.1 | Reserved | 1d? | 2008-05-01 | 2008-05-01 | 801d | start no earlier than 2008-05-01 |  |  |
| 6 | 1.3.2 | **PD Phase Management** | 434d? | 2008-04-01 | 2009-11-27 | 390d |  |  | 8987h |
| 7 | 1.3.2.1 | **Planning** | 361d? | 2008-05-02 | 2009-09-18 | 440d |  |  | 1650h |
| 8 | 1.3.2.1.1 | **Replans (PD phase)** | 260d? | 2008-05-02 | 2009-04-30 | 541d |  |  | 190h |
| 9 | 1.3.2.1.1.1 | Replan based on SDR | 6d? | 2008-05-02 | 2008-05-09 | 795d | finish no earlier than 2008-05-09 | Dekany [12.5%]; Gavel [12.5%]; Wizinowich [25%]; Other [12.5%] | 30h |
| 10 | 1.3.2.1.1.2 | Replan 1 | 13.2d? | 2008-10-13 | 2008-10-30 | 671d | finish no earlier than 2008-10-30 | Dekany [15.2%]; Gavel [15.2%]; Wizinowich [34.1%]; Other [11.4%] | 80h |
| 11 | 1.3.2.1.1.3 | Replan 2 | 14d? | 2009-04-13 | 2009-04-30 | 541d | start no earlier than 2009-04-13 | Dekany [14.3%]; Gavel [14.3%]; Wizinowich [28.6%]; Other [14.3%] | 80h |
| 12 | 1.3.2.1.2 | **WMKO FY Plans** | 280d? | 2008-05-05 | 2009-05-29 | 520d |  |  | 40h |
| 13 | 1.3.2.1.2.1 | Support WMKO FY09 Planning | 20d? | 2008-05-05 | 2008-05-30 | 780d | start no earlier than 2008-05-05 | Wizinowich [6.2%] | 10h |
| 14 | 1.3.2.1.2.2 | Support WMKO FY10 Planning | 85d? | 2009-02-02 | 2009-05-29 | 520d | start no earlier than 2009-02-02 | Wizinowich [4.4%] | 30h |
| 15 | 1.3.2.1.3 | **Systems Engineering Management Plan** | 123d? | 2009-04-01 | 2009-09-18 | 440d |  |  | 1420h |
| 16 | 1.3.2.1.3.1 | **Project Plan** | 50d? | 2009-07-06 | 2009-09-11 | 445d |  |  | 1020h |
| 17 | 1.3.2.1.3.1.1 | PBS, WBS & Task Definition | 15d? | 2009-07-06 | 2009-07-24 | 480d | finish no earlier than 2009-07-24 | Dekany [33.3%]; Gavel [33.3%]; Wizinowich [33.3%]; Max [8.3%]; Other [108.3%] | 260h |
| 18 | 1.3.2.1.3.1.2 | Cost Estimation | 20d? | 2009-07-27 | 2009-08-21 | 460d | start no earlier than 2009-07-27 | Dekany [50%]; Gavel [37.5%]; Max [6.2%]; Wizinowich [37.5%]; Other [168.8%] | 480h |
| 19 | 1.3.2.1.3.1.3 | Full Schedule (MS Project Plan) | 25d? | 2009-08-10 | 2009-09-11 | 445d | start no earlier than 2009-08-10 | Wizinowich [30%]; Dekany [15%]; Gavel [15%]; Max [5%]; Other [75%] | 280h |
| 20 | 1.3.2.1.3.2 | **Detailed Design Phase Plan** | 112d? | 2009-04-01 | 2009-09-03 | 451d |  |  | 320h |
| 21 | 1.3.2.1.3.2.1 | Detailed Design Plan v1 (FY10 planning) | 33d? | 2009-04-01 | 2009-05-15 | 530d | finish no earlier than 2009-05-15 | Wizinowich [15.2%] | 40h |
| 22 | 1.3.2.1.3.2.2 | Detailed Design Plan v2 (TSIP proposal) | 18d? | 2009-07-15 | 2009-08-07 | 470d | start no earlier than 2009-07-15 | Wizinowich [22.2%]; Dekany [27.8%]; Gavel [27.8%] | 40h |
| 23 | 1.3.2.1.3.2.3 | Detailed Design Plan Final Version | 19d? | 2009-08-10 | 2009-09-03 | 451d | start no earlier than 2009-08-10 | Wizinowich [46.1%]; Dekany [19.7%]; Gavel [19.7%]; Max [6.6%]; Other [65.8%] | 240h |
| 24 | 1.3.2.1.3.3 | SEMP Document | 15d? | 2009-08-31 | 2009-09-18 | 440d | finish no earlier than 2009-09-18 | Wizinowich [30%]; Dekany [66.7%]; Gavel [66.7%]; Max [66.7%] | 80h |

Notes:
- 6: PW
- 7: PW
- 15: PW
- 17: PW
- 18: RD
- 19: PW
- 20: PW
- 21: PW
- 22: PW
- 23: PW
- 24: PW

| ID | WBS | Task | Type | Duration | Start | Finish | Total slack | Constraint | Resources | Work |
| --- | --- | --- | --- | --- | --- | --- | --- | --- | --- | --- |
| 25 | 1.3.2.2 | **Project Management & Meetings** |  | 363d? | 2008-04-30 | 2009-09-18 | 440d |  |  | 2500h |
| 26 | 1.3.2.2.1 | **Executive Committee** |  | 15.62d? | 2008-05-01 | 2008-05-22 | 786.38d |  |  | 600h |
| 27 | 1.3.2.2.1.1 | Executive Committee Management Activities |  | 15.62d? | 2008-05-01 | 2008-05-22 | 786.38d | start no earlier than 2008-05-01 | Dekany; Gavel; Max; Wizinowich | 300h |
| 28 | 1.3.2.2.1.2 | Executive Committee Telecons |  | 9.38d? | 2008-05-01 | 2008-05-14 | 792.62d | start no earlier than 2008-05-01 | Dekany; Gavel; Max; Wizinowich | 300h |
| 29 | 1.3.2.2.2 | **Team Meetings** |  | 363d? | 2008-04-30 | 2009-09-18 | 440d |  |  | 1900h |
| 30 | 1.3.2.2.2.1 | Team Meeting #1 (CIT) |  | 2d? | 2008-04-30 | 2008-05-01 | 801d | start no earlier than 2008-04-30 | Dekany; Gavel; Max; Wizinowich; Other | 80h |
| 31 | 1.3.2.2.2.2 | Team Meeting #2 (telecon) |  | 1d? | 2008-06-13 | 2008-06-13 | 770d | start no earlier than 2008-06-13 |  | 60h |
| 32 | 1.3.2.2.2.3 | Team Meeting #3 (telecon) |  | 1d? | 2008-07-11 | 2008-07-11 | 750d | start no earlier than 2008-07-11 |  | 80h |
| 33 | 1.3.2.2.2.4 | Team Meeting #4 (telecon) |  | 1d? | 2008-08-15 | 2008-08-15 | 725d | start no earlier than 2008-08-15 |  | 60h |
| 34 | 1.3.2.2.2.5 | Team Meeting #5 (UC) |  | 3d? | 2008-09-16 | 2008-09-18 | 701d | finish no earlier than 2008-09-18 |  | 240h |
| 35 | 1.3.2.2.2.6 | Team Meeting #6 (telecon) |  | 1d? | 2008-10-17 | 2008-10-17 | 680d | start no earlier than 2008-10-17 |  | 60h |
| 36 | 1.3.2.2.2.7 | Team Meeting #7 (telecon) |  | 1d? | 2008-11-14 | 2008-11-14 | 660d | start no earlier than 2008-11-14 |  | 80h |
| 37 | 1.3.2.2.2.8 | Team Meeting #8 (telecon) |  | 1d? | 2008-12-12 | 2008-12-12 | 640d | start no earlier than 2008-12-12 |  | 60h |
| 38 | 1.3.2.2.2.9 | Team Meeting #9 (WMKO) |  | 4d? | 2009-01-20 | 2009-01-23 | 610d | start no earlier than 2009-01-20 |  | 320h |
| 39 | 1.3.2.2.2.10 | Team Meeting #10 (telecon) |  | 1d? | 2009-02-13 | 2009-02-13 | 595d | start no earlier than 2009-02-13 |  | 60h |
| 40 | 1.3.2.2.2.11 | Team Meeting #11 (telecon) |  | 1d? | 2009-03-13 | 2009-03-13 | 575d | start no earlier than 2009-03-13 |  | 80h |
| 41 | 1.3.2.2.2.12 | Team Meeting #12 (telecon) |  | 1d? | 2009-04-17 | 2009-04-17 | 550d | start no earlier than 2009-04-17 |  | 60h |
| 42 | 1.3.2.2.2.13 | Team Meeting #13 (CIT) |  | 3d? | 2009-05-15 | 2009-05-19 | 528d | start no earlier than 2009-05-15 |  | 240h |
| 43 | 1.3.2.2.2.14 | Team Meeting #14 (telecon) |  | 1d? | 2009-06-12 | 2009-06-12 | 510d | finish no earlier than 2009-06-12 |  | 60h |
| 44 | 1.3.2.2.2.15 | Team Meeting #15 (telecon) |  | 1d? | 2009-07-17 | 2009-07-17 | 485d | start no earlier than 2009-07-17 |  | 60h |
| 45 | 1.3.2.2.2.16 | Team Meeting #16 (UC) |  | 3d? | 2009-08-18 | 2009-08-20 | 461d | finish no earlier than 2009-08-20 |  | 240h |
| 46 | 1.3.2.2.2.17 | Team Meeting #17 (telecon) |  | 1d? | 2009-09-18 | 2009-09-18 | 440d | start no earlier than 2009-09-18 |  | 60h |
| 47 | 1.3.2.2.3 | **Director Telecons** |  | 325d | 2008-05-09 | 2009-08-07 | 471d |  |  |  |
| 48 | 1.3.2.2.3.1 | Director Telecon #1 | milestone | 0d | 2008-05-09 | 2008-05-09 | 796d | start no earlier than 2008-05-09 |  |  |
| 49 | 1.3.2.2.3.2 | Director Telecon #2 | milestone | 0d | 2008-10-03 | 2008-10-03 | 691d | start no earlier than 2008-10-03 |  |  |
| 50 | 1.3.2.2.3.3 | Director Telecon #3 | milestone | 0d | 2009-03-06 | 2009-03-06 | 581d | start no earlier than 2009-03-06 |  |  |
| 51 | 1.3.2.2.3.4 | Director Telecon #4 | milestone | 0d | 2009-08-07 | 2009-08-07 | 471d | start no earlier than 2009-08-07 |  |  |

Notes:
- 25: PW
- 26: PW
- 29: PW

| ID | WBS | Task | Type | Duration | Start | Finish | Total slack | Constraint | Resources | Work |
| --- | --- | --- | --- | --- | --- | --- | --- | --- | --- | --- |
| 52 | 1.3.2.3 | **Tracking & Reporting** |  | 413d? | 2008-04-30 | 2009-11-27 | 390d |  |  | 1004h |
| 53 | 1.3.2.3.1 | **Monthly Status Reports** |  | 412d? | 2008-05-01 | 2009-11-27 | 390d |  |  | 522h |
| 54 | 1.3.2.3.1.1 | Monthly Team Status Reports |  | 362d? | 2008-05-01 | 2009-09-18 | 440d | finish no earlier than 2009-09-18 | Other [6.9%]; Wizinowich; Max; Gavel; Dekany | 340h |
| 55 | 1.3.2.3.1.2 | Monthly Project Reports (TSIP, Directors) |  | 235.66d? | 2008-05-15 | 2009-04-09 | 556.34d | start no earlier than 2008-05-15 | Wizinowich [4.5%]; Dekany; Gavel; Adkins; Max | 152h |
| 56 | 1.3.2.3.1.3 | TSIP Project Report Telecons |  | 399d? | 2008-05-20 | 2009-11-27 | 390d | start no earlier than 2008-05-20 | Adkins [0.5%]; Wizinowich [0.5%] | 30h |
| 57 | 1.3.2.3.2 | **SSC Meetings** |  | 397d | 2008-04-30 | 2009-11-05 | 406d |  |  | 162h |
| 58 | 1.3.2.3.2.1 | SSC Meeting (CIT) - SDR report | milestone | 0d | 2008-04-30 | 2008-04-30 | 803d | start no earlier than 2008-04-30 |  |  |
| 59 | 1.3.2.3.2.2 | SSC Meeting (Keck) |  | 1.12d | 2008-06-18 | 2008-06-19 | 766.88d | start no earlier than 2008-06-18 | Dekany; Gavel; Max; Wizinowich | 18h |
| 60 | 1.3.2.3.2.3 | SSC Meeting (UCSC) |  | 1.12d | 2008-11-03 | 2008-11-04 | 668.88d | start no earlier than 2008-11-03 | Dekany; Gavel; Max; Wizinowich | 18h |
| 61 | 1.3.2.3.2.4 | SSC Meeting (Keck) |  | 1.12d | 2009-02-19 | 2009-02-20 | 590.88d | start no earlier than 2009-02-19 | Dekany; Gavel; Max; Wizinowich | 18h |
| 62 | 1.3.2.3.2.5 | SSC Meeting (CIT) |  | 1.12d | 2009-04-29 | 2009-04-30 | 541.88d | start no earlier than 2009-04-29 | Dekany; Gavel; Max; Wizinowich | 18h |
| 63 | 1.3.2.3.2.6 | SSC Meeting (Keck) |  | 1.12d | 2009-06-17 | 2009-06-18 | 506.88d | start no earlier than 2009-06-17 | Dekany; Gavel; Max; Wizinowich | 18h |
| 64 | 1.3.2.3.2.7 | SSC Meeting (UCSC) |  | 3d | 2009-11-03 | 2009-11-05 | 406d | start no earlier than 2009-11-03 | Dekany; Gavel; Max; Wizinowich | 72h |
| 65 | 1.3.2.3.3 | **Other Presentations** |  | 350d? | 2008-06-02 | 2009-10-02 | 430d |  |  | 320h |
| 66 | 1.3.2.3.3.1 | SPIE AO Conference Presentations/Papers |  | 15d? | 2008-06-02 | 2008-06-20 | 765d | start no earlier than 2008-06-02 | Dekany [33.3%]; Gavel [33.3%]; Max [33.3%]; Wizinowich [33.3%] | 160h |
| 67 | 1.3.2.3.3.2 | SPIE AO Conference (Marseille) |  | 5d? | 2008-06-23 | 2008-06-28 | 760d | finish no earlier than 2008-06-28 |  |  |
| 68 | 1.3.2.3.3.3 | Keck Science Meeting 08 |  | 3d | 2008-09-18 | 2008-09-22 | 699d | start no earlier than 2008-09-18 | Dekany; Gavel; Max; Wizinowich | 80h |
| 69 | 1.3.2.3.3.4 | Keck Science Meeting 09 |  | 3d | 2009-09-17 | 2009-09-21 | 439d | start no earlier than 2009-09-17 | Dekany; Gavel; Max; Wizinowich | 80h |
| 70 | 1.3.2.3.3.5 | Other |  | 195d? | 2009-01-05 | 2009-10-02 | 430d | finish no earlier than 2009-10-02 |  |  |
| 71 | 1.3.2.4 | **Proposals** |  | 348d? | 2008-06-02 | 2009-09-30 | 432d |  |  | 480h |
| 72 | 1.3.2.4.1 | Advancement Support |  | 348d? | 2008-06-02 | 2009-09-30 | 432d | start no earlier than 2008-06-02 | Free [2.9%] | 80h |
| 73 | 1.3.2.4.2 | TSIP Proposal for DDR |  | 25d? | 2009-07-28 | 2009-08-31 | 454d | finish no earlier than 2009-08-31 | Dekany [10%]; Gavel [10%]; Max [10%]; Free [90%] | 240h |
| 74 | 1.3.2.4.3 | Other Proposal |  | 20d? | 2009-09-03 | 2009-09-30 | 432d | finish no earlier than 2009-09-30 | Free | 160h |
| 75 | 1.3.2.5 | **Programmatic Risk Assessment & Mitigation** |  | 326d? | 2008-04-01 | 2009-06-30 | 498d |  |  | 180h |
| 76 | 1.3.2.5.1 | **Risk Assessment** |  | 326d? | 2008-04-01 | 2009-06-30 | 498d |  |  | 60h |
| 77 | 1.3.2.5.1.1 | Programmatic Risk Assessment v1 |  | 2d? | 2008-04-01 | 2008-04-02 | 822d |  | Wizinowich; Dekany; Gavel; Adkins; Other | 32h |
| 78 | 1.3.2.5.1.2 | Programmatic Risk Assessment v2 |  | 2d? | 2009-06-29 | 2009-06-30 | 498d | finish no earlier than 2009-06-30 | Wizinowich; Dekany; Gavel; Adkins | 28h |

Notes:
- 52: PW
- 71: PW
- 75: PW
- 76: PW

| ID | WBS | Task | Type | Duration | Start | Finish | Total slack | Constraint | Resources | Work |
| --- | --- | --- | --- | --- | --- | --- | --- | --- | --- | --- |
| 79 | 1.3.2.5.2 | **Risk Mitigation** |  | 139.33d? | 2008-04-01 | 2008-10-13 | 684.67d |  |  | 120h |
| 80 | 1.3.2.5.2.1 | Laser Procurement |  | 8.33d? | 2008-10-01 | 2008-10-13 | 684.67d | start no earlier than 2008-10-01 | Wizinowich [60%] | 40h |
| 81 | 1.3.2.5.2.2 | Science Instruments |  | 8.33d? | 2008-04-01 | 2008-04-11 | 815.67d |  | Wizinowich [60%] | 40h |
| 82 | 1.3.2.5.2.3 | Funding |  | 1d? | 2008-04-01 | 2008-04-01 | 823d |  | Wizinowich [500%] | 40h |
| 83 | 1.3.2.6 | **Preliminary Design Review** |  | 427d? | 2008-04-01 | 2009-11-18 | 397d |  |  | 518h |
| 84 | 1.3.2.6.1 | Define Success Criteria for all Reviews |  | 8.33d? | 2008-04-01 | 2008-04-11 | 815.67d |  | Wizinowich [60%]; Dekany [50%]; Gavel [50%]; Max [40%] | 60h |
| 85 | 1.3.2.6.2 | Review Setup (Date, Participants, Charter) |  | 5d? | 2009-05-04 | 2009-05-08 | 535d | start no earlier than 2009-05-04 | Wizinowich [20%]; Max [20%]; Other | 16h |
| 86 | 1.3.2.6.3 | Preliminary Design Report |  | 7.5d? | 2009-09-15 | 2009-09-24 | 436d | finish no earlier than 2009-09-24 | Wizinowich [83.3%]; Dekany [83.3%]; Gavel [83.3%]; Max [83.3%]; Other | 100h |
| 87 | 1.3.2.6.4 | Review Package Distributed |  | 1d? | 2009-09-25 | 2009-09-25 | 435d | start no earlier than 2009-09-25 | Wizinowich [75%] | 6h |
| 88 | 1.3.2.6.5 | Reviewer Comments Received | milestone | 0d | 2009-10-09 | 2009-10-09 | 426d | start no earlier than 2009-10-09 |  |  |
| 89 | 1.3.2.6.6 | Reviewer Comments Addressed |  | 7.5d? | 2009-10-12 | 2009-10-21 | 417.5d | start no earlier than 2009-10-11 | Wizinowich [40%]; Dekany [40%]; Gavel [40%]; Max [40%]; Other [40%] | 80h |
| 90 | 1.3.2.6.7 | PDR Presentation Preparation |  | 15d? | 2009-09-28 | 2009-10-16 | 420d | finish no earlier than 2009-10-16 | Wizinowich [16.7%]; Dekany [10%]; Gavel [10%]; Max [10%]; Other [20%] | 80h |
| 91 | 1.3.2.6.8 | Preliminary Design Review |  | 0.12d? | 2009-10-21 | 2009-10-21 | 417.88d | start no earlier than 2009-10-21 | Wizinowich [1250%]; Dekany [1250%]; Max [1250%]; Other [8333.3%]; Gavel [1250%] | 128h |
| 92 | 1.3.2.6.9 | Reviewer Report Received | milestone | 0d | 2009-11-11 | 2009-11-11 | 403d | start no earlier than 2009-11-11 |  |  |
| 93 | 1.3.2.6.10 | Response to Reviewer Report |  | 5d? | 2009-11-12 | 2009-11-18 | 397d | start no earlier than 2009-11-12 | Wizinowich [40%]; Dekany [20%]; Gavel [20%]; Max [20%]; Other [20%] | 48h |
| 94 | 1.3.2.7 | **Management Support** |  | 414d? | 2008-04-01 | 2009-10-30 | 410d |  |  | 2655h |
| 95 | 1.3.2.7.1 | Administrative Support |  | 392d? | 2008-05-01 | 2009-10-30 | 410d | start no earlier than 2008-05-01 | Tyau [21.5%]; Other; Wizinowich [60%] | 765h |
| 96 | 1.3.2.7.2 | Shared Infrastructure |  | 16.88d? | 2008-04-01 | 2008-04-23 | 807.12d |  | Chock | 135h |
| 97 | 1.3.2.7.3 | Research Time |  | 392d? | 2008-05-01 | 2009-10-30 | 410d | start no earlier than 2008-05-01 | McGrath [43%]; Le Mignant [15.5%] | 1755h |
| 98 | 1.3.3 | **Systems Engineering** |  | 414d? | 2008-04-01 | 2009-10-30 | 410d |  |  | 9796h |
| 99 | 1.3.3.1 | **Science Case Development** |  | 45d? | 2008-04-01 | 2008-06-02 | 779d |  |  | 4220h |
| 100 | 1.3.3.1.1 | **Science Case Requirements** |  | 45d? | 2008-04-01 | 2008-06-02 | 779d |  |  | 2822h |
| 101 | 1.3.3.1.1.1 | **Requirements for new Science Drivers** |  | 44d? | 2008-04-01 | 2008-05-30 | 780d |  |  | 440h |
| 102 | 1.3.3.1.1.1.1 | Astrometry Science in Sparse Fields |  | 22d? | 2008-04-01 | 2008-05-30 | 780d |  | McGrath [22.7%]; Student [45.5%]; Max [11.4%] | 140h |
| 103 | 1.3.3.1.1.1.2 | Resolved Stellar Populations in Crowded Fields |  | 15d? | 2008-04-01 | 2008-04-21 | 809d |  | Student; Max [40%] | 160h |
| 104 | 1.3.3.1.1.1.3 | Debris Disks & Young Stellar Objects |  | 12.5d? | 2008-04-01 | 2008-04-17 | 811.5d |  | McGrath; Max [40%] | 80h |
| 105 | 1.3.3.1.1.1.4 | QSO Host Galaxies |  | 6.25d? | 2008-04-01 | 2008-04-09 | 817.75d |  | McGrath; Max [40%] | 60h |

Notes:
- 79: PW
- 83: PW
- 94: PW
- 99: CM

| ID | WBS | Task | Duration | Start | Finish | Total slack | Resources | Work |
| --- | --- | --- | --- | --- | --- | --- | --- | --- |
| 106 | 1.3.3.1.1.2 | **Extend SCRD Discussion of Science Drivers** | 12.5d? | 2008-04-01 | 2008-04-17 | 811.5d |  | 626h |
| 107 | 1.3.3.1.1.2.1 | Nearby AGNs | 3.12d? | 2008-04-01 | 2008-04-04 | 820.88d | McGrath; Max [40%] | 30h |
| 108 | 1.3.3.1.1.2.2 | Gravitational Lensing | 5d? | 2008-04-01 | 2008-04-07 | 819d | McGrath; Max [40%] | 44h |
| 109 | 1.3.3.1.1.2.3 | Backup Science | 2.5d? | 2008-04-01 | 2008-04-03 | 821.5d | McGrath; Max; Le Mignant | 44h |
| 110 | 1.3.3.1.1.2.4 | Ice Giant Planets | 1.25d? | 2008-04-01 | 2008-04-02 | 822.75d | McGrath | 10h |
| 111 | 1.3.3.1.1.2.5 | GR at Galactic Center | 12.5d? | 2008-04-01 | 2008-04-17 | 811.5d | Student; Max [40%] | 120h |
| 112 | 1.3.3.1.1.2.6 | Extrasolar Planets | 10d? | 2008-04-01 | 2008-04-14 | 814d | McGrath; Scientist; Max [40%] | 140h |
| 113 | 1.3.3.1.1.2.7 | Asteroids | 5d? | 2008-04-01 | 2008-04-07 | 819d | Student; Le Mignant; Max [40%] | 68h |
| 114 | 1.3.3.1.1.2.8 | QSO Host Galaxies | 7.5d? | 2008-04-01 | 2008-04-10 | 816.5d | McGrath; Max [40%] | 80h |
| 115 | 1.3.3.1.1.2.9 | Backup Science - NGS & Acquisition Camera | 6.25d? | 2008-04-01 | 2008-04-09 | 817.75d | McGrath; Le Mignant; Neyman [40%]; Max [40%] | 90h |
| 116 | 1.3.3.1.1.3 | **Characterize PSF Stability, Knowledge & Subtraction Requirements** | 45d? | 2008-04-01 | 2008-06-02 | 779d |  | 1436h |
| 117 | 1.3.3.1.1.3.1 | Nearby AGNs | 45d? | 2008-04-01 | 2008-06-02 | 779d | McGrath; Student; Max | 600h |
| 118 | 1.3.3.1.1.3.2 | Galactic Center Astrometry | 20d? | 2008-04-01 | 2008-04-28 | 804d | Student; Max | 206h |
| 119 | 1.3.3.1.1.3.3 | Extrasolar Planets | 15d? | 2008-04-01 | 2008-04-21 | 809d | McGrath; Student; Scientist; Max [40%] | 260h |
| 120 | 1.3.3.1.1.3.4 | Minor Planet Multiplicity | 10d? | 2008-04-01 | 2008-04-14 | 814d | Student; Scientist; Max [40%] | 130h |
| 121 | 1.3.3.1.1.3.5 | QSO Host Galaxies | 15d? | 2008-04-01 | 2008-04-21 | 809d | McGrath; Student; Max | 240h |
| 122 | 1.3.3.1.1.4 | Characterize Sensitivity & Background Requirements | 15d? | 2008-04-01 | 2008-04-21 | 809d | McGrath; Max | 160h |
| 123 | 1.3.3.1.1.5 | Science Requirements Summary Matrix | 10d? | 2008-04-01 | 2008-04-14 | 814d | McGrath; Max | 100h |
| 124 | 1.3.3.1.1.6 | SEMP Input | 5d? | 2008-04-01 | 2008-04-07 | 819d | McGrath; Max | 60h |
| 125 | 1.3.3.1.2 | **Science Observing Planning & Execution** | 12.5d? | 2008-04-01 | 2008-04-17 | 811.5d |  | 500h |
| 126 | 1.3.3.1.2.1 | Key Science Driver Observing Scenarios | 10d? | 2008-04-01 | 2008-04-14 | 814d | McGrath; LeMignant; Max | 240h |
| 127 | 1.3.3.1.2.2 | Design Reference Missions | 12.5d? | 2008-04-01 | 2008-04-17 | 811.5d | McGrath; LeMignant; Max | 260h |
| 128 | 1.3.3.1.3 | **Science Performance Input** | 10d? | 2008-04-01 | 2008-04-14 | 814d |  | 190h |
| 129 | 1.3.3.1.3.1 | Define Science Driver Parameters for Performance Budgets | 2.5d? | 2008-04-01 | 2008-04-03 | 821.5d | McGrath; Max | 30h |
| 130 | 1.3.3.1.3.2 | Input to User Interfaces, Planning & Observing Tools | 10d? | 2008-04-01 | 2008-04-14 | 814d | McGrath | 80h |
| 131 | 1.3.3.1.3.3 | Input to Preliminary Operations Concept Document | 5d? | 2008-04-01 | 2008-04-07 | 819d | McGrath; Max | 80h |

| ID | WBS | Task | Duration | Start | Finish | Total slack | Resources | Work |
| --- | --- | --- | --- | --- | --- | --- | --- | --- |
| 132 | 1.3.3.1.4 | **Science Competitiveness** | 5.5d? | 2008-04-01 | 2008-04-08 | 818.5d |  | 188h |
| 133 | 1.3.3.1.4.1 | Update List of Science Goals for Other Facilities | 5.5d? | 2008-04-01 | 2008-04-08 | 818.5d | McGrath; Max | 88h |
| 134 | 1.3.3.1.4.2 | Evaluate NGAO Potential to Compliment Other Facilities | 5d? | 2008-04-01 | 2008-04-07 | 819d | McGrath; Max [40%] | 50h |
| 135 | 1.3.3.1.4.3 | Define NGAO Uniqueness Space | 3.75d? | 2008-04-01 | 2008-04-04 | 820.25d | McGrath; Max | 50h |
| 136 | 1.3.3.1.5 | **User Community Liaison** | 28.12d? | 2008-04-01 | 2008-05-09 | 795.88d |  | 240h |
| 137 | 1.3.3.1.5.1 | Enlist People to work on new NGAO Science Aspects | 12.5d? | 2008-04-01 | 2008-04-17 | 811.5d | Max [40%]; McGrath | 60h |
| 138 | 1.3.3.1.5.2 | **SSC & Keck Science Meeting** | 28.12d? | 2008-04-01 | 2008-05-09 | 795.88d |  | 180h |
| 139 | 1.3.3.1.5.2.1 | Prepare & Give Presentations | 28.12d? | 2008-04-01 | 2008-05-09 | 795.88d | Max [40%]; McGrath | 130h |
| 140 | 1.3.3.1.5.2.2 | Obtain & Document Feedback | 5d? | 2008-04-01 | 2008-04-07 | 819d | Max; McGrath | 50h |
| 141 | 1.3.3.1.6 | **Science Advisory Team Meetings** | 25d? | 2008-04-01 | 2008-05-05 | 799d |  | 280h |
| 142 | 1.3.3.1.6.1 | Prepare Minutes, Presentations & KAONs | 25d? | 2008-04-01 | 2008-05-05 | 799d | Max [40%]; McGrath; Le Mignant | 180h |
| 143 | 1.3.3.1.6.2 | Refine Science Requirements | 2.5d? | 2008-04-01 | 2008-04-03 | 821.5d | Le Mignant | 20h |
| 144 | 1.3.3.1.6.3 | Evaluate Science Impact of Proposed Changes | 12.5d? | 2008-04-01 | 2008-04-17 | 811.5d | Max [40%]; McGrath | 80h |
| 145 | 1.3.3.2 | **Requirements** | 20d? | 2008-04-01 | 2008-04-28 | 804d |  | 970h |
| 146 | 1.3.3.2.1 | **Operations Concept Document (OCD)** | 20d? | 2008-04-01 | 2008-04-28 | 804d |  | 480h |
| 147 | 1.3.3.2.1.1 | OCD Outline | 1.67d? | 2008-04-01 | 2008-04-02 | 822.33d | Le Mignant [500%]; Wizinowich [60%] | 40h |
| 148 | 1.3.3.2.1.2 | OCD Release 1 | 15d? | 2008-04-01 | 2008-04-21 | 809d | Le Mignant; Other | 200h |
| 149 | 1.3.3.2.1.3 | OCD Release 2 | 20d? | 2008-04-01 | 2008-04-28 | 804d | Le Mignant; Other | 240h |
| 150 | 1.3.3.2.2 | **System Requirements (SRD)** | 6.25d? | 2008-04-01 | 2008-04-09 | 817.75d |  | 80h |
| 151 | 1.3.3.2.2.1 | SRD Release I | 6.25d? | 2008-04-01 | 2008-04-09 | 817.75d | Johansson | 50h |
| 152 | 1.3.3.2.2.2 | SRD Release 2 | 3.75d? | 2008-04-01 | 2008-04-04 | 820.25d | Johansson | 30h |
| 153 | 1.3.3.2.3 | **Functional Requirements (FRD)** | 15d? | 2008-04-01 | 2008-04-21 | 809d |  | 250h |
| 154 | 1.3.3.2.3.1 | FRD Release 1 | 15d? | 2008-04-01 | 2008-04-21 | 809d | Johansson; Dekany [50%]; Wizinowich [60%] | 120h |
| 155 | 1.3.3.2.3.2 | FRD Release 2 | 6.25d? | 2008-04-01 | 2008-04-09 | 817.75d | Johansson; Dekany [50%] | 70h |
| 156 | 1.3.3.2.3.3 | Compliance Matrix | 7.5d? | 2008-04-01 | 2008-04-10 | 816.5d | Johansson | 60h |
| 157 | 1.3.3.2.4 | Software Standards (Define & Document) | 10d? | 2008-04-01 | 2008-04-14 | 814d | Johansson | 80h |
| 158 | 1.3.3.2.5 | Component Standards (Define & Document) | 10d? | 2008-04-01 | 2008-04-14 | 814d | Johansson | 80h |

Notes:
- 145: EJ
- 146: DLM
- 147: DLM
- 148: DLM
- 149: DLM
- 150: EJ
- 151: EJ
- 152: EJ
- 153: EJ
- 154: EJ
- 155: EJ
- 156: EJ
- 157: EJ
- 158: EJ

| ID | WBS | Task | Duration | Start | Finish | Total slack | Free slack | Constraint | Resources | Work |
| --- | --- | --- | --- | --- | --- | --- | --- | --- | --- | --- |
| 159 | 1.3.3.3 | **Systems Engineering Analysis** | 348d? | 2008-04-01 | 2009-07-30 | 476d |  |  |  | 2532h |
| 160 | 1.3.3.3.1 | **Performance Budgets** | 348d? | 2008-04-01 | 2009-07-30 | 476d |  |  |  | 1092h |
| 161 | 1.3.3.3.1.1 | Requirements Flowdown Report | 15d? | 2008-04-01 | 2008-04-21 | 809d |  |  | Dekany [50%] | 60h |
| 162 | 1.3.3.3.1.2 | **Throughput & Background Budget** | 6.25d? | 2008-04-01 | 2008-04-09 | 817.75d |  |  |  | 80h |
| 163 | 1.3.3.3.1.2.1 | Thermal Background Analysis Software with Documentation | 6.25d? | 2008-04-01 | 2008-04-09 | 817.75d |  |  | Bouchez | 50h |
| 164 | 1.3.3.3.1.2.2 | Thermal Analysis | 3.75d? | 2008-04-01 | 2008-04-04 | 820.25d |  |  | Bouchez | 30h |
| 165 | 1.3.3.3.1.3 | **Wavefront & Encircled Energy** | 20d? | 2008-04-01 | 2008-04-28 | 804d |  |  |  | 312h |
| 166 | 1.3.3.3.1.3.1 | **WFE/EE Budget Tool** | 20d? | 2008-04-01 | 2008-04-28 | 804d |  |  |  | 240h |
| 167 | 1.3.3.3.1.3.1.1 | NGS TT & TTFA Sharpening Budgets | 20d? | 2008-04-01 | 2008-04-28 | 804d |  |  | Dekany [50%] | 80h |
| 168 | 1.3.3.3.1.3.1.2 | Improved Bandwidth Model | 20d? | 2008-04-01 | 2008-04-28 | 804d |  |  | Dekany [50%] | 80h |
| 169 | 1.3.3.3.1.3.1.3 | Improved Atmospheric Dispersion Model | 5d? | 2008-04-01 | 2008-04-07 | 819d |  |  | Neyman | 40h |
| 170 | 1.3.3.3.1.3.1.4 | Other | 10d? | 2008-04-01 | 2008-04-14 | 814d |  |  | Dekany [50%] | 40h |
| 171 | 1.3.3.3.1.3.2 | **WFE/EE Performance Analysis** | 6d? | 2008-04-01 | 2008-04-08 | 818d |  |  |  | 72h |
| 172 | 1.3.3.3.1.3.2.1 | Key Science Cases Analysis | 6d? | 2008-04-01 | 2008-04-08 | 818d |  |  | Dekany [50%] | 24h |
| 173 | 1.3.3.3.1.3.2.2 | Additional Science Case Analysis | 1d? | 2008-04-01 | 2008-04-01 | 823d |  |  | Dekany [600%] | 48h |
| 174 | 1.3.3.3.1.4 | **Astrometric Precision** | 40d? | 2008-04-01 | 2008-05-26 | 784d | 0d |  |  | 480h |
| 175 | 1.3.3.3.1.4.1 | Develop Astrometric Budget Tool | 20d? | 2008-04-01 | 2008-04-28 | 804d |  |  | Dekany [50%]; Wizinowich [60%] | 160h |
| 176 | 1.3.3.3.1.4.2 | Galactic Center Astrometric Analysis | 40d? | 2008-04-01 | 2008-05-26 | 784d |  |  | Dekany [50%]; Neyman | 320h |
| 177 | 1.3.3.3.1.5 | **Observing Efficiency** | 266d? | 2008-06-24 | 2009-06-30 | 498d |  |  |  | 80h |
| 178 | 1.3.3.3.1.5.1 | Observing Efficiency Tool | 5d? | 2008-06-24 | 2008-06-30 | 759d |  | finish no earlier than 2008-06-30 | Le Mignant | 40h |
| 179 | 1.3.3.3.1.5.2 | Observing Efficiency Analysis | 5d? | 2009-06-24 | 2009-06-30 | 498d |  | finish no earlier than 2009-06-30 | Le Mignant | 40h |
| 180 | 1.3.3.3.1.6 | **Observing Uptime** | 266d? | 2008-07-24 | 2009-07-30 | 476d |  |  |  | 80h |
| 181 | 1.3.3.3.1.6.1 | Observing Uptime Tool | 5d? | 2008-07-24 | 2008-07-30 | 737d |  | finish no earlier than 2008-07-30 | Johansson | 40h |
| 182 | 1.3.3.3.1.6.2 | Observing Uptime Analysis | 5d? | 2009-07-24 | 2009-07-30 | 476d |  | finish no earlier than 2009-07-30 | Johansson | 40h |

Notes:
- 160: RD

| ID | WBS | Task | Duration | Start | Finish | Predecessors | Total slack | Free slack | Constraint | Resources | Work |
| --- | --- | --- | --- | --- | --- | --- | --- | --- | --- | --- | --- |
| 183 | 1.3.3.3.2 | **Modeling & Analysis** | 30d? | 2008-04-01 | 2008-05-12 |  | 794d |  |  |  | 960h |
| 184 | 1.3.3.3.2.1 | Performance vs T/T NGS Report | 30d? | 2008-04-01 | 2008-05-12 |  | 794d |  |  | Dekany [50%]; Neyman | 240h |
| 185 | 1.3.3.3.2.2 | Galactic Center Performance Report | 30d? | 2008-04-01 | 2008-05-12 |  | 794d |  |  | Dekany [50%]; Neyman | 240h |
| 186 | 1.3.3.3.2.3 | T/T Sharpening Study Report | 30d? | 2008-04-01 | 2008-05-12 |  | 794d |  |  | Dekany [50%]; Neyman | 320h |
| 187 | 1.3.3.3.2.4 | PSF Libraries | 20d? | 2008-04-01 | 2008-04-28 |  | 804d |  |  | Neyman | 160h |
| 188 | 1.3.3.3.3 | PSF Calibration | 30d? | 2008-04-01 | 2008-05-12 |  | 794d |  |  | Le Mignant; Neyman | 480h |
| 189 | 1.3.3.4 | **System Architecture** | 392d? | 2008-04-01 | 2009-09-30 |  | 432d |  |  |  | 1056h |
| 190 | 1.3.3.4.1 | **System Hardware Architecture** | 392d? | 2008-04-01 | 2009-09-30 |  | 432d |  |  |  | 264h |
| 191 | 1.3.3.4.1.1 | Hybrid Rayleigh / Sodium Trade Study | 20d? | 2008-04-01 | 2008-04-28 |  | 804d |  |  | Dekany [50%]; Neyman | 160h |
| 192 | 1.3.3.4.1.2 | Degraded Laser Power Trade Study | 5d? | 2008-04-01 | 2008-04-07 |  | 819d |  |  | Neyman | 40h |
| 193 | 1.3.3.4.1.3 | System Architecture: Evaluate & Document Changes | 16d? | 2009-09-09 | 2009-09-30 |  | 432d |  | finish no earlier than 2009-09-30 | Dekany [50%] | 64h |
| 194 | 1.3.3.4.2 | **Motion Control / Electronics Architecture** | 261d? | 2008-10-01 | 2009-09-30 |  | 432d |  |  |  |  |
| 195 | 1.3.3.4.2.1 | Evaluate MC/Electronics Arch Options | 33d? | 2008-10-01 | 2008-11-14 |  | 624d | 0d | finish no earlier than 2008-11-14 |  |  |
| 196 | 1.3.3.4.2.2 | Determine/Document MC/Electronics Arch | 36d? | 2008-11-17 | 2009-01-05 | 195 | 624d |  | start no earlier than 2008-11-17 |  |  |
| 197 | 1.3.3.4.2.3 | MC/Electronics Architecture Design Support | 228d? | 2008-11-17 | 2009-09-30 |  | 432d |  | finish no earlier than 2009-09-30 |  |  |
| 198 | 1.3.3.4.3 | **Software Architecture** | 308d? | 2008-07-28 | 2009-09-30 |  | 432d |  |  |  | 424h |
| 199 | 1.3.3.4.3.1 | Evaluate Software Architecture Options | 15d? | 2008-07-28 | 2008-08-15 |  | 700d | 0d | finish no earlier than 2008-08-15 | Johansson; Other | 160h |
| 200 | 1.3.3.4.3.2 | Determine/Document Software Arch Approach | 25d? | 2008-08-18 | 2008-09-19 | 199 | 700d |  | start no earlier than 2008-08-18 | Johansson | 200h |
| 201 | 1.3.3.4.3.3 | Software Architecture: Evaluate & Document Changes | 8d? | 2009-09-21 | 2009-09-30 |  | 432d |  | finish no earlier than 2009-09-30 | Johansson | 64h |
| 202 | 1.3.3.4.4 | **Operations Sequences Architecture** | 18d? | 2008-04-01 | 2008-04-24 |  | 806d |  |  |  | 368h |
| 203 | 1.3.3.4.4.1 | Define Required System Level Sequences | 10d? | 2008-04-01 | 2008-04-14 |  | 814d |  |  | Le Mignant | 80h |
| 204 | 1.3.3.4.4.2 | Develop System Level Sequences Approach | 18d? | 2008-04-01 | 2008-04-24 |  | 806d |  |  | Le Mignant | 144h |
| 205 | 1.3.3.4.4.3 | Sequences Definition Document | 10d? | 2008-04-01 | 2008-04-14 |  | 814d |  |  | Le Mignant | 80h |
| 206 | 1.3.3.4.4.4 | Sequences: Evaluate & Document Changes | 8d? | 2008-04-01 | 2008-04-10 |  | 816d |  |  | Le Mignant | 64h |

Notes:
- 188: DLM
- 198: EJ
- 202: DLM

| ID | WBS | Task | Duration | Start | Finish | Total slack | Constraint | Resources | Work |
| --- | --- | --- | --- | --- | --- | --- | --- | --- | --- |
| 207 | 1.3.3.5 | **External Interface Control** | 86d? | 2008-04-01 | 2008-07-29 | 738d |  |  | 244h |
| 208 | 1.3.3.5.1 | **Observatory Interfaces** | 22d? | 2008-04-01 | 2008-04-30 | 802d |  |  | 120h |
| 209 | 1.3.3.5.1.1 | AO System ICD | 22d? | 2008-04-01 | 2008-04-30 | 802d |  | Other [22.7%] | 40h |
| 210 | 1.3.3.5.1.2 | Laser System ICD | 22d? | 2008-04-01 | 2008-04-30 | 802d |  | Chin [5.7%]; Neyman [11.4%]; Adkins [5.7%] | 40h |
| 211 | 1.3.3.5.1.3 | Science Tools ICD | 3.12d? | 2008-04-01 | 2008-04-04 | 820.88d |  | Le Mignant; Johansson | 40h |
| 212 | 1.3.3.5.2 | **Science Instrument Interfaces to NGAO** | 86d? | 2008-04-01 | 2008-07-29 | 738d |  |  | 124h |
| 213 | 1.3.3.5.2.1 | Generic Science Instrument ICD to AO | 86d? | 2008-04-01 | 2008-07-29 | 738d |  | Adkins [2.9%]; Other [2.9%] | 40h |
| 214 | 1.3.3.5.2.2 | Generic Science Instrument ICD to NGAO Science Tools | 1.88d? | 2008-04-01 | 2008-04-02 | 822.12d |  | Adkins; Le Mignant; Johansson | 40h |
| 215 | 1.3.3.5.2.3 | Interferometer Specific ICD | 22d? | 2008-04-01 | 2008-04-30 | 802d |  | Neyman [6.8%] | 12h |
| 216 | 1.3.3.5.2.4 | OSIRIS Specific ICD | 20d? | 2008-04-01 | 2008-04-28 | 804d |  | Adkins [2.5%]; Kupke [1.2%]; Bell [1.2%] | 8h |
| 217 | 1.3.3.5.2.5 | NIR Camera Specific ICD | 22d? | 2008-04-01 | 2008-04-30 | 802d |  | Adkins [1.1%]; Kupke [0.6%]; Lockwood [0.6%] | 4h |
| 218 | 1.3.3.5.2.6 | Visible Camera Specific ICD | 21d? | 2008-04-01 | 2008-04-29 | 803d |  | Adkins [1.2%]; Kupke [0.6%]; Lockwood [0.6%] | 4h |
| 219 | 1.3.3.5.2.7 | d-IFS Specific ICD | 22d? | 2008-04-01 | 2008-04-30 | 802d |  | Adkins [5.7%]; Wizinowich [2.3%]; Bell [1.1%] | 16h |
| 220 | 1.3.3.6 | **Internal Interface Control** | 33.25d? | 2008-04-01 | 2008-05-16 | 790.75d |  |  | 416h |
| 221 | 1.3.3.6.1 | Interface N-Squared Diagram | 18.75d? | 2008-04-01 | 2008-04-25 | 805.25d |  | Other | 150h |
| 222 | 1.3.3.6.2 | Interface Definition Document | 33.25d? | 2008-04-01 | 2008-05-16 | 790.75d |  | Other | 266h |
| 223 | 1.3.3.7 | **Configuration Control** | 27.25d? | 2008-04-01 | 2008-05-08 | 796.75d |  |  | 218h |
| 224 | 1.3.3.7.1 | Change Control Guidelines & Tools Definition | 27.25d? | 2008-04-01 | 2008-05-08 | 796.75d |  | Other | 218h |
| 225 | 1.3.3.8 | **Documentation Control** | 2.5d? | 2008-04-01 | 2008-04-03 | 821.5d |  |  | 20h |
| 226 | 1.3.3.8.1 | Document Control Guidelines & Tools Definition | 2.5d? | 2008-04-01 | 2008-04-03 | 821.5d |  | Other | 20h |
| 227 | 1.3.3.9 | **Technical Risk Assessment & Mitigation** | 414d? | 2008-04-01 | 2009-10-30 | 410d |  |  |  |
| 228 | 1.3.3.9.1 | **Risk Assessment** | 238d? | 2008-10-01 | 2009-08-28 | 455d |  |  |  |
| 229 | 1.3.3.9.1.1 | Risk Assessment v1 | 22d? | 2008-10-01 | 2008-10-30 | 671d | finish no earlier than 2008-10-30 |  |  |
| 230 | 1.3.3.9.1.2 | Risk Assessment v2 | 20d? | 2009-08-03 | 2009-08-28 | 455d | finish no earlier than 2009-08-28 |  |  |

| ID | WBS | Task | Type | Duration | Start | Finish | Predecessors | Total slack | Free slack | Constraint |
| --- | --- | --- | --- | --- | --- | --- | --- | --- | --- | --- |
| 231 | 1.3.3.9.2 | **Risk Mitigation Efforts** |  | 414d? | 2008-04-01 | 2009-10-30 |  | 410d |  |  |
| 232 | 1.3.3.9.2.1 | **PSF Calibration** |  | 392d? | 2008-05-01 | 2009-10-30 |  | 410d |  |  |
| 233 | 1.3.3.9.2.1.1 | Support/Monitor CfAO-funded Project |  | 392d? | 2008-05-01 | 2009-10-30 |  | 410d |  | finish no earlier than 2009-10-30 |
| 234 | 1.3.3.9.2.1.2 | **Implement Atmospheric Profiler** |  | 347d? | 2008-05-01 | 2009-08-28 |  | 455d |  |  |
| 235 | 1.3.3.9.2.1.2.1 | Define & Procure Profiler |  | 131d? | 2008-05-01 | 2008-10-30 |  | 524d | 46d | finish no earlier than 2008-10-30 |
| 236 | 1.3.3.9.2.1.2.2 | Implement Profiler |  | 61d? | 2009-01-05 | 2009-03-30 | 235 | 478d | 23d | finish no earlier than 2009-03-30 |
| 237 | 1.3.3.9.2.1.2.3 | Evaluate Profiler Results |  | 86d? | 2009-05-01 | 2009-08-28 | 236 | 455d |  | finish no earlier than 2009-08-28 |
| 238 | 1.3.3.9.2.2 | **Astrometry Performance** |  | 197d? | 2008-05-01 | 2009-01-30 |  | 605d |  |  |
| 239 | 1.3.3.9.2.2.1 | Support/Monitor UCLA/CIT Astrometry Results |  | 197d? | 2008-05-01 | 2009-01-30 |  | 605d |  | finish no earlier than 2009-01-30 |
| 240 | 1.3.3.9.2.2.2 | Develop Error Budget (1.3.2.4.3) | milestone | 0d | 2008-05-26 | 2008-05-26 | 174 | 784d |  |  |
| 241 | 1.3.3.9.2.3 | **Tomographic Reconstruction** |  | 304d? | 2008-07-01 | 2009-08-28 |  | 455d |  |  |
| 242 | 1.3.3.9.2.3.1 | Summarize On-sky Tomography Results |  | 85d? | 2009-02-02 | 2009-05-29 |  | 520d |  | finish no earlier than 2009-05-29 |
| 243 | 1.3.3.9.2.3.2 | Support/Monitor LAO Tomography Expts |  | 239d? | 2008-07-01 | 2009-05-29 |  | 520d |  | finish no earlier than 2009-05-29 |
| 244 | 1.3.3.9.2.3.3 | Test Single Laser Tomography at Keck |  | 86d? | 2009-05-01 | 2009-08-28 | 236 | 455d |  | finish no earlier than 2009-08-28 |
| 245 | 1.3.3.9.2.4 | **Sky Coverage** |  | 236d? | 2008-06-02 | 2009-04-27 |  | 544d |  |  |
| 246 | 1.3.3.9.2.4.1 | **Prototype NIR Tip/tilt Sensor** |  | 236d? | 2008-06-02 | 2009-04-27 |  | 544d |  |  |
| 247 | 1.3.3.9.2.4.1.1 | Define & Procure Components |  | 130d? | 2008-06-02 | 2008-11-28 |  | 544d | 0d | finish no earlier than 2008-11-28 |
| 248 | 1.3.3.9.2.4.1.2 | Assemble & Perform Lab Testing |  | 106d? | 2008-12-01 | 2009-04-27 | 247 | 544d |  | finish no earlier than 2009-03-30 |
| 249 | 1.3.3.9.2.5 | **Photometry Performance** |  | 0d | 2008-04-01 | 2008-04-01 |  | 824d |  |  |
| 250 | 1.3.3.9.2.5.1 | Develop Error Budget (1.3.2.4.4) | milestone | 0d | 2008-04-01 | 2008-04-01 |  | 824d |  |  |
| 251 | 1.3.3.9.2.6 | **Science Requirements** |  | 0d | 2008-04-01 | 2008-04-01 |  | 824d |  |  |
| 252 | 1.3.3.9.2.6.1 | Update Science Case Requirements | milestone | 0d | 2008-04-01 | 2008-04-01 |  | 824d |  |  |
| 253 | 1.3.3.9.2.7 | **Woofer DM Tip/tilt Performance** |  | 0d | 2008-04-01 | 2008-04-01 |  | 824d |  |  |
| 254 | 1.3.3.9.2.7.1 | Complete Woofer Tip/Tilt Design | milestone | 0d | 2008-04-01 | 2008-04-01 |  | 824d |  |  |

Notes:
- 235: RF
- 237: RF
- 252: CM

| ID | WBS | Task | Duration | Start | Finish | Total slack | Constraint | Resources | Work |
| --- | --- | --- | --- | --- | --- | --- | --- | --- | --- |
| 255 | 1.3.3.9.2.8 | **Wavefront Error Budget** | 53d? | 2009-01-15 | 2009-03-30 | 564d |  |  |  |
| 256 | 1.3.3.9.2.8.1 | Determine CCID-56 Status | 20d? | 2009-02-02 | 2009-02-27 | 585d | finish no earlier than 2009-02-27 |  |  |
| 257 | 1.3.3.9.2.8.2 | Tip/tilt Vibration Analysis | 53d? | 2009-01-15 | 2009-03-30 | 564d | finish no earlier than 2009-03-30 |  |  |
| 258 | 1.3.3.9.2.9 | Other Risk Mitigation | 105d? | 2009-02-02 | 2009-06-26 | 500d | finish no earlier than 2009-06-26 |  |  |
| 259 | 1.3.3.10 | Preliminary Design Manual | 16.67d? | 2009-08-20 | 2009-09-11 | 445d | finish no earlier than 2009-09-11 | Wizinowich [60%]; Dekany [50%]; Gavel [50%]; Other | 120h |
| 260 | 1.3.4 | **AO System Design** | 261d? | 2008-04-01 | 2009-03-31 | 563d |  |  | 9276h |
| 261 | 1.3.4.1 | AO Enclosure | 130d? | 2008-10-01 | 2009-03-31 | 563d | finish no earlier than 2009-03-31 | Bell [28.8%] | 300h |
| 262 | 1.3.4.2 | **Opto-Mechanical** | 260d? | 2008-04-01 | 2009-03-30 | 564d |  |  | 6601h |
| 263 | 1.3.4.2.1 | AO Support Structure | 20d? | 2008-11-03 | 2008-11-28 | 650d | start no earlier than 2008-11-03 | Lockwood | 160h |
| 264 | 1.3.4.2.2 | Rotator | 12.5d? | 2009-03-12 | 2009-03-30 | 564d | finish no earlier than 2009-03-30 | Lockwood; Kupke | 120h |
| 265 | 1.3.4.2.3 | Optical Relays | 40d? | 2008-12-08 | 2009-01-30 | 605d | finish no earlier than 2009-01-30 | Lockwood; Kupke | 533h |
| 266 | 1.3.4.2.4 | Optical Switchyard | 30d? | 2008-08-01 | 2008-09-11 | 706d | start no earlier than 2008-08-01 | Lockwood; Kupke | 400h |
| 267 | 1.3.4.2.5 | **LGS Wavefront Sensor Assembly** | 55d? | 2008-04-01 | 2008-06-16 | 769d |  |  | 2200h |
| 268 | 1.3.4.2.5.1 | Review/Update Conceptual Design | 10d? | 2008-04-01 | 2008-04-14 | 814d |  | Velur; Dekany [50%] | 120h |
| 269 | 1.3.4.2.5.2 | Acquisition & Dithering Requirements & Approach | 6.25d? | 2008-04-01 | 2008-04-09 | 817.75d |  | Velur; Other | 100h |
| 270 | 1.3.4.2.5.3 | LGS WFS Opto-Mechanical Design | 42.5d? | 2008-04-01 | 2008-05-29 | 781.5d |  | Velur; Other | 660h |
| 271 | 1.3.4.2.5.4 | Object Selection Opto-Mechanical Design | 5d? | 2008-04-01 | 2008-04-07 | 819d |  | Velur | 40h |
| 272 | 1.3.4.2.5.5 | Assembly Model | 12.5d? | 2008-04-01 | 2008-04-17 | 811.5d |  | Velur; Other | 200h |
| 273 | 1.3.4.2.5.6 | Throughput Model & Scattered Light Issues | 10d? | 2008-04-01 | 2008-04-14 | 814d |  | Velur | 80h |
| 274 | 1.3.4.2.5.7 | Motion Control Design | 10d? | 2008-04-01 | 2008-04-14 | 814d |  | Velur; Wetherell | 160h |
| 275 | 1.3.4.2.5.8 | Design Risks Evaluation | 10d? | 2008-04-01 | 2008-04-14 | 814d |  | Velur | 80h |
| 276 | 1.3.4.2.5.9 | Alignment, Integration & Test Plans | 55d? | 2008-04-01 | 2008-06-16 | 769d |  | Velur | 440h |
| 277 | 1.3.4.2.5.10 | Compliance Matrix | 20d? | 2008-04-01 | 2008-04-28 | 804d |  | Velur | 160h |
| 278 | 1.3.4.2.5.11 | Design Report | 20d? | 2008-04-01 | 2008-04-28 | 804d |  | Velur | 160h |

| ID | WBS | Task | Duration | Start | Finish | Total slack | Resources | Work |
| --- | --- | --- | --- | --- | --- | --- | --- | --- |
| 279 | 1.3.4.2.6 | **NGS WFS/TWFS Assembly** | 28d? | 2008-04-01 | 2008-05-08 | 796d |  | 936h |
| 280 | 1.3.4.2.6.1 | Review/Update Conceptual Design | 5d? | 2008-04-01 | 2008-04-07 | 819d | Other | 40h |
| 281 | 1.3.4.2.6.2 | Field Steering Compliance Check | 14d? | 2008-04-01 | 2008-04-18 | 810d | Other | 112h |
| 282 | 1.3.4.2.6.3 | NGS WFS/TWFS Opto-Mechanical Design | 28d? | 2008-04-01 | 2008-05-08 | 796d | Other | 224h |
| 283 | 1.3.4.2.6.4 | Assembly Model | 17.5d? | 2008-04-01 | 2008-04-24 | 806.5d | Other | 140h |
| 284 | 1.3.4.2.6.5 | Motion Control Design | 7d? | 2008-04-01 | 2008-04-09 | 817d | Other | 56h |
| 285 | 1.3.4.2.6.6 | Design Risks Evaluation | 3.5d? | 2008-04-01 | 2008-04-04 | 820.5d | Other | 28h |
| 286 | 1.3.4.2.6.7 | Alignment Plan | 28d? | 2008-04-01 | 2008-05-08 | 796d | Other | 224h |
| 287 | 1.3.4.2.6.8 | Compliance Matrix | 7d? | 2008-04-01 | 2008-04-09 | 817d | Other | 56h |
| 288 | 1.3.4.2.6.9 | Design Report | 7d? | 2008-04-01 | 2008-04-09 | 817d | Other | 56h |
| 289 | 1.3.4.2.7 | **Low Order Wavefront Sensor Assembly** | 50d? | 2008-04-01 | 2008-06-09 | 774d |  | 1932h |
| 290 | 1.3.4.2.7.1 | Review/Update Conceptual Design | 12.5d? | 2008-04-01 | 2008-04-17 | 811.5d | Other | 100h |
| 291 | 1.3.4.2.7.2 | Detector Evaluation & Selection | 2.5d? | 2008-04-01 | 2008-04-03 | 821.5d | Other | 20h |
| 292 | 1.3.4.2.7.3 | Dithering Requirements & Approach | 19d? | 2008-04-01 | 2008-04-25 | 805d | Other | 152h |
| 293 | 1.3.4.2.7.4 | LOWFS Opto-Mechanical Design | 50d? | 2008-04-01 | 2008-06-09 | 774d | Other | 400h |
| 294 | 1.3.4.2.7.5 | Object Selection Opto-Mechanical Design | 37.5d? | 2008-04-01 | 2008-05-22 | 786.5d | Other | 300h |
| 295 | 1.3.4.2.7.6 | Assembly Model | 20d? | 2008-04-01 | 2008-04-28 | 804d | Other | 160h |
| 296 | 1.3.4.2.7.7 | Thermal Model & Related Issues | 1d? | 2008-04-01 | 2008-04-01 | 823d | Other [500%] | 40h |
| 297 | 1.3.4.2.7.8 | Motion Control Design | 40d? | 2008-04-01 | 2008-05-26 | 784d | Other | 320h |
| 298 | 1.3.4.2.7.9 | Design Risks Evaluation | 10d? | 2008-04-01 | 2008-04-14 | 814d | Other | 80h |
| 299 | 1.3.4.2.7.10 | Alignment, Integration & Test Plans | 30d? | 2008-04-01 | 2008-05-12 | 794d | Other | 240h |
| 300 | 1.3.4.2.7.11 | Compliance Matrix | 5d? | 2008-04-01 | 2008-04-07 | 819d | Other | 40h |
| 301 | 1.3.4.2.7.12 | Design Report | 10d? | 2008-04-01 | 2008-04-14 | 814d | Other | 80h |
| 302 | 1.3.4.2.8 | **Tip/Tilt Vibration Mitigation** | 10d? | 2008-04-01 | 2008-04-14 | 814d |  | 80h |
| 303 | 1.3.4.2.8.1 | TT Vibration Mitigation Analysis | 10d? | 2008-04-01 | 2008-04-14 | 814d | Neyman | 80h |

| ID | WBS | Task | Duration | Start | Finish | Total slack | Constraint | Resources | Work |
| --- | --- | --- | --- | --- | --- | --- | --- | --- | --- |
| 304 | 1.3.4.2.9 | **Acquisition Cameras** | 110d? | 2008-09-01 | 2009-01-30 | 605d |  |  |  |
| 305 | 1.3.4.2.9.1 | NGS Acquisition Camera | 45d? | 2008-12-01 | 2009-01-30 | 605d | finish no earlier than 2009-01-30 |  |  |
| 306 | 1.3.4.2.9.2 | LGS Acquisition Camera | 65d? | 2008-09-01 | 2008-11-28 | 650d | finish no earlier than 2008-11-28 |  |  |
| 307 | 1.3.4.2.10 | **Atmospheric Dispersion Correctors** | 96d? | 2008-10-17 | 2009-02-27 | 585d |  |  | 240h |
| 308 | 1.3.4.2.10.1 | LOWFS ADCs | 10d? | 2008-10-17 | 2008-10-30 | 671d | finish no earlier than 2008-10-30 | Kupke; Lockwood [75%] | 140h |
| 309 | 1.3.4.2.10.2 | NIR Science ADC | 5d? | 2008-12-24 | 2008-12-30 | 628d | finish no earlier than 2008-12-30 | Kupke; Lockwood [25%] | 50h |
| 310 | 1.3.4.2.10.3 | Visible Science & NGS WFS ADC | 5d? | 2009-02-23 | 2009-02-27 | 585d | finish no earlier than 2009-02-27 | Kupke; Lockwood [25%] | 50h |
| 311 | 1.3.4.3 | **Alignment, Calibration & Diagnostics** | 8.33d? | 2008-04-01 | 2008-04-11 | 815.67d |  |  | 505h |
| 312 | 1.3.4.3.1 | **Simulator** | 8.33d? | 2008-04-01 | 2008-04-11 | 815.67d |  |  | 250h |
| 313 | 1.3.4.3.1.1 | Simulator Requirements & Interfaces | 5d? | 2008-04-01 | 2008-04-07 | 819d |  | Neyman; Wizinowich [60%] | 50h |
| 314 | 1.3.4.3.1.2 | Simulator Optical Design | 8.33d? | 2008-04-01 | 2008-04-11 | 815.67d |  | Neyman; Wizinowich [60%] | 50h |
| 315 | 1.3.4.3.1.3 | Simulator Mechanical Design | 6.25d? | 2008-04-01 | 2008-04-09 | 817.75d |  | Neyman; Bell | 60h |
| 316 | 1.3.4.3.1.4 | Simulator Electrical Design | 3.75d? | 2008-04-01 | 2008-04-04 | 820.25d |  | Neyman; Wetherell | 50h |
| 317 | 1.3.4.3.1.5 | Simulator Assembly, Alignment & Test Plans | 5d? | 2008-04-01 | 2008-04-07 | 819d |  | Neyman | 40h |
| 318 | 1.3.4.3.2 | **System Alignment Tools** | 5d? | 2008-04-01 | 2008-04-07 | 819d |  |  | 255h |
| 319 | 1.3.4.3.2.1 | Alignment Requirements & Interfaces | 5d? | 2008-04-01 | 2008-04-07 | 819d |  | Neyman; Kupke; Wizinowich [60%] | 60h |
| 320 | 1.3.4.3.2.2 | Alignment Optical Design | 5d? | 2008-04-01 | 2008-04-07 | 819d |  | Neyman; Kupke | 50h |
| 321 | 1.3.4.3.2.3 | Alignment Mechanical Design | 5d? | 2008-04-01 | 2008-04-07 | 819d |  | Neyman; Lockwood | 50h |
| 322 | 1.3.4.3.2.4 | Alignment Electrical Design | 2.5d? | 2008-04-01 | 2008-04-03 | 821.5d |  | Neyman; Wetherell | 35h |
| 323 | 1.3.4.3.2.5 | Alignment Assembly, Alignment & Test Plans | 5d? | 2008-04-01 | 2008-04-07 | 819d |  | Neyman; Kupke; Wizinowich [60%] | 60h |
| 324 | 1.3.4.4 | **Non-real-time Control** | 12.5d? | 2008-04-01 | 2008-04-17 | 811.5d |  |  | 1350h |
| 325 | 1.3.4.4.1 | **AO Controls Infrastructure** | 10d? | 2008-04-01 | 2008-04-14 | 814d |  |  | 180h |
| 326 | 1.3.4.4.1.1 | AO Controls: Distributed Controls Architecture | 10d? | 2008-04-01 | 2008-04-14 | 814d |  | Other | 80h |
| 327 | 1.3.4.4.1.2 | AO Controls: Computer Specification & Selection | 5d? | 2008-04-01 | 2008-04-07 | 819d |  | Other | 40h |
| 328 | 1.3.4.4.1.3 | AO Controls: Interface Control Document | 2.5d? | 2008-04-01 | 2008-04-03 | 821.5d |  | Other | 20h |
| 329 | 1.3.4.4.1.4 | AO Controls: Configuration Management Document | 2.5d? | 2008-04-01 | 2008-04-03 | 821.5d |  | Other | 20h |
| 330 | 1.3.4.4.1.5 | AO Controls: Summary Report | 2.5d? | 2008-04-01 | 2008-04-03 | 821.5d |  | Other | 20h |

| ID | WBS | Task | Type | Duration | Start | Finish | Total slack | Resources | Work |
| --- | --- | --- | --- | --- | --- | --- | --- | --- | --- |
| 331 | 1.3.4.4.2 | **AO Sequencer** |  | 10d? | 2008-04-01 | 2008-04-14 | 814d |  | 140h |
| 332 | 1.3.4.4.2.1 | AO Sequencer: Architecture |  | 10d? | 2008-04-01 | 2008-04-14 | 814d | Other | 80h |
| 333 | 1.3.4.4.2.2 | AO Sequencer: Interface Control Document |  | 2.5d? | 2008-04-01 | 2008-04-03 | 821.5d | Other | 20h |
| 334 | 1.3.4.4.2.3 | AO Sequencer: Software Module Design |  | 1.25d? | 2008-04-01 | 2008-04-02 | 822.75d | Other | 10h |
| 335 | 1.3.4.4.2.4 | AO Sequencer: User Interface Design | milestone | 0d? | 2008-04-01 | 2008-04-01 | 824d | Other |  |
| 336 | 1.3.4.4.2.5 | AO Sequencer: Technical Specifications |  | 2.5d? | 2008-04-01 | 2008-04-03 | 821.5d | Other | 20h |
| 337 | 1.3.4.4.2.6 | AO Sequencer: Compliance Matrix | milestone | 0d? | 2008-04-01 | 2008-04-01 | 824d | Other |  |
| 338 | 1.3.4.4.2.7 | AO Sequencer: Test Plan | milestone | 0d? | 2008-04-01 | 2008-04-01 | 824d | Other |  |
| 339 | 1.3.4.4.2.8 | AO Sequencer: Summary Report |  | 1.25d? | 2008-04-01 | 2008-04-02 | 822.75d | Other | 10h |
| 340 | 1.3.4.4.3 | **AO Motion Control Software** |  | 10d? | 2008-04-01 | 2008-04-14 | 814d |  | 220h |
| 341 | 1.3.4.4.3.1 | Motion Control SW: Architecture |  | 10d? | 2008-04-01 | 2008-04-14 | 814d | Other | 80h |
| 342 | 1.3.4.4.3.2 | Motion Control SW: ICD |  | 5d? | 2008-04-01 | 2008-04-07 | 819d | Other | 40h |
| 343 | 1.3.4.4.3.3 | Motion Control SW: Module Design |  | 7.5d? | 2008-04-01 | 2008-04-10 | 816.5d | Other | 60h |
| 344 | 1.3.4.4.3.4 | Motion Control SW: User Interface Design | milestone | 0d? | 2008-04-01 | 2008-04-01 | 824d | Other |  |
| 345 | 1.3.4.4.3.5 | Motion Control SW: Technical Specifications |  | 2.5d? | 2008-04-01 | 2008-04-03 | 821.5d | Other | 20h |
| 346 | 1.3.4.4.3.6 | Motion Control SW: Compliance Matrix | milestone | 0d? | 2008-04-01 | 2008-04-01 | 824d | Other |  |
| 347 | 1.3.4.4.3.7 | Motion Control SW: Test Plan | milestone | 0d? | 2008-04-01 | 2008-04-01 | 824d | Other |  |
| 348 | 1.3.4.4.3.8 | Motion Control SW: Summary Report |  | 2.5d? | 2008-04-01 | 2008-04-03 | 821.5d | Other | 20h |
| 349 | 1.3.4.4.4 | **AO Device Control Software** |  | 10d? | 2008-04-01 | 2008-04-14 | 814d |  | 240h |
| 350 | 1.3.4.4.4.1 | Device Control: Software Architecture |  | 10d? | 2008-04-01 | 2008-04-14 | 814d | Other | 80h |
| 351 | 1.3.4.4.4.2 | Device Control: Interface Control Document |  | 5d? | 2008-04-01 | 2008-04-07 | 819d | Other | 40h |
| 352 | 1.3.4.4.4.3 | Device Control: Software Module Design |  | 10d? | 2008-04-01 | 2008-04-14 | 814d | Other | 80h |
| 353 | 1.3.4.4.4.4 | Device Control: User Interface Design | milestone | 0d? | 2008-04-01 | 2008-04-01 | 824d | Other |  |
| 354 | 1.3.4.4.4.5 | Device Control: Technical Specifications |  | 2.5d? | 2008-04-01 | 2008-04-03 | 821.5d | Other | 20h |
| 355 | 1.3.4.4.4.6 | Device Control: Compliance Matrix | milestone | 0d? | 2008-04-01 | 2008-04-01 | 824d | Other |  |
| 356 | 1.3.4.4.4.7 | Device Control: Test Plan | milestone | 0d? | 2008-04-01 | 2008-04-01 | 824d | Other |  |
| 357 | 1.3.4.4.4.8 | Device Control: Summary Report |  | 2.5d? | 2008-04-01 | 2008-04-03 | 821.5d | Other | 20h |

| ID | WBS | Task | Type | Duration | Start | Finish | Total slack | Resources | Work |
| --- | --- | --- | --- | --- | --- | --- | --- | --- | --- |
| 358 | 1.3.4.4.5 | **AO Motion Control Electronics** |  | 12.5d? | 2008-04-01 | 2008-04-17 | 811.5d |  | 200h |
| 359 | 1.3.4.4.5.1 | Motion Control HW: Architecture Trade Study |  | 12.5d? | 2008-04-01 | 2008-04-17 | 811.5d | Wetherell | 100h |
| 360 | 1.3.4.4.5.2 | Motion Control HW: Electronics Specification & Selection |  | 1.25d? | 2008-04-01 | 2008-04-02 | 822.75d | Wetherell | 10h |
| 361 | 1.3.4.4.5.3 | Motion Control HW: Spreadsheet |  | 10d? | 2008-04-01 | 2008-04-14 | 814d | Wetherell | 80h |
| 362 | 1.3.4.4.5.4 | Motion Control HW: Compliance Matrix | milestone | 0d? | 2008-04-01 | 2008-04-01 | 824d | Wetherell |  |
| 363 | 1.3.4.4.5.5 | Motion Control HW: Test Plan | milestone | 0d? | 2008-04-01 | 2008-04-01 | 824d | Wetherell |  |
| 364 | 1.3.4.4.5.6 | Motion Control HW: Summary Report |  | 1.25d? | 2008-04-01 | 2008-04-02 | 822.75d | Wetherell | 10h |
| 365 | 1.3.4.4.6 | **Non-RTC Electronics** |  | 10d? | 2008-04-01 | 2008-04-14 | 814d |  | 140h |
| 366 | 1.3.4.4.6.1 | Non-RTC Electronics: Architecture |  | 10d? | 2008-04-01 | 2008-04-14 | 814d | Wetherell | 80h |
| 367 | 1.3.4.4.6.2 | Non-RTC Electronics: Specification & Selection |  | 5d? | 2008-04-01 | 2008-04-07 | 819d | Wetherell | 40h |
| 368 | 1.3.4.4.6.3 | Non-RTC Electronics: Compliance Matrix | milestone | 0d? | 2008-04-01 | 2008-04-01 | 824d | Wetherell |  |
| 369 | 1.3.4.4.6.4 | Non-RTC Electronics: Test Plan | milestone | 0d? | 2008-04-01 | 2008-04-01 | 824d | Wetherell |  |
| 370 | 1.3.4.4.6.5 | Non-RTC Electronics: Summary Report |  | 2.5d? | 2008-04-01 | 2008-04-03 | 821.5d | Wetherell | 20h |
| 371 | 1.3.4.4.7 | **Non-RTC System Integration & Test** |  | 2.5d? | 2008-04-01 | 2008-04-03 | 821.5d |  | 70h |
| 372 | 1.3.4.4.7.1 | Non-RTC I&T: Architecture |  | 2.5d? | 2008-04-01 | 2008-04-03 | 821.5d | Other; Wetherell | 40h |
| 373 | 1.3.4.4.7.2 | Non-RTC I&T: Electronics Specification & Selection | milestone | 0d? | 2008-04-01 | 2008-04-01 | 824d | Wetherell |  |
| 374 | 1.3.4.4.7.3 | Non-RTC I&T: Test Plan |  | 1.88d? | 2008-04-01 | 2008-04-02 | 822.12d | Other; Wetherell | 30h |
| 375 | 1.3.4.4.7.4 | Non-RTC I&T: Summary Report | milestone | 0d? | 2008-04-01 | 2008-04-01 | 824d | Other; Wetherell |  |
| 376 | 1.3.4.4.8 | **Acquisition, Guiding & Offload (AGO) Control** |  | 10d? | 2008-04-01 | 2008-04-14 | 814d |  | 160h |
| 377 | 1.3.4.4.8.1 | AGO: Architecture |  | 10d? | 2008-04-01 | 2008-04-14 | 814d | Other | 80h |
| 378 | 1.3.4.4.8.2 | AGO: ICD |  | 5d? | 2008-04-01 | 2008-04-07 | 819d | Other | 40h |
| 379 | 1.3.4.4.8.3 | AGO: Software Module Design |  | 1.25d? | 2008-04-01 | 2008-04-02 | 822.75d | Other | 10h |
| 380 | 1.3.4.4.8.4 | AGO: User Interface | milestone | 0d? | 2008-04-01 | 2008-04-01 | 824d | Other |  |
| 381 | 1.3.4.4.8.5 | AGO: Technical Specification |  | 1.25d? | 2008-04-01 | 2008-04-02 | 822.75d | Other | 10h |
| 382 | 1.3.4.4.8.6 | AGO: Compliance Matrix | milestone | 0d? | 2008-04-01 | 2008-04-01 | 824d | Other |  |
| 383 | 1.3.4.4.8.7 | AGO: Test Plan | milestone | 0d? | 2008-04-01 | 2008-04-01 | 824d | Other |  |
| 384 | 1.3.4.4.8.8 | AGO: Summary Report |  | 2.5d? | 2008-04-01 | 2008-04-03 | 821.5d | Other | 20h |

| ID | WBS | Task | Duration | Start | Finish | Total slack | Resources | Work |
| --- | --- | --- | --- | --- | --- | --- | --- | --- |
| 385 | 1.3.4.5 | **Real-time Control** | 10d? | 2008-04-01 | 2008-04-14 | 814d |  | 320h |
| 386 | 1.3.4.5.1 | **RTC Processor** | 1d? | 2008-04-01 | 2008-04-01 | 823d |  |  |
| 387 | 1.3.4.5.1.1 | RTC Technical Management | 1d? | 2008-04-01 | 2008-04-01 | 823d |  |  |
| 388 | 1.3.4.5.1.2 | Centroid/Wavefront Reconstruction Coding | 1d? | 2008-04-01 | 2008-04-01 | 823d |  |  |
| 389 | 1.3.4.5.1.3 | Centroid/Wavefront Reconstruction Testing | 1d? | 2008-04-01 | 2008-04-01 | 823d |  |  |
| 390 | 1.3.4.5.1.4 | Preconditioning & Scaling Coding | 1d? | 2008-04-01 | 2008-04-01 | 823d |  |  |
| 391 | 1.3.4.5.1.5 | Preconditioning & Scaling Testing | 1d? | 2008-04-01 | 2008-04-01 | 823d |  |  |
| 392 | 1.3.4.5.1.6 | Low Order WFS Code Design | 1d? | 2008-04-01 | 2008-04-01 | 823d |  |  |
| 393 | 1.3.4.5.1.7 | Low Order WFS Code Testing | 1d? | 2008-04-01 | 2008-04-01 | 823d |  |  |
| 394 | 1.3.4.5.1.8 | Layer Combining & DM Processing Coding | 1d? | 2008-04-01 | 2008-04-01 | 823d |  |  |
| 395 | 1.3.4.5.1.9 | Centroid Distance from Camera Issues | 1d? | 2008-04-01 | 2008-04-01 | 823d |  |  |
| 396 | 1.3.4.5.1.10 | Radial versus Rectilinear Voxels | 1d? | 2008-04-01 | 2008-04-01 | 823d |  |  |
| 397 | 1.3.4.5.1.11 | Define Required Bit Resolution | 1d? | 2008-04-01 | 2008-04-01 | 823d |  |  |
| 398 | 1.3.4.5.1.12 | Characterize SEU | 1d? | 2008-04-01 | 2008-04-01 | 823d |  |  |
| 399 | 1.3.4.5.1.13 | Power Characterization and Parameter Estimation | 1d? | 2008-04-01 | 2008-04-01 | 823d |  |  |
| 400 | 1.3.4.5.1.14 | Voxel Communication Parameters | 1d? | 2008-04-01 | 2008-04-01 | 823d |  |  |
| 401 | 1.3.4.5.1.15 | Diagnostic Control & I/O | 1d? | 2008-04-01 | 2008-04-01 | 823d |  |  |
| 402 | 1.3.4.5.1.16 | Monitoring Control & I/O | 1d? | 2008-04-01 | 2008-04-01 | 823d |  |  |
| 403 | 1.3.4.5.1.17 | Testing | 1d? | 2008-04-01 | 2008-04-01 | 823d |  |  |
| 404 | 1.3.4.5.1.18 | Documentation | 1d? | 2008-04-01 | 2008-04-01 | 823d |  |  |
| 405 | 1.3.4.5.2 | **DMs & Tip/Tilt Stages** | 10d? | 2008-04-01 | 2008-04-14 | 814d |  | 320h |
| 406 | 1.3.4.5.2.1 | **Woofer DM/TT** | 5d? | 2008-04-01 | 2008-04-07 | 819d |  | 132h |
| 407 | 1.3.4.5.2.1.1 | Define Requirements | 4d? | 2008-04-01 | 2008-04-04 | 820d | Gavel [50%] | 16h |
| 408 | 1.3.4.5.2.1.2 | Evaluate Tip/Tilt Mount Options | 5d? | 2008-04-01 | 2008-04-07 | 819d | Lockwood; Gavel [50%] | 44h |
| 409 | 1.3.4.5.2.1.3 | Evaluate Combined DM & Tip/Tilt Performance | 4d? | 2008-04-01 | 2008-04-04 | 820d | Gavel [50%] | 16h |
| 410 | 1.3.4.5.2.1.4 | Select Tip/Tilt Mount | 1d? | 2008-04-01 | 2008-04-01 | 823d | Gavel [50%]; Lockwood | 8h |
| 411 | 1.3.4.5.2.1.5 | Design Mechanical Package | 5d? | 2008-04-01 | 2008-04-07 | 819d | Lockwood | 40h |
| 412 | 1.3.4.5.2.1.6 | Obtain Quotes | 2d? | 2008-04-01 | 2008-04-02 | 822d | Lockwood [50%] | 8h |

| ID | WBS | Task | Duration | Start | Finish | Predecessors | Total slack | Free slack | Resources | Work |
| --- | --- | --- | --- | --- | --- | --- | --- | --- | --- | --- |
| 413 | 1.3.4.5.2.2 | **Tweeter DM/TT** | 2.5d? | 2008-04-01 | 2008-04-03 |  | 821.5d |  |  | 48h |
| 414 | 1.3.4.5.2.2.1 | Define Requirements | 2d? | 2008-04-01 | 2008-04-02 |  | 822d |  | Gavel [50%] | 8h |
| 415 | 1.3.4.5.2.2.2 | Evaluate Options & Select Tip/Tilt Mount | 2.5d? | 2008-04-01 | 2008-04-03 |  | 821.5d |  | Lockwood; Gavel [50%] | 28h |
| 416 | 1.3.4.5.2.2.3 | Design Mechanical Package | 1d? | 2008-04-01 | 2008-04-01 |  | 823d |  | Lockwood | 8h |
| 417 | 1.3.4.5.2.2.4 | Obtain Quotes | 1d? | 2008-04-01 | 2008-04-01 |  | 823d |  | Gavel [50%] | 4h |
| 418 | 1.3.4.5.2.3 | **LOWFS DM/TT** | 10d? | 2008-04-01 | 2008-04-14 |  | 814d |  |  | 140h |
| 419 | 1.3.4.5.2.3.1 | Define Requirements including LOWFS Interface | 2.5d? | 2008-04-01 | 2008-04-03 |  | 821.5d |  | Gavel [50%]; Velur | 28h |
| 420 | 1.3.4.5.2.3.2 | Evaluate Options & Select Tip/Tilt Mount | 2.5d? | 2008-04-01 | 2008-04-03 |  | 821.5d |  | Lockwood; Gavel [50%] | 28h |
| 421 | 1.3.4.5.2.3.3 | Design Mechanical Package | 10d? | 2008-04-01 | 2008-04-14 |  | 814d |  | Lockwood | 80h |
| 422 | 1.3.4.5.2.3.4 | Obtain Quotes | 1d? | 2008-04-01 | 2008-04-01 |  | 823d |  | Gavel [50%] | 4h |
| 423 | 1.3.4.6 | **AO System Lab I&T** | 1d? | 2008-04-01 | 2008-04-01 |  | 823d |  |  | 200h |
| 424 | 1.3.4.6.1 | AO System Lab I&T Scope Definition | 1d? | 2008-04-01 | 2008-04-01 |  | 823d |  | Wizinowich [200%] | 16h |
| 425 | 1.3.4.6.2 | AO System Lab Facility Plan | 1d? | 2008-04-01 | 2008-04-01 |  | 823d |  | Neyman [300%] | 24h |
| 426 | 1.3.4.6.3 | AO System Lab Integration Plan | 1d? | 2008-04-01 | 2008-04-01 |  | 823d |  | Neyman [1000%] | 80h |
| 427 | 1.3.4.6.4 | AO System Lab Test Plan | 1d? | 2008-04-01 | 2008-04-01 |  | 823d |  | Neyman [1000%] | 80h |
| 428 | 1.3.5 | **Laser System Design** | 280d? | 2008-04-01 | 2009-04-27 |  | 544d |  |  | 2484h |
| 429 | 1.3.5.1 | **Laser Enclosure (LE)** | 5d? | 2008-04-01 | 2008-04-07 |  | 819d |  |  | 160h |
| 430 | 1.3.5.1.1 | LE Requirements & Interfaces | 2.5d? | 2008-04-01 | 2008-04-03 |  | 821.5d |  | Chin; Medeiros | 40h |
| 431 | 1.3.5.1.2 | LE Mechanical Design | 5d? | 2008-04-01 | 2008-04-07 |  | 819d |  | Chin; Medeiros | 50h |
| 432 | 1.3.5.1.3 | LE Environmental Control Design | 5d? | 2008-04-01 | 2008-04-07 |  | 819d |  | Chin; Nance | 50h |
| 433 | 1.3.5.1.4 | LE Assembly & Test Plans | 1d? | 2008-04-01 | 2008-04-01 |  | 823d |  | Chin; Nance; Medeiros | 20h |
| 434 | 5.2.3 | **Laser** | 280d? | 2008-04-01 | 2009-04-27 |  | 544d |  |  | 820h |
| 435 | 1.3.5.2.1 | Laser Project Management | 18.75d? | 2008-04-01 | 2008-04-25 |  | 805.25d |  | Adkins; Kissner | 300h |
| 436 | 5.2.3.1 | **Laser Requirements** | 110d | 2008-04-01 | 2008-09-01 |  | 544d |  |  | 160h |
| 437 | 5.2.3.1.1 | Laser Performance Analysis | 20d | 2008-04-01 | 2008-04-28 |  | 544d | 0d | Adkins [25%] | 40h |
| 438 | 5.2.3.1.2 | Laser Requirements Analysis | 20d | 2008-04-29 | 2008-05-26 | 437 | 544d | 0d | Adkins [25%] | 40h |
| 439 | 5.2.3.1.3 | Laser Requirements Development | 20d | 2008-05-27 | 2008-06-23 | 438 | 544d | 0d | Adkins [25%] | 40h |
| 440 | 5.2.3.1.4 | Laser Requirements Drafting and Revisions | 50d | 2008-06-24 | 2008-09-01 | 439 | 544d | 0d | Adkins [10%] | 40h |

Notes:
- 429: JC
- 430: JC
- 431: DM
- 432: CN
- 433: JC
- 434: SA
- 435: SA
- 436: SA

| ID | WBS | Task | Duration | Start | Finish | Predecessors | Total slack | Free slack | Resources | Work |
| --- | --- | --- | --- | --- | --- | --- | --- | --- | --- | --- |
| 441 | 5.2.3.2 | **Laser Preliminary ICD** | 20d | 2008-06-24 | 2008-07-21 |  | 744d |  |  | 40h |
| 442 | 5.2.3.2.1 | Laser ICD Drafting and Revisions | 20d | 2008-06-24 | 2008-07-21 | 439 | 744d |  | Adkins [25%] | 40h |
| 443 | 5.2.3.3 | **Laser Request for Proposals (RFP)** | 90d | 2008-09-02 | 2009-01-05 |  | 544d |  |  | 120h |
| 444 | 5.2.3.3.1 | Laser Proposal Drafting | 20d | 2008-09-02 | 2008-09-29 | 440 | 544d | 0d | Adkins [25%] | 40h |
| 445 | 5.2.3.3.2 | Laser Proposal Release | 10d | 2008-09-30 | 2008-10-13 | 444 | 544d | 0d | Adkins [25%]; Kissner [30%] | 40h |
| 446 | 5.2.3.3.3 | Laser Proposal Response Period | 3mo | 2008-10-14 | 2009-01-05 | 445 | 544d | 0d | Adkins [3.3%]; Kissner [5%] | 40h |
| 447 | 5.2.3.4 | **Laser RFP Response Report** | 40d | 2009-01-06 | 2009-03-02 |  | 544d |  |  | 120h |
| 448 | 5.2.3.4.1 | Laser Proposal Evaluation | 20d | 2009-01-06 | 2009-02-02 | 446 | 544d | 0d | Adkins [25%] | 40h |
| 449 | 5.2.3.4.2 | Laser Response Discussions | 20d | 2009-02-03 | 2009-03-02 | 448 | 584d |  | Adkins [25%] | 40h |
| 450 | 5.2.3.4.3 | Laser Report Drafting and Revisions | 20d | 2009-02-03 | 2009-03-02 | 448 | 544d | 0d | Adkins [25%] | 40h |
| 451 | 5.2.3.5 | **Laser Contract** | 40d | 2009-03-03 | 2009-04-27 |  | 544d |  |  | 80h |
| 452 | 5.2.3.5.1 | Laser Contract Drafting and Revisions | 20d | 2009-03-03 | 2009-03-30 | 450 | 544d | 0d | Adkins [25%] | 40h |
| 453 | 5.2.3.5.2 | Laser Contract Negotiations | 20d | 2009-03-31 | 2009-04-27 | 452 | 544d |  | Adkins [25%] | 40h |
| 454 | 1.3.5.3 | **Laser Launch Facility (LLF)** | 25d? | 2008-04-01 | 2008-05-05 |  | 799d |  |  | 856h |
| 455 | 1.3.5.3.1 | LLF Requirements & Interfaces | 10d? | 2008-04-01 | 2008-04-14 |  | 814d |  | Neyman; Chin | 100h |
| 456 | 1.3.5.3.2 | LLF Optical Design | 25d? | 2008-04-01 | 2008-05-05 |  | 799d |  | Neyman; Other | 260h |
| 457 | 1.3.5.3.3 | LLF Launch Telescope Preliminary Design Contract | 7.5d? | 2008-04-01 | 2008-04-10 |  | 816.5d |  | Neyman; Chin; Other | 96h |
| 458 | 1.3.5.3.4 | LLF Mechanical Design | 25d? | 2008-04-01 | 2008-05-05 |  | 799d |  | Neyman; Medeiros | 220h |
| 459 | 1.3.5.3.5 | LLF Electrical Design | 12.5d? | 2008-04-01 | 2008-04-17 |  | 811.5d |  | Neyman; Wetherell | 120h |
| 460 | 1.3.5.3.6 | LLF Assembly, Alignment & Test Plans | 6.25d? | 2008-04-01 | 2008-04-09 |  | 817.75d |  | Neyman; Chin | 60h |
| 461 | 1.3.5.4 | **Laser Safety Systems** | 5d? | 2008-04-01 | 2008-04-07 |  | 819d |  |  | 170h |
| 462 | 1.3.5.4.1 | **Personnel & Equipment Safety System** | 5d? | 2008-04-01 | 2008-04-07 |  | 819d |  |  | 130h |
| 463 | 1.3.5.4.1.1 | Safety Requirements & Interfaces | 5d? | 2008-04-01 | 2008-04-07 |  | 819d |  | Chin | 40h |
| 464 | 1.3.5.4.1.2 | Safety Algorithms, Diagrams & Dataflow | 2.5d? | 2008-04-01 | 2008-04-03 |  | 821.5d |  | Other | 20h |
| 465 | 1.3.5.4.1.3 | Safety Communication Protocols & Methods | 2.5d? | 2008-04-01 | 2008-04-03 |  | 821.5d |  | Other | 20h |
| 466 | 1.3.5.4.1.4 | Safety Performance Estimate | 2.5d? | 2008-04-01 | 2008-04-03 |  | 821.5d |  | Other | 20h |
| 467 | 1.3.5.4.1.5 | Safety Electronics, Shutter & Interlocks | 1.25d? | 2008-04-01 | 2008-04-02 |  | 822.75d |  | Other | 10h |
| 468 | 1.3.5.4.1.6 | Safety Test Plans | 1.25d? | 2008-04-01 | 2008-04-02 |  | 822.75d |  | Chin; Other | 20h |

Notes:
- 441: SA
- 443: SA
- 447: SA
- 451: SA
- 454: CN
- 462: JC

| ID | WBS | Task | Duration | Start | Finish | Total slack | Resources | Work |
| --- | --- | --- | --- | --- | --- | --- | --- | --- |
| 469 | 1.3.5.4.2 | **Laser Traffic Control System (LTCS) Modifications** | 1d? | 2008-04-01 | 2008-04-01 | 823d |  | 40h |
| 470 | 1.3.5.4.2.1 | LTCS Requirements & Interfaces | 1d? | 2008-04-01 | 2008-04-01 | 823d | Summers | 8h |
| 471 | 1.3.5.4.2.2 | LTCS Algorithms, Diagrams & Dataflow | 1d? | 2008-04-01 | 2008-04-01 | 823d | Summers | 8h |
| 472 | 1.3.5.4.2.3 | LTCS Communication Protocols & Methods | 1d? | 2008-04-01 | 2008-04-01 | 823d | Summers | 8h |
| 473 | 1.3.5.4.2.4 | LTCS Performance Estimate | 1d? | 2008-04-01 | 2008-04-01 | 823d | Summers | 8h |
| 474 | 1.3.5.4.2.5 | LTCS Test Plans | 1d? | 2008-04-01 | 2008-04-01 | 823d | Summers | 8h |
| 475 | 1.3.5.5 | **Laser System Control (LSC)** | 10d? | 2008-04-01 | 2008-04-14 | 814d |  | 430h |
| 476 | 1.3.5.5.1 | LSC Requirements & Interfaces | 1d? | 2008-04-01 | 2008-04-01 | 823d |  |  |
| 477 | 1.3.5.5.2 | **LSC Software** | 10d? | 2008-04-01 | 2008-04-14 | 814d |  | 220h |
| 478 | 1.3.5.5.2.1 | LSC Software Requirements & Interfaces | 3.75d? | 2008-04-01 | 2008-04-04 | 820.25d | Other; Neyman; Chin | 60h |
| 479 | 1.3.5.5.2.2 | LSC Sequencer Software | 10d? | 2008-04-01 | 2008-04-14 | 814d | Other | 80h |
| 480 | 1.3.5.5.2.3 | LSC Motion Control Software | 5d? | 2008-04-01 | 2008-04-07 | 819d | Other | 40h |
| 481 | 1.3.5.5.2.4 | LSC Device Control Software | 5d? | 2008-04-01 | 2008-04-07 | 819d | Other | 40h |
| 482 | 1.3.5.5.3 | **LSC Hardware** | 10d? | 2008-04-01 | 2008-04-14 | 814d |  | 210h |
| 483 | 1.3.5.5.3.1 | LSC Hardware Requirements & Interfaces | 3.75d? | 2008-04-01 | 2008-04-04 | 820.25d | Neyman; Wetherell; Chin | 60h |
| 484 | 1.3.5.5.3.2 | LSC Motion Control Hardware | 10d? | 2008-04-01 | 2008-04-14 | 814d | Wetherell | 80h |
| 485 | 1.3.5.5.3.3 | LSC Device Control Hardware | 8.75d? | 2008-04-01 | 2008-04-11 | 815.25d | Wetherell | 70h |
| 486 | 1.3.5.6 | Laser System Lab I&T Plan | 4d? | 2008-04-01 | 2008-04-04 | 820d | Neyman; Chin; Nance | 48h |
| 487 | 1.3.6 | **Science Operations Tools Design** | 10d? | 2008-04-01 | 2008-04-14 | 814d |  | 1800h |
| 488 | 1.3.6.1 | **Multi-Systems Command Sequencer (MCS)** | 5d? | 2008-04-01 | 2008-04-07 | 819d |  | 580h |
| 489 | 1.3.6.1.1 | **MCS Infrastructure** | 5d? | 2008-04-01 | 2008-04-07 | 819d |  | 140h |
| 490 | 1.3.6.1.1.1 | **MCS Infrastructure Architecture** | 5d? | 2008-04-01 | 2008-04-07 | 819d |  | 140h |
| 491 | 1.3.6.1.1.1.1 | MCS Architecture | 5d? | 2008-04-01 | 2008-04-07 | 819d | Johansson | 40h |
| 492 | 1.3.6.1.1.1.2 | MCS Operations Concept Document | 5d? | 2008-04-01 | 2008-04-07 | 819d | Johansson | 40h |
| 493 | 1.3.6.1.1.1.3 | MCS Software Requirements | 5d? | 2008-04-01 | 2008-04-07 | 819d | Johansson | 40h |
| 494 | 1.3.6.1.1.1.4 | MCS Module Definitions | 2.5d? | 2008-04-01 | 2008-04-03 | 821.5d | Johansson | 20h |

Notes:
- 469: DS
- 487: DLM

| ID | WBS | Task | Duration | Start | Finish | Total slack | Resources | Work |
| --- | --- | --- | --- | --- | --- | --- | --- | --- |
| 495 | 1.3.6.1.1.2 | **Coordination Sequence Support Library** | 1d? | 2008-04-01 | 2008-04-01 | 823d |  |  |
| 496 | 1.3.6.1.1.2.1 | Functional Requirements | 1d? | 2008-04-01 | 2008-04-01 | 823d |  |  |
| 497 | 1.3.6.1.1.2.2 | Interface Definitions | 1d? | 2008-04-01 | 2008-04-01 | 823d |  |  |
| 498 | 1.3.6.1.1.3 | **Command Interface** | 1d? | 2008-04-01 | 2008-04-01 | 823d |  |  |
| 499 | 1.3.6.1.1.3.1 | Functional Requirements | 1d? | 2008-04-01 | 2008-04-01 | 823d |  |  |
| 500 | 1.3.6.1.1.3.2 | Interface Definitions | 1d? | 2008-04-01 | 2008-04-01 | 823d |  |  |
| 501 | 1.3.6.1.1.4 | **System Health** | 1d? | 2008-04-01 | 2008-04-01 | 823d |  |  |
| 502 | 1.3.6.1.1.4.1 | Functional Requirements | 1d? | 2008-04-01 | 2008-04-01 | 823d |  |  |
| 503 | 1.3.6.1.1.4.2 | Interface Definitions | 1d? | 2008-04-01 | 2008-04-01 | 823d |  |  |
| 504 | 1.3.6.1.2 | **Setup Sequences: Configuration & Calibration** | 1d? | 2008-04-01 | 2008-04-01 | 823d |  | 100h |
| 505 | 1.3.6.1.2.1 | **Setup Sequences Common Structure** | 1d? | 2008-04-01 | 2008-04-01 | 823d |  | 60h |
| 506 | 1.3.6.1.2.1.1 | Setup Sequences Operations Concept Document | 1d? | 2008-04-01 | 2008-04-01 | 823d | Johansson [250%] | 20h |
| 507 | 1.3.6.1.2.1.2 | Setup Sequences Software Requirements | 1d? | 2008-04-01 | 2008-04-01 | 823d | Johansson [250%] | 20h |
| 508 | 1.3.6.1.2.1.3 | Setup Sequences Module Definitions | 1d? | 2008-04-01 | 2008-04-01 | 823d | Johansson [250%] | 20h |
| 509 | 1.3.6.1.2.2 | **Configuration Sequences** | 1d? | 2008-04-01 | 2008-04-01 | 823d |  | 20h |
| 510 | 1.3.6.1.2.2.1 | Functional Requirements | 1d? | 2008-04-01 | 2008-04-01 | 823d | Le Mignant [250%] | 20h |
| 511 | 1.3.6.1.2.2.2 | Interface Definitions | 1d? | 2008-04-01 | 2008-04-01 | 823d |  |  |
| 512 | 1.3.6.1.2.3 | **Calibration Sequences** | 1d? | 2008-04-01 | 2008-04-01 | 823d |  | 20h |
| 513 | 1.3.6.1.2.3.1 | Functional Requirements | 1d? | 2008-04-01 | 2008-04-01 | 823d | Le Mignant [250%] | 20h |
| 514 | 1.3.6.1.2.3.2 | Interface Definitions | 1d? | 2008-04-01 | 2008-04-01 | 823d |  |  |
| 515 | 1.3.6.1.3 | **Observing Sequences** | 2.5d? | 2008-04-01 | 2008-04-03 | 821.5d |  | 240h |
| 516 | 1.3.6.1.3.1 | **Observing Sequences Common Structure** | 1d? | 2008-04-01 | 2008-04-01 | 823d |  | 120h |
| 517 | 1.3.6.1.3.1.1 | Observing Sequences Operations Concept Document | 1d? | 2008-04-01 | 2008-04-01 | 823d | Le Mignant [500%] | 40h |
| 518 | 1.3.6.1.3.1.2 | Observing Sequences Software Requirements | 1d? | 2008-04-01 | 2008-04-01 | 823d | Johansson [500%] | 40h |
| 519 | 1.3.6.1.3.1.3 | Observing Sequences Module Definitions | 1d? | 2008-04-01 | 2008-04-01 | 823d | Johansson [500%] | 40h |

| ID | WBS | Task | Duration | Start | Finish | Total slack | Resources | Work |
| --- | --- | --- | --- | --- | --- | --- | --- | --- |
| 520 | 1.3.6.1.3.2 | **Acquisition Sequences** | 1d? | 2008-04-01 | 2008-04-01 | 823d |  | 60h |
| 521 | 1.3.6.1.3.2.1 | Functional Requirements | 1d? | 2008-04-01 | 2008-04-01 | 823d | Le Mignant [500%] | 40h |
| 522 | 1.3.6.1.3.2.2 | Interface Definitions | 1d? | 2008-04-01 | 2008-04-01 | 823d | Johansson [250%] | 20h |
| 523 | 1.3.6.1.3.3 | **Observing Sequences** | 1d? | 2008-04-01 | 2008-04-01 | 823d |  | 20h |
| 524 | 1.3.6.1.3.3.1 | Functional Requirements | 0.5d? | 2008-04-01 | 2008-04-01 | 823.5d | Le Mignant [500%] | 20h |
| 525 | 1.3.6.1.3.3.2 | Interface Definitions | 1d? | 2008-04-01 | 2008-04-01 | 823d |  |  |
| 526 | 1.3.6.1.3.4 | **Quality Monitoring Sequences** | 2.5d? | 2008-04-01 | 2008-04-03 | 821.5d |  | 20h |
| 527 | 1.3.6.1.3.4.1 | Functional Requirements | 2.5d? | 2008-04-01 | 2008-04-03 | 821.5d | Le Mignant | 20h |
| 528 | 1.3.6.1.3.4.2 | Interface Definitions | 1d? | 2008-04-01 | 2008-04-01 | 823d |  |  |
| 529 | 1.3.6.1.3.5 | **Optimization Sequences** | 1d? | 2008-04-01 | 2008-04-01 | 823d |  | 20h |
| 530 | 1.3.6.1.3.5.1 | Functional Requirements | 1d? | 2008-04-01 | 2008-04-01 | 823d | Le Mignant [250%] | 20h |
| 531 | 1.3.6.1.3.5.2 | Interface Definitions | 1d? | 2008-04-01 | 2008-04-01 | 823d |  |  |
| 532 | 1.3.6.1.4 | **Alarm Handler & Troubleshooting Sequences** | 1d? | 2008-04-01 | 2008-04-01 | 823d |  | 100h |
| 533 | 1.3.6.1.4.1 | **Alarm Handler & Troubleshooting Common Structure** | 1d? | 2008-04-01 | 2008-04-01 | 823d |  | 100h |
| 534 | 1.3.6.1.4.1.1 | Alarm & Troubleshooting Operations Concept Document | 1d? | 2008-04-01 | 2008-04-01 | 823d | Le Mignant [500%] | 40h |
| 535 | 1.3.6.1.4.1.2 | Alarm & Troubleshooting Software Requirements | 1d? | 2008-04-01 | 2008-04-01 | 823d | Johansson [500%] | 40h |
| 536 | 1.3.6.1.4.1.3 | Alarm & Troubleshooting Module Definitions | 1d? | 2008-04-01 | 2008-04-01 | 823d | Johansson [250%] | 20h |
| 537 | 1.3.6.1.4.2 | **Alarm Handler Sequences** | 1d? | 2008-04-01 | 2008-04-01 | 823d |  |  |
| 538 | 1.3.6.1.4.2.1 | Functional Requirements | 1d? | 2008-04-01 | 2008-04-01 | 823d |  |  |
| 539 | 1.3.6.1.4.2.2 | Interface Definitions | 1d? | 2008-04-01 | 2008-04-01 | 823d |  |  |
| 540 | 1.3.6.1.4.3 | **Troubleshooting Sequences** | 1d? | 2008-04-01 | 2008-04-01 | 823d |  |  |
| 541 | 1.3.6.1.4.3.1 | Functional Requirements | 1d? | 2008-04-01 | 2008-04-01 | 823d |  |  |
| 542 | 1.3.6.1.4.3.2 | Interface Definitions | 1d? | 2008-04-01 | 2008-04-01 | 823d |  |  |
| 543 | 1.3.6.2 | **User Interfaces** | 10d? | 2008-04-01 | 2008-04-14 | 814d |  | 1220h |
| 544 | 1.3.6.2.1 | **User Interface (UI) Infrastructure** | 5d? | 2008-04-01 | 2008-04-07 | 819d |  | 120h |
| 545 | 1.3.6.2.1.1 | **UI Infrastructure Architecture** | 5d? | 2008-04-01 | 2008-04-07 | 819d |  | 120h |
| 546 | 1.3.6.2.1.1.1 | UI Architecture | 5d? | 2008-04-01 | 2008-04-07 | 819d | Johansson | 40h |
| 547 | 1.3.6.2.1.1.2 | UI Operations Concept Document | 5d? | 2008-04-01 | 2008-04-07 | 819d | Le Mignant | 40h |
| 548 | 1.3.6.2.1.1.3 | UI Software Requirements | 2.5d? | 2008-04-01 | 2008-04-03 | 821.5d | Johansson | 20h |
| 549 | 1.3.6.2.1.1.4 | UI Module Definitions | 1d? | 2008-04-01 | 2008-04-01 | 823d | Johansson [250%] | 20h |

| ID | WBS | Task | Duration | Start | Finish | Total slack | Resources | Work |
| --- | --- | --- | --- | --- | --- | --- | --- | --- |
| 550 | 1.3.6.2.1.2 | **UI Command Interface to MCS** | 1d? | 2008-04-01 | 2008-04-01 | 823d |  |  |
| 551 | 1.3.6.2.1.2.1 | Functional Requirements | 1d? | 2008-04-01 | 2008-04-01 | 823d |  |  |
| 552 | 1.3.6.2.1.2.2 | Interface Definitions | 1d? | 2008-04-01 | 2008-04-01 | 823d |  |  |
| 553 | 1.3.6.2.1.3 | **UI Command Interface to Observing Tools** | 1d? | 2008-04-01 | 2008-04-01 | 823d |  |  |
| 554 | 1.3.6.2.1.3.1 | Functional Requirements | 1d? | 2008-04-01 | 2008-04-01 | 823d |  |  |
| 555 | 1.3.6.2.1.3.2 | Interface Definitions | 1d? | 2008-04-01 | 2008-04-01 | 823d |  |  |
| 556 | 1.3.6.2.2 | **Setup User Interfaces** | 2.5d? | 2008-04-01 | 2008-04-03 | 821.5d |  | 80h |
| 557 | 1.3.6.2.2.1 | **Setup UI Common Structure** | 2.5d? | 2008-04-01 | 2008-04-03 | 821.5d |  | 50h |
| 558 | 1.3.6.2.2.1.1 | Setup UI Operations Concept Document | 2.5d? | 2008-04-01 | 2008-04-03 | 821.5d | Le Mignant | 20h |
| 559 | 1.3.6.2.2.1.2 | Setup UI Software Requirements | 1.25d? | 2008-04-01 | 2008-04-02 | 822.75d | Johansson | 10h |
| 560 | 1.3.6.2.2.1.3 | Setup UI Module Definitions | 2.5d? | 2008-04-01 | 2008-04-03 | 821.5d | Johansson | 20h |
| 561 | 1.3.6.2.2.2 | **Setup UI Configurations** | 1.88d? | 2008-04-01 | 2008-04-02 | 822.12d |  | 15h |
| 562 | 1.3.6.2.2.2.1 | Functional Requirements | 1.88d? | 2008-04-01 | 2008-04-02 | 822.12d | Le Mignant | 15h |
| 563 | 1.3.6.2.2.2.2 | Interface Definitions | 1d? | 2008-04-01 | 2008-04-01 | 823d |  |  |
| 564 | 1.3.6.2.2.3 | **Setup UI Calibrations** | 1.88d? | 2008-04-01 | 2008-04-02 | 822.12d |  | 15h |
| 565 | 1.3.6.2.2.3.1 | Functional Requirements | 1.88d? | 2008-04-01 | 2008-04-02 | 822.12d | Le Mignant | 15h |
| 566 | 1.3.6.2.2.3.2 | Interface Definitions | 1d? | 2008-04-01 | 2008-04-01 | 823d |  |  |
| 567 | 1.3.6.2.3 | **Observations User Interfaces** | 10d? | 2008-04-01 | 2008-04-14 | 814d |  | 240h |
| 568 | 1.3.6.2.3.1 | **Observations UI Common Structure** | 10d? | 2008-04-01 | 2008-04-14 | 814d |  | 130h |
| 569 | 1.3.6.2.3.1.1 | Observations UI Operations Concept Document | 5d? | 2008-04-01 | 2008-04-07 | 819d | Le Mignant | 40h |
| 570 | 1.3.6.2.3.1.2 | Observations UI Software Requirements | 1.25d? | 2008-04-01 | 2008-04-02 | 822.75d | Johansson | 10h |
| 571 | 1.3.6.2.3.1.3 | Observations UI Module Definitions | 10d? | 2008-04-01 | 2008-04-14 | 814d | Johansson | 80h |
| 572 | 1.3.6.2.3.2 | **Acquisition & AO Control UI** | 2.5d? | 2008-04-01 | 2008-04-03 | 821.5d |  | 30h |
| 573 | 1.3.6.2.3.2.1 | Functional Requirements | 2.5d? | 2008-04-01 | 2008-04-03 | 821.5d | Le Mignant | 20h |
| 574 | 1.3.6.2.3.2.2 | Interface Definitions | 1.25d? | 2008-04-01 | 2008-04-02 | 822.75d | Johansson | 10h |

| ID | WBS | Task | Duration | Start | Finish | Total slack | Resources | Work |
| --- | --- | --- | --- | --- | --- | --- | --- | --- |
| 575 | 1.3.6.2.3.3 | **Observing Sequences UI** | 2.5d? | 2008-04-01 | 2008-04-03 | 821.5d |  | 20h |
| 576 | 1.3.6.2.3.3.1 | Functional Requirements | 2.5d? | 2008-04-01 | 2008-04-03 | 821.5d | Le Mignant | 20h |
| 577 | 1.3.6.2.3.3.2 | Interface Definitions | 1d? | 2008-04-01 | 2008-04-01 | 823d |  |  |
| 578 | 1.3.6.2.3.4 | **Status & Graph UI** | 2.5d? | 2008-04-01 | 2008-04-03 | 821.5d |  | 20h |
| 579 | 1.3.6.2.3.4.1 | Functional Requirements | 2.5d? | 2008-04-01 | 2008-04-03 | 821.5d | Le Mignant | 20h |
| 580 | 1.3.6.2.3.4.2 | Interface Definitions | 1d? | 2008-04-01 | 2008-04-01 | 823d |  |  |
| 581 | 1.3.6.2.3.5 | **Advanced Monitoring UI** | 2.5d? | 2008-04-01 | 2008-04-03 | 821.5d |  | 20h |
| 582 | 1.3.6.2.3.5.1 | Functional Requirements | 2.5d? | 2008-04-01 | 2008-04-03 | 821.5d | Le Mignant | 20h |
| 583 | 1.3.6.2.3.5.2 | Interface Definitions | 1d? | 2008-04-01 | 2008-04-01 | 823d |  |  |
| 584 | 1.3.6.2.3.6 | **Optimization & Troubleshooting UI** | 2.5d? | 2008-04-01 | 2008-04-03 | 821.5d |  | 20h |
| 585 | 1.3.6.2.3.6.1 | Functional Requirements | 2.5d? | 2008-04-01 | 2008-04-03 | 821.5d | Le Mignant | 20h |
| 586 | 1.3.6.2.3.6.2 | Interface Definitions | 1d? | 2008-04-01 | 2008-04-01 | 823d |  |  |
| 587 | 1.3.6.2.4 | **Pre- & Post-Observing Science Support Tools** | 5d? | 2008-04-01 | 2008-04-07 | 819d |  | 710h |
| 588 | 1.3.6.2.4.1 | **User Documentation** | 1.25d? | 2008-04-01 | 2008-04-02 | 822.75d |  | 20h |
| 589 | 1.3.6.2.4.1.1 | User Documentation Operations Concept | 1.25d? | 2008-04-01 | 2008-04-02 | 822.75d | Le Mignant | 10h |
| 590 | 1.3.6.2.4.1.2 | User Documentation Functional Requirements | 1d? | 2008-04-01 | 2008-04-01 | 823d | Le Mignant [125%] | 10h |
| 591 | 1.3.6.2.4.2 | **Science Observations Planning Tools** | 5d? | 2008-04-01 | 2008-04-07 | 819d |  | 440h |
| 592 | 1.3.6.2.4.2.1 | **NGS Star Finder** | 5d? | 2008-04-01 | 2008-04-07 | 819d |  | 120h |
| 593 | 1.3.6.2.4.2.1.1 | Operations Concept | 2.5d? | 2008-04-01 | 2008-04-03 | 821.5d | Le Mignant | 20h |
| 594 | 1.3.6.2.4.2.1.2 | Functional Requirements & Use Case Definitions | 5d? | 2008-04-01 | 2008-04-07 | 819d | Le Mignant | 40h |
| 595 | 1.3.6.2.4.2.1.3 | Interface Definitions | 2.5d? | 2008-04-01 | 2008-04-03 | 821.5d | Johansson | 20h |
| 596 | 1.3.6.2.4.2.1.4 | Module Definitions | 5d? | 2008-04-01 | 2008-04-07 | 819d | Johansson | 40h |
| 597 | 1.3.6.2.4.2.2 | **Performance Prediction Tool** | 5d? | 2008-04-01 | 2008-04-07 | 819d |  | 140h |
| 598 | 1.3.6.2.4.2.2.1 | Operations Concept | 5d? | 2008-04-01 | 2008-04-07 | 819d | Le Mignant | 40h |
| 599 | 1.3.6.2.4.2.2.2 | Functional Requirements & Use Case Definitions | 5d? | 2008-04-01 | 2008-04-07 | 819d | Le Mignant | 40h |
| 600 | 1.3.6.2.4.2.2.3 | Interface Definitions | 2.5d? | 2008-04-01 | 2008-04-03 | 821.5d | Johansson | 20h |
| 601 | 1.3.6.2.4.2.2.4 | Module Definitions | 5d? | 2008-04-01 | 2008-04-07 | 819d | Johansson | 40h |

| ID | WBS | Task | Duration | Start | Finish | Total slack | Resources | Work |
| --- | --- | --- | --- | --- | --- | --- | --- | --- |
| 602 | 1.3.6.2.4.2.3 | **Observation Planning & Efficiency Tool** | 5d? | 2008-04-01 | 2008-04-07 | 819d |  | 140h |
| 603 | 1.3.6.2.4.2.3.1 | Operations Concept | 5d? | 2008-04-01 | 2008-04-07 | 819d | Le Mignant | 40h |
| 604 | 1.3.6.2.4.2.3.2 | Functional Requirements & Use Case Definitions | 5d? | 2008-04-01 | 2008-04-07 | 819d | Le Mignant | 40h |
| 605 | 1.3.6.2.4.2.3.3 | Interface Definitions | 2.5d? | 2008-04-01 | 2008-04-03 | 821.5d | Johansson | 20h |
| 606 | 1.3.6.2.4.2.3.4 | Module Definitions | 5d? | 2008-04-01 | 2008-04-07 | 819d | Johansson | 40h |
| 607 | 1.3.6.2.4.2.4 | **Laser Clearinghouse Coordination Tool** | 2.5d? | 2008-04-01 | 2008-04-03 | 821.5d |  | 40h |
| 608 | 1.3.6.2.4.2.4.1 | Operations Concept | 2.5d? | 2008-04-01 | 2008-04-03 | 821.5d | Le Mignant | 20h |
| 609 | 1.3.6.2.4.2.4.2 | Functional Requirements & Use Case Definitions | 2.5d? | 2008-04-01 | 2008-04-03 | 821.5d | Le Mignant | 20h |
| 610 | 1.3.6.2.4.2.4.3 | Interface Definitions | 1d? | 2008-04-01 | 2008-04-01 | 823d |  |  |
| 611 | 1.3.6.2.4.2.4.4 | Module Definitions | 1d? | 2008-04-01 | 2008-04-01 | 823d |  |  |
| 612 | 1.3.6.2.4.3 | **Data Products** | 5d? | 2008-04-01 | 2008-04-07 | 819d |  | 250h |
| 613 | 1.3.6.2.4.3.1 | **Generic Data Products** | 5d? | 2008-04-01 | 2008-04-07 | 819d |  | 80h |
| 614 | 1.3.6.2.4.3.1.1 | Operations Concept | 2.5d? | 2008-04-01 | 2008-04-03 | 821.5d | Le Mignant | 20h |
| 615 | 1.3.6.2.4.3.1.2 | Functional Requirements & Use Case Definitions | 5d? | 2008-04-01 | 2008-04-07 | 819d | Le Mignant | 40h |
| 616 | 1.3.6.2.4.3.1.3 | Interface Definitions | 2.5d? | 2008-04-01 | 2008-04-03 | 821.5d | Johansson | 20h |
| 617 | 1.3.6.2.4.3.2 | **Science Data Quality Assessment** | 5d? | 2008-04-01 | 2008-04-07 | 819d |  | 160h |
| 618 | 1.3.6.2.4.3.2.1 | **Quality Metrics & Logged Information** | 5d? | 2008-04-01 | 2008-04-07 | 819d |  | 80h |
| 619 | 1.3.6.2.4.3.2.1.1 | Operations Concept | 5d? | 2008-04-01 | 2008-04-07 | 819d | Le Mignant | 40h |
| 620 | 1.3.6.2.4.3.2.1.2 | Functional Requirements & Use Case Definitions | 5d? | 2008-04-01 | 2008-04-07 | 819d | Le Mignant | 40h |
| 621 | 1.3.6.2.4.3.2.1.3 | Interface Definitions | 1d? | 2008-04-01 | 2008-04-01 | 823d |  |  |
| 622 | 1.3.6.2.4.3.2.2 | **PSF Calibration** | 5d? | 2008-04-01 | 2008-04-07 | 819d |  | 80h |
| 623 | 1.3.6.2.4.3.2.2.1 | Operations Concept | 5d? | 2008-04-01 | 2008-04-07 | 819d | Le Mignant | 40h |
| 624 | 1.3.6.2.4.3.2.2.2 | Functional Requirements & Use Case Definitions | 5d? | 2008-04-01 | 2008-04-07 | 819d | Le Mignant | 40h |
| 625 | 1.3.6.2.4.3.2.2.3 | Interface Definitions | 1d? | 2008-04-01 | 2008-04-01 | 823d |  |  |
| 626 | 1.3.6.2.4.3.2.2.4 | Module Definitions | 1d? | 2008-04-01 | 2008-04-01 | 823d |  |  |

| ID | WBS | Task | Type | Duration | Start | Finish | Total slack | Constraint | Resources | Work |
| --- | --- | --- | --- | --- | --- | --- | --- | --- | --- | --- |
| 627 | 1.3.6.2.4.3.3 | **Science Data Archiving** |  | 1.25d? | 2008-04-01 | 2008-04-02 | 822.75d |  |  | 10h |
| 628 | 1.3.6.2.4.3.3.1 | Operations Concept |  | 1.25d? | 2008-04-01 | 2008-04-02 | 822.75d |  | Le Mignant | 10h |
| 629 | 1.3.6.2.4.3.3.2 | Functional Requirements & Use Case Definitions |  | 1d? | 2008-04-01 | 2008-04-01 | 823d |  |  |  |
| 630 | 1.3.6.2.4.3.3.3 | Interface Definitions |  | 1d? | 2008-04-01 | 2008-04-01 | 823d |  |  |  |
| 631 | 1.3.6.2.5 | **Data Server** |  | 5d? | 2008-04-01 | 2008-04-07 | 819d |  |  | 70h |
| 632 | 1.3.6.2.5.1 | Data Server: Architecture |  | 5d? | 2008-04-01 | 2008-04-07 | 819d |  | Johansson | 40h |
| 633 | 1.3.6.2.5.2 | Data Server: HW & SW Specification & Selection |  | 2.5d? | 2008-04-01 | 2008-04-03 | 821.5d |  | Johansson | 20h |
| 634 | 1.3.6.2.5.3 | Data Server: Software Design | milestone | 0d? | 2008-04-01 | 2008-04-01 | 824d |  | Johansson |  |
| 635 | 1.3.6.2.5.4 | Data Server: Compliance Matrix | milestone | 0d? | 2008-04-01 | 2008-04-01 | 824d |  | Johansson |  |
| 636 | 1.3.6.2.5.5 | Data Server: Test Plan | milestone | 0d? | 2008-04-01 | 2008-04-01 | 824d |  | Johansson |  |
| 637 | 1.3.6.2.5.6 | Data Server: Summary Report |  | 1.25d? | 2008-04-01 | 2008-04-02 | 822.75d |  | Johansson | 10h |
| 638 | 1.3.7 | **Telescope & Summit Engineering Design** |  | 219d? | 2008-04-01 | 2009-01-30 | 605d |  |  | 1421h |
| 639 | 1.3.7.1 | **Telescope Performance** |  | 1d? | 2008-04-01 | 2008-04-01 | 823d |  |  | 200h |
| 640 | 1.3.7.1.1 | Telescope Performance Improvement Trade Study |  | 1d? | 2008-04-01 | 2008-04-01 | 823d |  |  | 120h |
| 641 | 1.3.7.1.2 | Telescope Performance Improvement Design |  | 1d? | 2008-04-01 | 2008-04-01 | 823d |  |  | 80h |
| 642 | 1.3.7.2 | **Infrastructure Modifications for AO** |  | 17.5d? | 2008-04-01 | 2008-04-24 | 806.5d |  |  | 660h |
| 643 | 1.3.7.2.1 | Infrastructure Requirements & Interfaces |  | 7.5d? | 2008-04-01 | 2008-04-10 | 816.5d |  | Bell; Wetherell; Wizinowich [60%] | 90h |
| 644 | 1.3.7.2.2 | Infrastructure Mechanical Modifications |  | 15d? | 2008-04-01 | 2008-04-21 | 809d |  | Bell; Medeiros; Tech | 160h |
| 645 | 1.3.7.2.3 | Infrastructure Electrical Modifications |  | 15d? | 2008-04-01 | 2008-04-21 | 809d |  | Nance | 120h |
| 646 | 1.3.7.2.4 | Infrastructure Glycol Cooling Modifications |  | 17.5d? | 2008-04-01 | 2008-04-24 | 806.5d |  | Nance | 140h |
| 647 | 1.3.7.2.5 | Infrastructure CCR Modifications |  | 5d? | 2008-04-01 | 2008-04-07 | 819d |  | Nance | 40h |
| 648 | 1.3.7.2.6 | Infrastructure Implementation & Test Plans |  | 6.25d? | 2008-04-01 | 2008-04-09 | 817.75d |  | Bell; Medeiros; Nance; Chin | 110h |
| 649 | 1.3.7.3 | **Infrastructure modifications for Laser System** |  | 6.25d? | 2008-04-01 | 2008-04-09 | 817.75d |  |  | 280h |
| 650 | 1.3.7.3.1 | Infrastructure Requirements & Interfaces |  | 5d? | 2008-04-01 | 2008-04-07 | 819d |  | Bell; Chin; Nance | 70h |
| 651 | 1.3.7.3.2 | Infrastructure Mechanical Modifications |  | 6.25d? | 2008-04-01 | 2008-04-09 | 817.75d |  | Medeiros | 50h |
| 652 | 1.3.7.3.3 | Infrastructure Electrical Modifications |  | 5d? | 2008-04-01 | 2008-04-07 | 819d |  | Nance | 40h |
| 653 | 1.3.7.3.4 | Infrastructure Glycol Cooling Modifications |  | 6.25d? | 2008-04-01 | 2008-04-09 | 817.75d |  | Nance | 50h |
| 654 | 1.3.7.3.5 | Infrastructure Implementation & Test Plans |  | 5d? | 2008-04-01 | 2008-04-07 | 819d |  | Bell; Chin; Medeiros; Nance | 70h |
| 655 | 1.3.7.4 | OSIRIS Modifications |  | 10d? | 2009-01-19 | 2009-01-30 | 605d | finish no earlier than 2009-01-30 | Adkins; Other; Medeiros | 220h |

Notes:
- 631: EJ
- 642: JB
- 643: JB
- 644: DM
- 645: CN
- 646: CN
- 647: CN
- 648: JB
- 649: JB
- 650: JB
- 651: DM
- 652: CN
- 653: CN
- 654: JB
- 655: SA

| ID | WBS | Task | Duration | Start | Finish | Total slack | Resources | Work |
| --- | --- | --- | --- | --- | --- | --- | --- | --- |
| 656 | 1.3.7.5 | **Interferometer Modifications** | 5.21d? | 2008-04-01 | 2008-04-08 | 818.79d |  | 61h |
| 657 | 1.3.7.5.1 | Optical Design of Post Field Selector Optics | 5.21d? | 2008-04-01 | 2008-04-08 | 818.79d | Wizinowich [60%]; Kupke | 45h |
| 658 | 1.3.7.5.2 | Evaluation of Optical Design Impact on Interferometer | 3.33d? | 2008-04-01 | 2008-04-04 | 820.67d | Wizinowich [60%] | 16h |
| 659 | 1.3.8 | **Telescope Integration & Test** | 7.5d? | 2008-04-01 | 2008-04-10 | 816.5d |  | 622h |
| 660 | 1.3.8.1 | **Old AO/Laser Removal** | 1d? | 2008-04-01 | 2008-04-01 | 823d |  | 120h |
| 661 | 1.3.8.1.1 | AO Removal Plan | 1d? | 2008-04-01 | 2008-04-01 | 823d | Other [750%] | 60h |
| 662 | 1.3.8.1.2 | Laser Removal Plan | 1d? | 2008-04-01 | 2008-04-01 | 823d | Other [750%] | 60h |
| 663 | 1.3.8.2 | Laser Enclosure Integration | 1d? | 2008-04-01 | 2008-04-01 | 823d |  |  |
| 664 | 1.3.8.3 | AO Enclosure Integration | 1d? | 2008-04-01 | 2008-04-01 | 823d |  |  |
| 665 | 1.3.8.4 | **AO System Install + I&T** | 5d? | 2008-04-01 | 2008-04-07 | 819d |  | 170h |
| 666 | 1.3.8.4.1 | Opto-Mechanical Integration Plan | 0.6d? | 2008-04-01 | 2008-04-01 | 823.4d | Other [1250%] | 60h |
| 667 | 1.3.8.4.2 | Electronics Integration Plan | 1d? | 2008-04-01 | 2008-04-01 | 823d | Wetherell [500%] | 40h |
| 668 | 1.3.8.4.3 | Computer Integration Plan | 2.5d? | 2008-04-01 | 2008-04-03 | 821.5d | Chock | 20h |
| 669 | 1.3.8.4.4 | AO System Integration Plan | 5d? | 2008-04-01 | 2008-04-07 | 819d | Other | 40h |
| 670 | 1.3.8.4.5 | AO System Test Plan | 1d? | 2008-04-01 | 2008-04-01 | 823d | Other [125%] | 10h |
| 671 | 1.3.8.5 | **Laser System Install + I&T** | 7.5d? | 2008-04-01 | 2008-04-10 | 816.5d |  | 212h |
| 672 | 1.3.8.5.1 | Laser System Installation & Integration Plan | 7.5d? | 2008-04-01 | 2008-04-10 | 816.5d | Chin; Nance; Medeiros; Wetherell; Neyman; Adkins | 148h |
| 673 | 1.3.8.5.2 | Laser System Test Plan | 5d? | 2008-04-01 | 2008-04-07 | 819d | Neyman; Wetherell; Other; Chin; Adkins | 64h |
| 674 | 1.3.8.6 | LGS AO System On-sky I&T Plan | 4.17d? | 2008-04-01 | 2008-04-07 | 819.83d | Le Mignant; Wizinowich [60%] | 40h |
| 675 | 1.3.8.7 | Performance Characterization | 1d? | 2008-04-01 | 2008-04-01 | 823d |  |  |
| 676 | 1.3.8.8 | Science Verification Plan | 7.5d? | 2008-04-01 | 2008-04-10 | 816.5d | Le Mignant; Wizinowich [60%] | 80h |
| 677 | 1.3.9 | **Operations Transition** | 7d? | 2008-04-01 | 2008-04-09 | 817d |  | 166h |
| 678 | 1.3.9.1 | **Operations Plans** | 7d? | 2008-04-01 | 2008-04-09 | 817d |  | 96h |
| 679 | 1.3.9.1.1 | Operations Support Plan | 1d? | 2008-04-01 | 2008-04-01 | 823d | Le Mignant [500%] | 40h |
| 680 | 1.3.9.1.2 | Operations Maintenance & Spares Plan Template | 7d? | 2008-04-01 | 2008-04-09 | 817d | Other | 56h |

Notes:
- 656: PW
- 657: PW
- 658: PW
- 671: JC
- 672: JC
- 673: CN
- 674: DLM
- 676: DLM
- 679: DLM

| ID | WBS | Task | Duration | Start | Finish | Total slack | Constraint | Resources | Work |
| --- | --- | --- | --- | --- | --- | --- | --- | --- | --- |
| 681 | 1.3.9.2 | **Operations Handover** | 5d? | 2008-04-01 | 2008-04-07 | 819d |  |  | 70h |
| 682 | 1.3.9.2.1 | Operations Personnel Training Plan | 5d? | 2008-04-01 | 2008-04-07 | 819d |  | Le Mignant; Wizinowich [60%] | 50h |
| 683 | 1.3.9.2.2 | Documentation Transition Plan | 2.5d? | 2008-04-01 | 2008-04-03 | 821.5d |  | Le Mignant | 20h |
| 684 | 1.4 | **Detailed Design** | 824d? | 2008-04-01 | 2011-05-27 | 0d |  |  | 9745h |
| 685 | 1.4.1 | Placeholder | 1d? | 2008-04-01 | 2008-04-01 | 823d |  |  |  |
| 686 | 1.4.2 | **DD Phase Management** | 824d? | 2008-04-01 | 2011-05-27 | 0d |  |  | 8615h |
| 687 | 1.4.2.1 | **Planning** | 824d? | 2008-04-01 | 2011-05-27 | 0d |  |  | 1980h |
| 688 | 1.4.2.1.1 | **Replans** | 449d? | 2008-04-01 | 2009-12-18 | 375d |  |  | 380h |
| 689 | 1.4.2.1.1.1 | Replan based on PDR | 20d? | 2009-11-23 | 2009-12-18 | 375d | finish no earlier than 2009-12-18 |  | 60h |
| 690 | 1.4.2.1.1.2 | Replan 1 | 1d? | 2008-04-01 | 2008-04-01 | 823d |  |  | 160h |
| 691 | 1.4.2.1.1.3 | Replan 2 | 1d? | 2008-04-01 | 2008-04-01 | 823d |  |  | 160h |
| 692 | 1.4.2.1.2 | **WMKO FY Plans** | 345d? | 2010-02-01 | 2011-05-27 | 0d |  |  | 80h |
| 693 | 1.4.2.1.2.1 | Support WMKO FY11 Planning | 85d? | 2010-02-01 | 2010-05-28 | 260d | start no earlier than 2010-02-01 |  | 40h |
| 694 | 1.4.2.1.2.2 | Support WMKO FY12 Planning | 84d? | 2011-02-01 | 2011-05-27 | 0d | finish no earlier than 2011-05-27 |  | 40h |
| 695 | 1.4.2.1.3 | **Systems Engineering Management Plan** | 1d? | 2008-04-01 | 2008-04-01 | 823d |  |  | 1520h |
| 696 | 1.4.2.1.3.1 | **Project Plan** | 1d? | 2008-04-01 | 2008-04-01 | 823d |  |  | 1400h |
| 697 | 1.4.2.1.3.1.1 | PBS, WBS & Task Definition | 1d? | 2008-04-01 | 2008-04-01 | 823d |  |  | 200h |
| 698 | 1.4.2.1.3.1.2 | Cost Estimation | 1d? | 2008-04-01 | 2008-04-01 | 823d |  |  | 560h |
| 699 | 1.4.2.1.3.1.3 | Full Schedule | 1d? | 2008-04-01 | 2008-04-01 | 823d |  |  | 640h |
| 700 | 1.4.2.1.3.2 | SEMP Document | 1d? | 2008-04-01 | 2008-04-01 | 823d |  |  | 120h |
| 701 | 1.4.2.2 | **Project Management & Meetings** | 1d? | 2008-04-01 | 2008-04-01 | 823d |  |  | 3600h |
| 702 | 1.4.2.2.1 | Executive Committee | 1d? | 2008-04-01 | 2008-04-01 | 823d |  |  | 700h |
| 703 | 1.4.2.2.2 | Team Meetings | 1d? | 2008-04-01 | 2008-04-01 | 823d |  |  | 2900h |
| 704 | 1.4.2.2.3 | Director Telecons | 1d? | 2008-04-01 | 2008-04-01 | 823d |  |  |  |

Notes:
- 681: DLM
- 682: DLM
- 683: DLM

| ID | WBS | Task | Type | Duration | Start | Finish | Total slack | Constraint | Work |
| --- | --- | --- | --- | --- | --- | --- | --- | --- | --- |
| 705 | 1.4.2.3 | **Tracking & Reporting** |  | 1d? | 2008-04-01 | 2008-04-01 | 823d |  | 1535h |
| 706 | 1.4.2.3.1 | Monthly Team Status Reports |  | 1d? | 2008-04-01 | 2008-04-01 | 823d |  | 855h |
| 707 | 1.4.2.3.2 | SSC Meetings |  | 1d? | 2008-04-01 | 2008-04-01 | 823d |  | 180h |
| 708 | 1.4.2.3.3 | Other Presentations |  | 1d? | 2008-04-01 | 2008-04-01 | 823d |  | 500h |
| 709 | 1.4.2.4 | **Proposals & Fundraising** |  | 1d? | 2008-04-01 | 2008-04-01 | 823d |  | 380h |
| 710 | 1.4.2.4.1 | Support Advancement Office |  | 1d? | 2008-04-01 | 2008-04-01 | 823d |  | 120h |
| 711 | 1.4.2.4.2 | Proposal(s) for Fabrication |  | 1d? | 2008-04-01 | 2008-04-01 | 823d |  | 260h |
| 712 | 1.4.2.5 | **Programmatic Risk Assessment & Mitigation** |  | 1d? | 2008-04-01 | 2008-04-01 | 823d |  | 560h |
| 713 | 1.4.2.5.1 | Risk Assessment |  | 1d? | 2008-04-01 | 2008-04-01 | 823d |  | 60h |
| 714 | 1.4.2.5.2 | Risk Mitigation |  | 1d? | 2008-04-01 | 2008-04-01 | 823d |  | 500h |
| 715 | 1.4.2.6 | **Detailed Design Review** |  | 131d? | 2010-11-17 | 2011-05-18 | 7d |  | 560h |
| 716 | 1.4.2.6.1 | Review Setup |  | 3d? | 2010-11-17 | 2010-11-19 | 135d | finish no earlier than 2010-11-19 | 16h |
| 717 | 1.4.2.6.2 | Detailed Design Report |  | 14d? | 2011-03-07 | 2011-03-24 | 46d | finish no earlier than 2011-03-24 | 80h |
| 718 | 1.4.2.6.3 | Review Package Distributed |  | 1d? | 2011-03-25 | 2011-03-25 | 45d | finish no earlier than 2011-03-25 | 4h |
| 719 | 1.4.2.6.4 | Review Comments Received | milestone | 0d | 2011-04-08 | 2011-04-08 | 36d | start no earlier than 2011-04-08 |  |
| 720 | 1.4.2.6.5 | Reviewer Comments Addressed |  | 5d? | 2011-04-11 | 2011-04-15 | 30d | finish no earlier than 2011-04-15 | 120h |
| 721 | 1.4.2.6.6 | DDR Presentation Preparation |  | 15d? | 2011-03-28 | 2011-04-15 | 30d | finish no earlier than 2011-04-15 | 120h |
| 722 | 1.4.2.6.7 | Detailed Design Review |  | 1d? | 2011-04-20 | 2011-04-20 | 27d | start no earlier than 2011-04-20 | 160h |
| 723 | 1.4.2.6.8 | Reviewer Report Received | milestone | 0d | 2011-05-11 | 2011-05-11 | 13d | start no earlier than 2011-05-11 |  |
| 724 | 1.4.2.6.9 | Response to Reviewer Report |  | 5d? | 2011-05-12 | 2011-05-18 | 7d | finish no earlier than 2011-05-18 | 60h |
| 725 | 1.4.2.7 | **Management Support** |  | 1d? | 2008-04-01 | 2008-04-01 | 823d |  |  |
| 726 | 1.4.2.7.1 | Administrative Support |  | 1d? | 2008-04-01 | 2008-04-01 | 823d |  |  |
| 727 | 1.4.2.7.2 | Shared Infrastructure |  | 1d? | 2008-04-01 | 2008-04-01 | 823d |  |  |
| 728 | 1.4.2.7.3 | Research Time |  | 1d? | 2008-04-01 | 2008-04-01 | 823d |  |  |

| ID | WBS | Task | Duration | Start | Finish | Total slack |
| --- | --- | --- | --- | --- | --- | --- |
| 729 | 1.4.3 | **Systems Engineering** | 1d? | 2008-04-01 | 2008-04-01 | 823d |
| 730 | 1.4.3.1 | Science Case Development | 1d? | 2008-04-01 | 2008-04-01 | 823d |
| 731 | 1.4.3.2 | **Requirements** | 1d? | 2008-04-01 | 2008-04-01 | 823d |
| 732 | 1.4.3.2.1 | Science Requirements | 1d? | 2008-04-01 | 2008-04-01 | 823d |
| 733 | 1.4.3.2.2 | Operations Concept Document | 1d? | 2008-04-01 | 2008-04-01 | 823d |
| 734 | 1.4.3.2.3 | System Requirements | 1d? | 2008-04-01 | 2008-04-01 | 823d |
| 735 | 1.4.3.2.4 | Functional Requirements | 1d? | 2008-04-01 | 2008-04-01 | 823d |
| 736 | 1.4.3.3 | **System Architecture** | 1d? | 2008-04-01 | 2008-04-01 | 823d |
| 737 | 1.4.3.3.1 | Opto-Mechanical Architecture | 1d? | 2008-04-01 | 2008-04-01 | 823d |
| 738 | 1.4.3.3.2 | Software Architecture | 1d? | 2008-04-01 | 2008-04-01 | 823d |
| 739 | 1.4.3.3.3 | Motion Control / Electronics Architecture | 1d? | 2008-04-01 | 2008-04-01 | 823d |
| 740 | 1.4.3.4 | Modeling & Analysis | 1d? | 2008-04-01 | 2008-04-01 | 823d |
| 741 | 1.4.3.5 | **Performance Budgets** | 1d? | 2008-04-01 | 2008-04-01 | 823d |
| 742 | 1.4.3.5.1 | Throughput & Background | 1d? | 2008-04-01 | 2008-04-01 | 823d |
| 743 | 1.4.3.5.2 | Wavefront & Encircled Energy | 1d? | 2008-04-01 | 2008-04-01 | 823d |
| 744 | 1.4.3.5.3 | Astrometric | 1d? | 2008-04-01 | 2008-04-01 | 823d |
| 745 | 1.4.3.5.4 | Photometric | 1d? | 2008-04-01 | 2008-04-01 | 823d |
| 746 | 1.4.3.5.5 | Companion Sensitivity | 1d? | 2008-04-01 | 2008-04-01 | 823d |
| 747 | 1.4.3.5.6 | Polarimetry | 1d? | 2008-04-01 | 2008-04-01 | 823d |
| 748 | 1.4.3.5.7 | Observing Efficiency | 1d? | 2008-04-01 | 2008-04-01 | 823d |
| 749 | 1.4.3.5.8 | Observing Uptime | 1d? | 2008-04-01 | 2008-04-01 | 823d |
| 750 | 1.4.3.6 | **External Interface Control** | 1d? | 2008-04-01 | 2008-04-01 | 823d |
| 751 | 1.4.3.6.1 | **Observatory Interfaces** | 1d? | 2008-04-01 | 2008-04-01 | 823d |
| 752 | 1.4.3.6.1.1 | AO System | 1d? | 2008-04-01 | 2008-04-01 | 823d |
| 753 | 1.4.3.6.1.2 | Laser System | 1d? | 2008-04-01 | 2008-04-01 | 823d |
| 754 | 1.4.3.6.2 | Science Instrument Requirements Input & Review | 1d? | 2008-04-01 | 2008-04-01 | 823d |

| ID | WBS | Task | Duration | Start | Finish | Total slack | Work |
| --- | --- | --- | --- | --- | --- | --- | --- |
| 755 | 1.4.3.6.3 | **Science Instrument Interfaces** | 1d? | 2008-04-01 | 2008-04-01 | 823d |  |
| 756 | 1.4.3.6.3.1 | Generic Science Instrument ICD | 1d? | 2008-04-01 | 2008-04-01 | 823d |  |
| 757 | 1.4.3.6.3.2 | Interferometer & OHANA ICD | 1d? | 2008-04-01 | 2008-04-01 | 823d |  |
| 758 | 1.4.3.6.3.3 | OSIRIS ICD | 1d? | 2008-04-01 | 2008-04-01 | 823d |  |
| 759 | 1.4.3.6.3.4 | NIR Camera ICD | 1d? | 2008-04-01 | 2008-04-01 | 823d |  |
| 760 | 1.4.3.6.3.5 | Visible Camera ICD | 1d? | 2008-04-01 | 2008-04-01 | 823d |  |
| 761 | 1.4.3.6.3.6 | Deployabe IFS ICD | 1d? | 2008-04-01 | 2008-04-01 | 823d |  |
| 762 | 1.4.3.7 | Internal Interface Control | 1d? | 2008-04-01 | 2008-04-01 | 823d |  |
| 763 | 1.4.3.8 | Configuration Control | 1d? | 2008-04-01 | 2008-04-01 | 823d |  |
| 764 | 1.4.3.9 | Documentation Control | 1d? | 2008-04-01 | 2008-04-01 | 823d |  |
| 765 | 1.4.3.10 | **Technical Risk Assessment & Mitigation** | 1d? | 2008-04-01 | 2008-04-01 | 823d |  |
| 766 | 1.4.3.10.1 | Risk Assessment | 1d? | 2008-04-01 | 2008-04-01 | 823d |  |
| 767 | 1.4.3.10.2 | Risk Mitigation Efforts | 1d? | 2008-04-01 | 2008-04-01 | 823d |  |
| 768 | 1.4.3.11 | Detailed Design Manual | 1d? | 2008-04-01 | 2008-04-01 | 823d |  |
| 769 | 1.4.4 | **AO System Design** | 1d? | 2008-04-01 | 2008-04-01 | 823d | 200h |
| 770 | 1.4.4.1 | AO Enclosure | 1d? | 2008-04-01 | 2008-04-01 | 823d |  |
| 771 | 1.4.4.2 | **Opto-Mechanical** | 1d? | 2008-04-01 | 2008-04-01 | 823d |  |
| 772 | 1.4.4.2.1 | **AO Support Structure** | 1d? | 2008-04-01 | 2008-04-01 | 823d |  |
| 773 | 1.4.4.2.1.1 | Optics Bench | 1d? | 2008-04-01 | 2008-04-01 | 823d |  |
| 774 | 1.4.4.2.1.2 | Interface to Nasmyth Platform | 1d? | 2008-04-01 | 2008-04-01 | 823d |  |
| 775 | 1.4.4.2.1.3 | Level 2 Support | 1d? | 2008-04-01 | 2008-04-01 | 823d |  |
| 776 | 1.4.4.2.2 | Rotator | 1d? | 2008-04-01 | 2008-04-01 | 823d |  |
| 777 | 1.4.4.2.3 | **Optical Relays** | 1d? | 2008-04-01 | 2008-04-01 | 823d |  |
| 778 | 1.4.4.2.3.1 | Entrance Window & Mount | 1d? | 2008-04-01 | 2008-04-01 | 823d |  |
| 779 | 1.4.4.2.3.2 | OAP1 & Mount | 1d? | 2008-04-01 | 2008-04-01 | 823d |  |
| 780 | 1.4.4.2.3.3 | Fold Mirror & Mount | 1d? | 2008-04-01 | 2008-04-01 | 823d |  |
| 781 | 1.4.4.2.3.4 | Woofer DM Mount | 1d? | 2008-04-01 | 2008-04-01 | 823d |  |
| 782 | 1.4.4.2.3.5 | OAP2 & Mount | 1d? | 2008-04-01 | 2008-04-01 | 823d |  |
| 783 | 1.4.4.2.3.6 | OAP3 & Mount | 1d? | 2008-04-01 | 2008-04-01 | 823d |  |
| 784 | 1.4.4.2.3.7 | Tweeter DM Mount | 1d? | 2008-04-01 | 2008-04-01 | 823d |  |
| 785 | 1.4.4.2.3.8 | OAP4 & Mount | 1d? | 2008-04-01 | 2008-04-01 | 823d |  |
| 786 | 1.4.4.2.4 | Optical Switchyard | 1d? | 2008-04-01 | 2008-04-01 | 823d |  |
| 787 | 1.4.4.2.5 | LGS Wavefront Sensor Assembly | 1d? | 2008-04-01 | 2008-04-01 | 823d |  |
| 788 | 1.4.4.2.6 | NGS WFS/TWFS Assembly | 1d? | 2008-04-01 | 2008-04-01 | 823d |  |
| 789 | 1.4.4.2.7 | Low Order Wavefront Sensor Assembly | 1d? | 2008-04-01 | 2008-04-01 | 823d |  |
| 790 | 1.4.4.2.8 | Tip/Tilt Vibration Mitigation | 1d? | 2008-04-01 | 2008-04-01 | 823d |  |

| ID | WBS | Task | Duration | Start | Finish | Total slack |
| --- | --- | --- | --- | --- | --- | --- |
| 791 | 1.4.4.2.9 | **Acquisition Cameras** | 1d? | 2008-04-01 | 2008-04-01 | 823d |
| 792 | 1.4.4.2.9.1 | NGS Acquisition Camera | 1d? | 2008-04-01 | 2008-04-01 | 823d |
| 793 | 1.4.4.2.9.2 | LGS Acquisition Camera | 1d? | 2008-04-01 | 2008-04-01 | 823d |
| 794 | 1.4.4.2.10 | **Atmospheric Dispersion Correctors** | 1d? | 2008-04-01 | 2008-04-01 | 823d |
| 795 | 1.4.4.2.10.1 | LOWFS ADCs | 1d? | 2008-04-01 | 2008-04-01 | 823d |
| 796 | 1.4.4.2.10.2 | NIR Science ADC | 1d? | 2008-04-01 | 2008-04-01 | 823d |
| 797 | 1.4.4.2.10.3 | Visible Science ADC | 1d? | 2008-04-01 | 2008-04-01 | 823d |
| 798 | 1.4.4.2.10.4 | NGS Wavefront Sensor ADC | 1d? | 2008-04-01 | 2008-04-01 | 823d |
| 799 | 1.4.4.3 | **Alignment, Calibration & Diagnostics** | 1d? | 2008-04-01 | 2008-04-01 | 823d |
| 800 | 1.4.4.3.1 | Simulator | 1d? | 2008-04-01 | 2008-04-01 | 823d |
| 801 | 1.4.4.3.2 | System Alignment Tools | 1d? | 2008-04-01 | 2008-04-01 | 823d |
| 802 | 1.4.4.3.3 | Atmospheric Profiler | 1d? | 2008-04-01 | 2008-04-01 | 823d |
| 803 | 1.4.4.3.4 | PSF Monitoring Camera | 1d? | 2008-04-01 | 2008-04-01 | 823d |
| 804 | 1.4.4.4 | **Non-real-time Control** | 1d? | 2008-04-01 | 2008-04-01 | 823d |
| 805 | 1.4.4.4.1 | **Non-RTC Software** | 1d? | 2008-04-01 | 2008-04-01 | 823d |
| 806 | 1.4.4.4.1.1 | **AO System Sequencer** | 1d? | 2008-04-01 | 2008-04-01 | 823d |
| 807 | 1.4.4.4.1.1.1 | Coordination Sequence | 1d? | 2008-04-01 | 2008-04-01 | 823d |
| 808 | 1.4.4.4.1.1.2 | Command Interface | 1d? | 2008-04-01 | 2008-04-01 | 823d |
| 809 | 1.4.4.4.1.1.3 | Data Interface | 1d? | 2008-04-01 | 2008-04-01 | 823d |
| 810 | 1.4.4.4.1.1.4 | Health Monitor | 1d? | 2008-04-01 | 2008-04-01 | 823d |
| 811 | 1.4.4.4.1.2 | **Low Level AO Control** | 1d? | 2008-04-01 | 2008-04-01 | 823d |
| 812 | 1.4.4.4.1.2.1 | **Motion Control** | 1d? | 2008-04-01 | 2008-04-01 | 823d |
| 813 | 1.4.4.4.1.2.1.1 | High-level Motion Control | 1d? | 2008-04-01 | 2008-04-01 | 823d |
| 814 | 1.4.4.4.1.2.1.2 | Low-Level Motion Control | 1d? | 2008-04-01 | 2008-04-01 | 823d |
| 815 | 1.4.4.4.1.2.2 | Camera Control | 1d? | 2008-04-01 | 2008-04-01 | 823d |
| 816 | 1.4.4.4.1.2.3 | DM & TT Mirror Control | 1d? | 2008-04-01 | 2008-04-01 | 823d |
| 817 | 1.4.4.4.1.2.4 | RTC Control | 1d? | 2008-04-01 | 2008-04-01 | 823d |
| 818 | 1.4.4.4.1.2.5 | Environmental Control | 1d? | 2008-04-01 | 2008-04-01 | 823d |

| ID | WBS | Task | Duration | Start | Finish | Total slack | Work |
| --- | --- | --- | --- | --- | --- | --- | --- |
| 819 | 1.4.4.4.2 | **Non-RTC Hardware** | 1d? | 2008-04-01 | 2008-04-01 | 823d |  |
| 820 | 1.4.4.4.2.1 | Motion Control Electronics | 1d? | 2008-04-01 | 2008-04-01 | 823d |  |
| 821 | 1.4.4.4.2.2 | Power Distribution & Control | 1d? | 2008-04-01 | 2008-04-01 | 823d |  |
| 822 | 1.4.4.4.2.3 | Other Electronics | 1d? | 2008-04-01 | 2008-04-01 | 823d |  |
| 823 | 1.4.4.5 | Real-time Control | 1d? | 2008-04-01 | 2008-04-01 | 823d |  |
| 824 | 1.4.4.6 | **AO System Lab I&T** | 1d? | 2008-04-01 | 2008-04-01 | 823d | 200h |
| 825 | 1.4.4.6.1 | AO System Lab Facility Plan | 1d? | 2008-04-01 | 2008-04-01 | 823d | 120h |
| 826 | 1.4.4.6.2 | AO System Lab Integration Plan | 1d? | 2008-04-01 | 2008-04-01 | 823d | 40h |
| 827 | 1.4.4.6.3 | AO System Lab Test Plan | 1d? | 2008-04-01 | 2008-04-01 | 823d | 40h |
| 828 | 1.4.5 | **Laser System Design** | 1d? | 2008-04-01 | 2008-04-01 | 823d |  |
| 829 | 1.4.5.1 | Laser Enclosure | 1d? | 2008-04-01 | 2008-04-01 | 823d |  |
| 830 | 1.4.5.2 | Laser | 1d? | 2008-04-01 | 2008-04-01 | 823d |  |
| 831 | 1.4.5.3 | **Laser Launch Facility** | 1d? | 2008-04-01 | 2008-04-01 | 823d |  |
| 832 | 1.4.5.3.1 | Beam Transport | 1d? | 2008-04-01 | 2008-04-01 | 823d |  |
| 833 | 1.4.5.3.2 | Laser Pointing & Diagnostics | 1d? | 2008-04-01 | 2008-04-01 | 823d |  |
| 834 | 1.4.5.3.3 | Launch Telescope | 1d? | 2008-04-01 | 2008-04-01 | 823d |  |
| 835 | 1.4.5.4 | Laser Safety Systems | 1d? | 2008-04-01 | 2008-04-01 | 823d |  |
| 836 | 1.4.5.5 | Laser System Control | 1d? | 2008-04-01 | 2008-04-01 | 823d |  |
| 837 | 1.4.5.6 | Laser System Lab I&T | 1d? | 2008-04-01 | 2008-04-01 | 823d |  |
| 838 | 1.4.6 | **Science Operations Tools Design** | 1d? | 2008-04-01 | 2008-04-01 | 823d |  |
| 839 | 1.4.6.1 | **Multi-Systems Command Sequencer** | 1d? | 2008-04-01 | 2008-04-01 | 823d |  |
| 840 | 1.4.6.1.1 | Sequencer Infrastructure | 1d? | 2008-04-01 | 2008-04-01 | 823d |  |
| 841 | 1.4.6.1.2 | Setup Sequences: Configurations & Calibrations | 1d? | 2008-04-01 | 2008-04-01 | 823d |  |
| 842 | 1.4.6.1.3 | **Observing Sequences** | 1d? | 2008-04-01 | 2008-04-01 | 823d |  |
| 843 | 1.4.6.1.3.1 | Acquisition | 1d? | 2008-04-01 | 2008-04-01 | 823d |  |
| 844 | 1.4.6.1.3.2 | Observing Sequences | 1d? | 2008-04-01 | 2008-04-01 | 823d |  |
| 845 | 1.4.6.1.3.3 | Performance Monitoring & Optimization | 1d? | 2008-04-01 | 2008-04-01 | 823d |  |
| 846 | 1.4.6.1.4 | Data Logging & Troubleshooting | 1d? | 2008-04-01 | 2008-04-01 | 823d |  |

| ID | WBS | Task | Duration | Start | Finish | Total slack | Work |
| --- | --- | --- | --- | --- | --- | --- | --- |
| 847 | 1.4.6.2 | **User Interfaces** | 1d? | 2008-04-01 | 2008-04-01 | 823d |  |
| 848 | 1.4.6.2.1 | User Interface Infrastructure | 1d? | 2008-04-01 | 2008-04-01 | 823d |  |
| 849 | 1.4.6.2.2 | Setup User Interfaces | 1d? | 2008-04-01 | 2008-04-01 | 823d |  |
| 850 | 1.4.6.2.3 | Observation User Interfaces | 1d? | 2008-04-01 | 2008-04-01 | 823d |  |
| 851 | 1.4.6.3 | **Pre- & Post-Observing Science Support Tools** | 1d? | 2008-04-01 | 2008-04-01 | 823d |  |
| 852 | 1.4.6.3.1 | User Documentation | 1d? | 2008-04-01 | 2008-04-01 | 823d |  |
| 853 | 1.4.6.3.2 | **Planning Tools** | 1d? | 2008-04-01 | 2008-04-01 | 823d |  |
| 854 | 1.4.6.3.2.1 | Science Observations Planning Tools | 1d? | 2008-04-01 | 2008-04-01 | 823d |  |
| 855 | 1.4.6.3.2.2 | Laser Clearinghouse Coordination Tool | 1d? | 2008-04-01 | 2008-04-01 | 823d |  |
| 856 | 1.4.6.3.3 | **Data Products** | 1d? | 2008-04-01 | 2008-04-01 | 823d |  |
| 857 | 1.4.6.3.3.1 | Generic Data Products | 1d? | 2008-04-01 | 2008-04-01 | 823d |  |
| 858 | 1.4.6.3.3.2 | Science Data Quality Assessment | 1d? | 2008-04-01 | 2008-04-01 | 823d |  |
| 859 | 1.4.6.3.3.3 | Science Data Archiving | 1d? | 2008-04-01 | 2008-04-01 | 823d |  |
| 860 | 1.4.6.4 | Data Server | 1d? | 2008-04-01 | 2008-04-01 | 823d |  |
| 861 | 1.4.7 | **Telescope & Summit Engineering Design** | 1d? | 2008-04-01 | 2008-04-01 | 823d | 240h |
| 862 | 1.4.7.1 | Telescope Performance | 1d? | 2008-04-01 | 2008-04-01 | 823d | 240h |
| 863 | 1.4.7.2 | Infrastructure Modifications for AO | 1d? | 2008-04-01 | 2008-04-01 | 823d |  |
| 864 | 1.4.7.3 | Infrastructure modifications for Laser System | 1d? | 2008-04-01 | 2008-04-01 | 823d |  |
| 865 | 1.4.7.4 | OSIRIS Modifications | 1d? | 2008-04-01 | 2008-04-01 | 823d |  |
| 866 | 1.4.7.5 | Interferometer & OHANA Modifications | 1d? | 2008-04-01 | 2008-04-01 | 823d |  |
| 867 | 1.4.8 | **Telescope Integration & Test** | 1d? | 2008-04-01 | 2008-04-01 | 823d | 690h |
| 868 | 1.4.8.1 | **Old AO/Laser Removal** | 1d? | 2008-04-01 | 2008-04-01 | 823d | 480h |
| 869 | 1.4.8.1.1 | AO Removal Plan | 1d? | 2008-04-01 | 2008-04-01 | 823d | 240h |
| 870 | 1.4.8.1.2 | Laser Removal Plan | 1d? | 2008-04-01 | 2008-04-01 | 823d | 240h |
| 871 | 1.4.8.2 | Laser Enclosure Integration | 1d? | 2008-04-01 | 2008-04-01 | 823d |  |
| 872 | 1.4.8.3 | AO Enclosure Integration | 1d? | 2008-04-01 | 2008-04-01 | 823d |  |

| ID | WBS | Task | Duration | Start | Finish | Total slack | Work |
| --- | --- | --- | --- | --- | --- | --- | --- |
| 873 | 1.4.8.4 | **AO System Install + I&T** | 1d? | 2008-04-01 | 2008-04-01 | 823d | 210h |
| 874 | 1.4.8.4.1 | AO System Install | 1d? | 2008-04-01 | 2008-04-01 | 823d | 160h |
| 875 | 1.4.8.4.2 | AO System Integration | 1d? | 2008-04-01 | 2008-04-01 | 823d | 40h |
| 876 | 1.4.8.4.3 | AO System Test | 1d? | 2008-04-01 | 2008-04-01 | 823d | 10h |
| 877 | 1.4.8.5 | Laser System Install + I&T | 1d? | 2008-04-01 | 2008-04-01 | 823d |  |
| 878 | 1.4.8.6 | LGS AO System On-sky I&T | 1d? | 2008-04-01 | 2008-04-01 | 823d |  |
| 879 | 1.4.8.7 | Performance Characterization | 1d? | 2008-04-01 | 2008-04-01 | 823d |  |
| 880 | 1.4.8.8 | Science Verification | 1d? | 2008-04-01 | 2008-04-01 | 823d |  |
| 881 | 1.4.9 | **Operations Transition** | 1d? | 2008-04-01 | 2008-04-01 | 823d |  |
| 882 | 1.4.9.1 | Operations Plans | 1d? | 2008-04-01 | 2008-04-01 | 823d |  |
| 883 | 1.4.9.2 | Operations Handover | 1d? | 2008-04-01 | 2008-04-01 | 823d |  |
