# NGAO Design v5

Schedule from MS Project, 2005-10-03 to 2010-03-22, costs in $.
CARA

## Calendars

- Standard: Mon-Fri 08:00-12:00, 13:00-17:00; Sat-Sun off.

## Resources

| Resource | Rate |
| --- | --- |
| Dekany |  |
| Gavel | 75 |
| Max |  |
| Wizinowich | 75 |
| Other | 75 |
| Adkins | 75 |
| McGrath | 75 |
| Tyau | 75 |
| Le Mignant | 75 |
| Bell | 75 |
| Chin | 75 |
| Kupke | 75 |
| Lockwood | 75 |
| Neyman | 75 |
| Reinig | 75 |
| Velur | 75 |
| Free | 75 |
| Student | 75 |
| Scientist | 75 |
| Johansson | 75 |
| Wetherell | 75 |
| Medeiros | 75 |
| Nance | 75 |
| Summers | 75 |
| Tech | 75 |
| Bouchez | 75 |
| Kissner | 75 |
| Chock | 75 |
| Panteleev |  |

## Schedule

| ID | WBS | Task | Duration | Start | Finish | Total slack | Constraint | Resources | Work | Cost |
| --- | --- | --- | --- | --- | --- | --- | --- | --- | --- | --- |
| 1 | 1 | **NGAO Design** | 1166d? | 2005-10-03 | 2010-03-22 | 0d |  |  | 36146h | 2,589,825 |
| 2 | 1.1 | Proposal | 195d? | 2005-10-03 | 2006-06-30 | 971d | finish no earlier than 2006-06-30 |  |  |  |
| 3 | 1.2 | System Design | 413d? | 2006-10-02 | 2008-04-30 | 493d | finish no earlier than 2008-04-30 |  |  |  |
| 4 | 1.3 | **Preliminary Design** | 515d? | 2008-04-01 | 2010-03-22 | 0d |  |  | 36146h | 2,589,825 |
| 5 | 1.3.1 | Reserved | 1d? | 2008-05-01 | 2008-05-01 | 492d | start no earlier than 2008-05-01 |  |  |  |
| 6 | 1.3.2 | **PD Phase Management** | 515d? | 2008-04-01 | 2010-03-22 | 0d |  |  | 9933h | 713,250 |
| 7 | 1.3.2.1 | **Planning** | 456d? | 2008-05-02 | 2010-01-29 | 36d |  |  | 1650h | 120,450 |
| 8 | 1.3.2.1.1 | **Replans (PD phase)** | 286d? | 2008-05-02 | 2009-06-05 | 206d |  |  | 190h | 14,250 |
| 9 | 1.3.2.1.1.1 | Replan based on SDR | 6d? | 2008-05-02 | 2008-05-09 | 486d | finish no earlier than 2008-05-09 | Dekany [12.5%]; Gavel [12.5%]; Wizinowich [25%]; Other [12.5%] | 30h | 2,250 |
| 10 | 1.3.2.1.1.2 | Replan 1 | 10d? | 2008-10-27 | 2008-11-07 | 356d | finish no earlier than 2008-11-07 | Dekany [20%]; Gavel [20%]; Wizinowich [45%]; Other [15%] | 80h | 6,000 |
| 11 | 1.3.2.1.1.3 | Replan 2 | 10d? | 2009-05-25 | 2009-06-05 | 206d | finish no earlier than 2009-06-05 | Dekany [20%]; Gavel [20%]; Wizinowich [40%]; Other [20%] | 80h | 6,000 |
| 12 | 1.3.2.1.2 | **WMKO FY Plans** | 280d? | 2008-05-05 | 2009-05-29 | 211d |  |  | 40h | 3,000 |
| 13 | 1.3.2.1.2.1 | Support WMKO FY09 Planning | 20d? | 2008-05-05 | 2008-05-30 | 471d | start no earlier than 2008-05-05 | Wizinowich [6.2%] | 10h | 750 |
| 14 | 1.3.2.1.2.2 | Support WMKO FY10 Planning | 85d? | 2009-02-02 | 2009-05-29 | 211d | start no earlier than 2009-02-02 | Wizinowich [4.4%] | 30h | 2,250 |
| 15 | 1.3.2.1.3 | **Systems Engineering Management Plan** | 218d? | 2009-04-01 | 2010-01-29 | 36d |  |  | 1420h | 103,200 |
| 16 | 1.3.2.1.3.1 | **Project Plan** | 50d? | 2009-11-02 | 2010-01-08 | 51d |  |  | 1020h | 74,250 |
| 17 | 1.3.2.1.3.1.1 | PBS, WBS & Task Definition | 15d? | 2009-11-02 | 2009-11-20 | 86d | start no earlier than 2009-11-02 | Dekany [33.3%]; Gavel [33.3%]; Wizinowich [33.3%]; Max [8.3%]; Other [108.3%] | 260h | 18,750 |
| 18 | 1.3.2.1.3.1.2 | Cost Estimation | 20d? | 2009-11-23 | 2009-12-18 | 66d | start no earlier than 2009-11-23 | Dekany [50%]; Gavel [37.5%]; Max [6.2%]; Wizinowich [37.5%]; Other [168.8%] | 480h | 35,250 |
| 19 | 1.3.2.1.3.1.3 | Full Schedule (MS Project Plan) | 25d? | 2009-12-07 | 2010-01-08 | 51d | start no earlier than 2009-12-07 | Wizinowich [30%]; Dekany [15%]; Gavel [15%]; Max [5%]; Other [75%] | 280h | 20,250 |
| 20 | 1.3.2.1.3.2 | **Detailed Design Phase Plan** | 177d? | 2009-04-01 | 2009-12-03 | 77d |  |  | 320h | 23,250 |
| 21 | 1.3.2.1.3.2.1 | Detailed Design Plan v1 (FY10 planning) | 33d? | 2009-04-01 | 2009-05-15 | 221d | finish no earlier than 2009-05-15 | Wizinowich [15.2%] | 40h | 3,000 |
| 22 | 1.3.2.1.3.2.2 | Detailed Design Plan v2 (TSIP proposal) | 18d? | 2009-07-15 | 2009-08-07 | 161d | start no earlier than 2009-07-15 | Wizinowich [22.2%]; Dekany [27.8%]; Gavel [27.8%] | 40h | 3,000 |
| 23 | 1.3.2.1.3.2.3 | Detailed Design Plan Final Version | 19d? | 2009-11-09 | 2009-12-03 | 77d | start no earlier than 2009-11-09 | Wizinowich [46.1%]; Dekany [19.7%]; Gavel [19.7%]; Max [6.6%]; Other [65.8%] | 240h | 17,250 |
| 24 | 1.3.2.1.3.3 | SEMP Document | 15d? | 2010-01-11 | 2010-01-29 | 36d | start no earlier than 2010-01-11 | Wizinowich [30%]; Dekany [66.7%]; Gavel [66.7%]; Max [66.7%] | 80h | 5,700 |

Notes:
- 6: PW
- 7: PW
- 15: PW
- 17: PW
- 18: RD
- 19: PW
- 20: PW
- 21: PW
- 22: PW
- 23: PW
- 24: PW

| ID | WBS | Task | Duration | Start | Finish | Total slack | Constraint | Resources | Work | Cost |
| --- | --- | --- | --- | --- | --- | --- | --- | --- | --- | --- |
| 25 | 1.3.2.2 | **Project Management & Meetings** | 478d? | 2008-04-30 | 2010-02-26 | 16d |  |  | 2500h | 178,800 |
| 26 | 1.3.2.2.1 | **Executive Committee** | 477d? | 2008-05-01 | 2010-02-26 | 16d |  |  | 600h | 37,500 |
| 27 | 1.3.2.2.1.1 | Executive Committee Management Activities | 477d? | 2008-05-01 | 2010-02-26 | 16d | finish no earlier than 2010-02-26 | Dekany; Gavel; Max; Wizinowich [3.3%] | 300h | 20,625 |
| 28 | 1.3.2.2.1.2 | Executive Committee Telecons | 477d? | 2008-05-01 | 2010-02-26 | 16d | finish no earlier than 2010-02-26 | Dekany [2%]; Gavel [2%]; Max [2%]; Wizinowich [2%] | 300h | 16,875 |
| 29 | 1.3.2.2.2 | **Team Meetings** | 447.13d? | 2008-04-30 | 2010-01-15 | 46.87d |  |  | 1900h | 141,300 |
| 30 | 1.3.2.2.2.1 | Team Meeting #1 (CIT) | 2d? | 2008-04-30 | 2008-05-01 | 492d | start no earlier than 2008-04-30 | Dekany; Gavel; Max; Wizinowich; Other | 80h | 4,800 |
| 31 | 1.3.2.2.2.2 | Team Meeting #2 (telecon) | 1d? | 2008-06-13 | 2008-06-13 | 461d | start no earlier than 2008-06-13 | Other [750%] | 60h | 4,500 |
| 32 | 1.3.2.2.2.3 | Team Meeting #3 (telecon) | 1d? | 2008-07-11 | 2008-07-11 | 441d | start no earlier than 2008-07-11 | Other [750%] | 60h | 4,500 |
| 33 | 1.3.2.2.2.4 | Team Meeting #4 (telecon) | 1d? | 2008-08-15 | 2008-08-15 | 416d | start no earlier than 2008-08-15 | Other [750%] | 60h | 4,500 |
| 34 | 1.3.2.2.2.5 | Team Meeting #5 (UC) | 3d? | 2008-09-16 | 2008-09-18 | 392d | finish no earlier than 2008-09-18 | Other [1000%] | 240h | 18,000 |
| 35 | 1.3.2.2.2.6 | Team Meeting #6 (telecon) | 1d? | 2008-10-17 | 2008-10-17 | 371d | start no earlier than 2008-10-17 | Other [750%] | 60h | 4,500 |
| 36 | 1.3.2.2.2.7 | Team Meeting #7 (telecon) | 1d? | 2008-11-14 | 2008-11-14 | 351d | start no earlier than 2008-11-14 | Other [750%] | 60h | 4,500 |
| 37 | 1.3.2.2.2.8 | Team Meeting #8 (telecon) | 1d? | 2008-12-12 | 2008-12-12 | 331d | start no earlier than 2008-12-12 | Other [750%] | 60h | 4,500 |
| 38 | 1.3.2.2.2.9 | Team Meeting #9 (telecon) | 1d? | 2009-01-16 | 2009-01-16 | 306d | finish no earlier than 2009-01-16 | Other [750%] | 60h | 4,500 |
| 39 | 1.3.2.2.2.10 | Team Meeting #10 (WMKO) | 1d? | 2009-02-10 | 2009-02-10 | 289d | start no earlier than 2009-02-10 | Other [4000%] | 320h | 24,000 |
| 40 | 1.3.2.2.2.11 | Team Meeting #11 (telecon) | 1d? | 2009-03-13 | 2009-03-13 | 266d | start no earlier than 2009-03-13 | Other [750%] | 60h | 4,500 |
| 41 | 1.3.2.2.2.12 | Team Meeting #12 (telecon) | 1d? | 2009-04-17 | 2009-04-17 | 241d | start no earlier than 2009-04-17 | Other [750%] | 60h | 4,500 |
| 42 | 1.3.2.2.2.13 | Team Meeting #13 (telecon) | 1d? | 2009-05-15 | 2009-05-15 | 221d | finish no earlier than 2009-05-15 | Other [750%] | 60h | 4,500 |
| 43 | 1.3.2.2.2.14 | Team Meeting #14 (telecon) | 1d? | 2009-06-12 | 2009-06-12 | 201d | finish no earlier than 2009-06-12 | Other [750%] | 60h | 4,500 |
| 44 | 1.3.2.2.2.15 | Team Meeting #15 (telecon) | 1d? | 2009-07-17 | 2009-07-17 | 176d | start no earlier than 2009-07-17 | Other [750%] | 60h | 4,500 |
| 45 | 1.3.2.2.2.16 | Team Meeting #16 (CIT) | 0.4d? | 2009-08-20 | 2009-08-20 | 152d | finish no earlier than 2009-08-20 | Other [7500%] | 240h | 18,000 |
| 46 | 1.3.2.2.2.17 | Team Meeting #17 (telecon) | 0.13d? | 2009-09-18 | 2009-09-18 | 131.87d | start no earlier than 2009-09-18 | Other [5625%] | 60h | 4,500 |
| 47 | 1.3.2.2.2.18 | Team Meeting #18 (telecon) | 0.13d? | 2009-10-16 | 2009-10-16 | 111.87d | start no earlier than 2009-10-16 | Other [5625%] | 60h | 4,500 |
| 48 | 1.3.2.2.2.19 | Team Meeting #19 (telecon) | 0.13d? | 2009-11-13 | 2009-11-13 | 91.87d | start no earlier than 2009-11-13 | Other [5625%] | 60h | 4,500 |
| 49 | 1.3.2.2.2.20 | Team Meeting #20 (telecon) | 0.13d? | 2009-12-11 | 2009-12-11 | 71.87d | start no earlier than 2009-12-11 | Other [5625%] | 60h | 4,500 |
| 50 | 1.3.2.2.2.21 | Team Meeting #21 (telecon) | 0.13d? | 2010-01-15 | 2010-01-15 | 46.87d | start no earlier than 2010-01-15 | Other [5625%] | 60h | 4,500 |

Notes:
- 25: PW
- 26: PW
- 29: PW

| ID | WBS | Task | Type | Duration | Start | Finish | Total slack | Constraint | Resources | Work | Cost |
| --- | --- | --- | --- | --- | --- | --- | --- | --- | --- | --- | --- |
| 51 | 1.3.2.2.3 | **Director Telecons** |  | 390d | 2008-05-09 | 2009-11-06 | 97d |  |  |  |  |
| 52 | 1.3.2.2.3.1 | Director Telecon #1 | milestone | 0d | 2008-05-09 | 2008-05-09 | 487d | start no earlier than 2008-05-09 |  |  |  |
| 53 | 1.3.2.2.3.2 | Director Telecon #2 | milestone | 0d | 2008-11-07 | 2008-11-07 | 357d | start no earlier than 2008-11-07 |  |  |  |
| 54 | 1.3.2.2.3.3 | Director Telecon #3 | milestone | 0d | 2009-05-08 | 2009-05-08 | 227d | start no earlier than 2009-05-08 |  |  |  |
| 55 | 1.3.2.2.3.4 | Director Telecon #4 | milestone | 0d | 2009-11-06 | 2009-11-06 | 97d | start no earlier than 2009-11-06 |  |  |  |
| 56 | 1.3.2.3 | **Tracking & Reporting** |  | 478d? | 2008-04-30 | 2010-02-26 | 16d |  |  | 1012h | 62,175 |
| 57 | 1.3.2.3.1 | **Monthly Status Reports** |  | 477d? | 2008-05-01 | 2010-02-26 | 16d |  |  | 566h | 37,950 |
| 58 | 1.3.2.3.1.1 | Monthly Team Status Reports |  | 477d? | 2008-05-01 | 2010-02-26 | 16d | start no earlier than 2008-05-01 | Other [5.2%]; Wizinowich [1%]; Max [1%]; Gavel [1%]; Dekany [1%] | 360h | 24,000 |
| 59 | 1.3.2.3.1.2 | Monthly Project Reports (TSIP, Directors) |  | 467d? | 2008-05-15 | 2010-02-26 | 16d | start no earlier than 2008-05-15 | Wizinowich [2.4%]; Dekany [0.5%]; Gavel [0.5%]; Adkins [0.5%]; Max [0.5%] | 170h | 11,250 |
| 60 | 1.3.2.3.1.3 | TSIP Project Report Telecons |  | 464d? | 2008-05-20 | 2010-02-26 | 16d | start no earlier than 2008-05-20 | Adkins [0.5%]; Wizinowich [0.5%] | 36h | 2,700 |
| 61 | 1.3.2.3.2 | **SSC Meetings** |  | 459.88d? | 2008-04-30 | 2010-02-02 | 34.12d |  |  | 126h | 6,825 |
| 62 | 1.3.2.3.2.1 | SSC Meeting (CIT) - SDR report | milestone | 0d | 2008-04-30 | 2008-04-30 | 494d | start no earlier than 2008-04-30 |  |  |  |
| 63 | 1.3.2.3.2.2 | SSC Meeting (Keck) |  | 1.12d | 2008-06-18 | 2008-06-19 | 457.88d | start no earlier than 2008-06-18 | Dekany; Gavel; Max; Wizinowich | 18h | 975 |
| 64 | 1.3.2.3.2.3 | SSC Meeting (UCSC) |  | 1.12d | 2008-11-03 | 2008-11-04 | 359.88d | start no earlier than 2008-11-03 | Dekany; Gavel; Max; Wizinowich | 18h | 975 |
| 65 | 1.3.2.3.2.4 | SSC Meeting (Keck) |  | 1.12d | 2009-02-19 | 2009-02-20 | 281.88d | start no earlier than 2009-02-19 | Dekany; Gavel; Max; Wizinowich | 18h | 975 |
| 66 | 1.3.2.3.2.5 | SSC Meeting (CIT) |  | 1.12d | 2009-04-29 | 2009-04-30 | 232.88d | start no earlier than 2009-04-29 | Dekany; Gavel; Max; Wizinowich | 18h | 975 |
| 67 | 1.3.2.3.2.6 | SSC Meeting (Keck) |  | 1.12d | 2009-06-17 | 2009-06-18 | 197.88d | start no earlier than 2009-06-17 | Dekany; Gavel; Max; Wizinowich | 18h | 975 |
| 68 | 1.3.2.3.2.7 | SSC Meeting (UCSC) |  | 1.12d | 2009-11-03 | 2009-11-04 | 98.88d | start no earlier than 2009-11-03 | Dekany; Gavel; Max; Wizinowich | 18h | 975 |
| 69 | 1.3.2.3.2.8 | SSC Meeting (Keck) |  | 1.88d? | 2010-02-01 | 2010-02-02 | 34.12d | start no earlier than 2010-02-01 | Dekany [50%]; Gavel [50%]; Max [40%]; Wizinowich [60%] | 18h | 975 |
| 70 | 1.3.2.3.3 | **Other Presentations** |  | 350d? | 2008-06-02 | 2009-10-02 | 121d |  |  | 320h | 17,400 |
| 71 | 1.3.2.3.3.1 | SPIE AO Conference Presentations/Papers |  | 15d? | 2008-06-02 | 2008-06-20 | 456d | start no earlier than 2008-06-02 | Dekany [33.3%]; Gavel [33.3%]; Max [33.3%]; Wizinowich [33.3%] | 160h | 9,000 |
| 72 | 1.3.2.3.3.2 | SPIE AO Conference (Marseille) |  | 5d? | 2008-06-23 | 2008-06-28 | 451d | finish no earlier than 2008-06-28 |  |  |  |
| 73 | 1.3.2.3.3.3 | Keck Science Meeting 08 |  | 3d | 2008-09-18 | 2008-09-22 | 390d | start no earlier than 2008-09-18 | Dekany; Gavel; Max; Wizinowich | 80h | 4,200 |
| 74 | 1.3.2.3.3.4 | Keck Science Meeting 09 |  | 3d | 2009-09-17 | 2009-09-21 | 130d | start no earlier than 2009-09-17 | Dekany; Gavel; Max; Wizinowich | 80h | 4,200 |
| 75 | 1.3.2.3.3.5 | Other |  | 195d? | 2009-01-05 | 2009-10-02 | 121d | finish no earlier than 2009-10-02 |  |  |  |

Notes:
- 56: PW

| ID | WBS | Task | Type | Duration | Start | Finish | Total slack | Constraint | Resources | Work | Cost |
| --- | --- | --- | --- | --- | --- | --- | --- | --- | --- | --- | --- |
| 76 | 1.3.2.4 | **Proposals** |  | 348d? | 2008-06-02 | 2009-09-30 | 123d |  |  | 480h | 34,500 |
| 77 | 1.3.2.4.1 | Advancement Support |  | 348d? | 2008-06-02 | 2009-09-30 | 123d | start no earlier than 2008-06-02 | Free [2.9%] | 80h | 6,000 |
| 78 | 1.3.2.4.2 | TSIP Proposal for DDR |  | 25d? | 2009-07-28 | 2009-08-31 | 145d | finish no earlier than 2009-08-31 | Dekany [10%]; Gavel [10%]; Max [10%]; Free [90%] | 240h | 16,500 |
| 79 | 1.3.2.4.3 | Other Proposal |  | 20d? | 2009-09-03 | 2009-09-30 | 123d | finish no earlier than 2009-09-30 | Free | 160h | 12,000 |
| 80 | 1.3.2.5 | **Programmatic Risk Assessment & Mitigation** |  | 326d? | 2008-04-01 | 2009-06-30 | 189d |  |  | 180h | 13,500 |
| 81 | 1.3.2.5.1 | **Risk Assessment** |  | 326d? | 2008-04-01 | 2009-06-30 | 189d |  |  | 60h | 4,500 |
| 82 | 1.3.2.5.1.1 | Programmatic Risk Assessment v1 |  | 2d? | 2008-04-01 | 2008-04-02 | 513d |  | Wizinowich; Dekany; Gavel; Adkins; Other | 32h | 2,400 |
| 83 | 1.3.2.5.1.2 | Programmatic Risk Assessment v2 |  | 2d? | 2009-06-29 | 2009-06-30 | 189d | finish no earlier than 2009-06-30 | Wizinowich; Dekany; Gavel; Adkins | 28h | 2,100 |
| 84 | 1.3.2.5.2 | **Risk Mitigation** |  | 139.33d? | 2008-04-01 | 2008-10-13 | 375.67d |  |  | 120h | 9,000 |
| 85 | 1.3.2.5.2.1 | Laser Procurement |  | 8.33d? | 2008-10-01 | 2008-10-13 | 375.67d | start no earlier than 2008-10-01 | Wizinowich [60%] | 40h | 3,000 |
| 86 | 1.3.2.5.2.2 | Science Instruments |  | 8.33d? | 2008-04-01 | 2008-04-11 | 506.67d |  | Wizinowich [60%] | 40h | 3,000 |
| 87 | 1.3.2.5.2.3 | Funding |  | 1d? | 2008-04-01 | 2008-04-01 | 514d |  | Wizinowich [500%] | 40h | 3,000 |
| 88 | 1.3.2.6 | **Preliminary Design Review** |  | 406d? | 2008-09-01 | 2010-03-22 | 0d |  |  | 526h | 34,950 |
| 89 | 1.3.2.6.1 | Define Success Criteria for all Reviews |  | 10d? | 2008-09-01 | 2008-09-12 | 396d | finish no earlier than 2008-09-12 | Wizinowich [60%]; Dekany [50%]; Gavel [50%]; Max [40%] | 68h | 4,800 |
| 90 | 1.3.2.6.2 | Review Setup (Date, Participants, Charter) |  | 5d? | 2009-09-07 | 2009-09-11 | 136d | finish no earlier than 2009-09-11 | Wizinowich [20%]; Max [20%]; Other | 16h | 900 |
| 91 | 1.3.2.6.3 | Preliminary Design Report |  | 12d? | 2010-01-11 | 2010-01-26 | 39d | start no earlier than 2010-01-11 | Wizinowich [52.1%]; Dekany [83.3%]; Gavel [83.3%]; Max [83.3%]; Other | 100h | 7,200 |
| 92 | 1.3.2.6.4 | Review Package Distributed |  | 1d? | 2010-01-27 | 2010-01-27 | 38d | start no earlier than 2010-01-27 | Wizinowich [75%] | 6h | 450 |
| 93 | 1.3.2.6.5 | Reviewer Comments Received | milestone | 0d | 2010-02-10 | 2010-02-10 | 29d | start no earlier than 2010-02-10 |  |  |  |
| 94 | 1.3.2.6.6 | Reviewer Comments Addressed |  | 5d? | 2010-02-11 | 2010-02-17 | 23d | start no earlier than 2010-02-11 | Wizinowich [40%]; Dekany [40%]; Gavel [40%]; Max [40%]; Other [60%] | 80h | 4,800 |
| 95 | 1.3.2.6.7 | PDR Presentation Preparation |  | 15d? | 2010-02-01 | 2010-02-19 | 21d | start no earlier than 2010-02-01 | Wizinowich [16.7%]; Dekany [10%]; Gavel [10%]; Max [10%]; Other [20%] | 80h | 5,100 |
| 96 | 1.3.2.6.8 | Preliminary Design Review |  | 0.12d? | 2010-02-22 | 2010-02-22 | 20.88d | start no earlier than 2010-02-22 | Wizinowich [1250%]; Dekany [1250%]; Max [1250%]; Other [8333.3%]; Gavel [1250%] | 128h | 8,700 |
| 97 | 1.3.2.6.9 | Reviewer Report Received | milestone | 0d | 2010-03-15 | 2010-03-15 | 6d | start no earlier than 2010-03-15 |  |  |  |
| 98 | 1.3.2.6.10 | Response to Reviewer Report |  | 5d? | 2010-03-16 | 2010-03-22 | 0d | start no earlier than 2010-03-16 | Wizinowich [40%]; Dekany [20%]; Gavel [20%]; Max [20%]; Other [20%] | 48h | 3,000 |
| 99 | 1.3.2.7 | **Management Support** |  | 499d? | 2008-04-01 | 2010-02-26 | 16d |  |  | 3585h | 268,875 |
| 100 | 1.3.2.7.1 | Administrative/Contract Support |  | 477d? | 2008-05-01 | 2010-02-26 | 16d | start no earlier than 2008-05-01 | Tyau [17.7%]; Other [2.1%]; Wizinowich [10.4%] | 765h | 57,375 |
| 101 | 1.3.2.7.2 | Shared Infrastructure |  | 477d? | 2008-04-01 | 2010-02-26 | 16d |  | Chock [6.6%] | 250h | 18,750 |
| 102 | 1.3.2.7.3 | Research Time |  | 477d? | 2008-05-01 | 2010-02-26 | 16d | start no earlier than 2008-05-01 | McGrath [51.9%]; Le Mignant [15.5%] | 2570h | 192,750 |

Notes:
- 76: PW
- 80: PW
- 81: PW
- 84: PW
- 88: PW
- 99: PW

| ID | WBS | Task | Duration | Start | Finish | Total slack | Constraint | Resources | Work | Cost |
| --- | --- | --- | --- | --- | --- | --- | --- | --- | --- | --- |
| 103 | 1.3.3 | **Systems Engineering** | 428.67d? | 2008-05-01 | 2009-12-22 | 64.33d |  |  | 10516h | 700,500 |
| 104 | 1.3.3.1 | **Science Case Development** | 363d? | 2008-05-01 | 2009-09-21 | 130d |  |  | 4220h | 228,300 |
| 105 | 1.3.3.1.1 | **Science Case Requirements** | 363d? | 2008-05-01 | 2009-09-21 | 130d |  |  | 2822h | 169,500 |
| 106 | 1.3.3.1.1.1 | **Requirements for new Science Drivers** | 72d? | 2008-05-01 | 2008-08-08 | 421d |  |  | 440h | 24,000 |
| 107 | 1.3.3.1.1.1.1 | Astrometry Science in Sparse Fields | 47d? | 2008-05-01 | 2008-07-04 | 446d | start no earlier than 2008-05-01 | McGrath [10.6%]; Student [21.3%]; Max [5.3%] | 140h | 9,000 |
| 108 | 1.3.3.1.1.1.2 | Resolved Stellar Populations in Crowded Fields | 72d? | 2008-05-01 | 2008-08-08 | 421d | start no earlier than 2008-05-01 | Student [20.8%]; Max [6.9%] | 160h | 9,000 |
| 109 | 1.3.3.1.1.1.3 | Debris Disks & Young Stellar Objects | 72d? | 2008-05-01 | 2008-08-08 | 421d | start no earlier than 2008-05-01 | McGrath [6.9%]; Max [6.9%] | 80h | 3,000 |
| 110 | 1.3.3.1.1.1.4 | QSO Host Galaxies | 37d? | 2008-05-01 | 2008-06-20 | 456d | start no earlier than 2008-05-01 | McGrath [13.5%]; Max [6.8%] | 60h | 3,000 |
| 111 | 1.3.3.1.1.2 | **Extend SCRD Discussion of Science Drivers** | 57d? | 2008-05-01 | 2008-07-18 | 436d |  |  | 626h | 37,500 |
| 112 | 1.3.3.1.1.2.1 | Nearby AGNs | 16d? | 2008-05-01 | 2008-05-22 | 477d | start no earlier than 2008-05-01 | McGrath [15.6%]; Max [7.8%] | 30h | 1,500 |
| 113 | 1.3.3.1.1.2.2 | Gravitational Lensing | 32d? | 2008-05-01 | 2008-06-13 | 461d | start no earlier than 2008-05-01 | McGrath [15.6%]; Max [1.6%] | 44h | 3,000 |
| 114 | 1.3.3.1.1.2.3 | Backup Science | 18d? | 2008-05-01 | 2008-05-26 | 475d | start no earlier than 2008-05-01 | McGrath [13.9%]; Max [2.8%]; Le Mignant [13.9%] | 44h | 3,000 |
| 115 | 1.3.3.1.1.2.4 | Ice Giant Planets | 57d? | 2008-05-01 | 2008-07-18 | 436d | start no earlier than 2008-05-01 | McGrath [2.2%] | 10h | 750 |
| 116 | 1.3.3.1.1.2.5 | GR at Galactic Center | 52d? | 2008-05-01 | 2008-07-11 | 441d | start no earlier than 2008-05-01 | Student [19.2%]; Max [9.6%] | 120h | 6,000 |
| 117 | 1.3.3.1.1.2.6 | Extrasolar Planets | 52d? | 2008-05-01 | 2008-07-11 | 441d | start no earlier than 2008-05-01 | McGrath [9.6%]; Scientist [19.2%]; Max [4.8%] | 140h | 9,000 |
| 118 | 1.3.3.1.1.2.7 | Asteroids | 22d? | 2008-05-01 | 2008-05-30 | 471d | start no earlier than 2008-05-01 | Student [22.7%]; Le Mignant [11.4%]; Max [4.5%] | 68h | 4,500 |
| 119 | 1.3.3.1.1.2.8 | QSO Host Galaxies | 42d? | 2008-05-01 | 2008-06-27 | 451d | start no earlier than 2008-05-01 | McGrath [17.9%]; Max [6%] | 80h | 4,500 |
| 120 | 1.3.3.1.1.2.9 | Backup Science - NGS & Acquisition Camera | 32d? | 2008-05-01 | 2008-06-13 | 461d | start no earlier than 2008-05-01 | McGrath [7.8%]; Le Mignant [11.7%]; Neyman [7.8%]; Max [7.8%] | 90h | 5,250 |
| 121 | 1.3.3.1.1.3 | **Characterize PSF Stability, Knowledge & Subtraction Requirements** | 242d? | 2008-05-01 | 2009-04-03 | 251d |  |  | 1436h | 90,000 |
| 122 | 1.3.3.1.1.3.1 | Nearby AGNs | 227d? | 2008-05-22 | 2009-04-03 | 251d | start no earlier than 2008-05-22 | McGrath [8.8%]; Student [19.8%]; Max [4.4%] | 600h | 39,000 |
| 123 | 1.3.3.1.1.3.2 | Galactic Center Astrometry | 97d? | 2008-05-01 | 2008-09-12 | 396d | start no earlier than 2008-05-01 | Student [20.6%]; Max [5.9%] | 206h | 12,000 |
| 124 | 1.3.3.1.1.3.3 | Extrasolar Planets | 96d? | 2008-07-11 | 2008-11-21 | 346d | start no earlier than 2008-07-11 | McGrath [5.2%]; Student [15.6%]; Scientist [10.4%]; Max [2.6%] | 260h | 18,000 |
| 125 | 1.3.3.1.1.3.4 | Minor Planet Multiplicity | 36d? | 2008-05-30 | 2008-07-18 | 436d | start no earlier than 2008-05-30 | Student [27.8%]; Scientist [13.9%]; Max [3.5%] | 130h | 9,000 |
| 126 | 1.3.3.1.1.3.5 | QSO Host Galaxies | 71d? | 2008-06-27 | 2008-10-03 | 381d | start no earlier than 2008-06-27 | McGrath [7%]; Student [21.1%]; Max [14.1%] | 240h | 12,000 |
| 127 | 1.3.3.1.1.4 | Characterize Sensitivity & Background Requirements | 152d? | 2008-05-01 | 2008-11-28 | 341d | start no earlier than 2008-05-01 | McGrath [9.9%]; Max [3.3%] | 160h | 9,000 |
| 128 | 1.3.3.1.1.5 | Science Requirements Summary Matrix | 52d? | 2008-11-21 | 2009-02-02 | 295d | start no earlier than 2008-11-21 | McGrath [19.2%]; Max [4.8%] | 100h | 6,000 |
| 129 | 1.3.3.1.1.6 | SEMP Input | 363d? | 2008-05-01 | 2009-09-21 | 130d | start no earlier than 2008-05-01 | McGrath [1.4%]; Max [0.7%] | 60h | 3,000 |

Notes:
- 103: RD
- 104: CM

| ID | WBS | Task | Duration | Start | Finish | Total slack | Constraint | Resources | Work | Cost |
| --- | --- | --- | --- | --- | --- | --- | --- | --- | --- | --- |
| 130 | 1.3.3.1.2 | **Science Observing Planning & Execution** | 363d? | 2008-05-01 | 2009-09-21 | 130d |  |  | 500h | 24,000 |
| 131 | 1.3.3.1.2.1 | Key Science Driver Observing Scenarios | 92d? | 2008-05-01 | 2008-09-05 | 401d | start no earlier than 2008-05-01 | McGrath [10.9%]; Le Mignant [10.9%]; Max [10.9%] | 240h | 12,000 |
| 132 | 1.3.3.1.2.2 | Design Reference Missions | 86d? | 2009-05-25 | 2009-09-21 | 130d | start no earlier than 2009-05-25 | McGrath [11.6%]; Le Mignant [12%]; Max [14.5%] | 260h | 12,000 |
| 133 | 1.3.3.1.3 | **Science Performance Input** | 363d? | 2008-05-01 | 2009-09-21 | 130d |  |  | 190h | 9,750 |
| 134 | 1.3.3.1.3.1 | Define Science Driver Parameters for Performance Budgets | 12d? | 2008-05-01 | 2008-05-16 | 481d | start no earlier than 2008-05-01 | McGrath [10.4%]; Max [20.8%] | 30h | 750 |
| 135 | 1.3.3.1.3.2 | Input to User Interfaces, Planning & Observing Tools | 363d? | 2008-05-01 | 2009-09-21 | 130d | start no earlier than 2008-05-01 | McGrath [2.8%] | 80h | 6,000 |
| 136 | 1.3.3.1.3.3 | Input to Preliminary Operations Concept Document | 363d? | 2008-05-01 | 2009-09-21 | 130d | start no earlier than 2008-05-01 | McGrath [1.4%]; Max [1.4%] | 80h | 3,000 |
| 137 | 1.3.3.1.4 | **Science Competitiveness** | 363d? | 2008-05-01 | 2009-09-21 | 130d |  |  | 188h | 7,800 |
| 138 | 1.3.3.1.4.1 | Update List of Science Goals for Other Facilities | 363d? | 2008-05-01 | 2009-09-21 | 130d | start no earlier than 2008-05-01 | McGrath [1.5%]; Max [1.5%] | 88h | 3,300 |
| 139 | 1.3.3.1.4.2 | Evaluate NGAO Potential to Compliment Other Facilities | 363d? | 2008-05-01 | 2009-09-21 | 130d | start no earlier than 2008-05-01 | McGrath [1.4%]; Max [0.3%] | 50h | 3,000 |
| 140 | 1.3.3.1.4.3 | Define NGAO Uniqueness Space | 363d? | 2008-05-01 | 2009-09-21 | 130d | start no earlier than 2008-05-01 | McGrath [0.7%]; Max [1%] | 50h | 1,500 |
| 141 | 1.3.3.1.5 | **User Community Liaison** | 363d? | 2008-05-01 | 2009-09-21 | 130d |  |  | 240h | 5,250 |
| 142 | 1.3.3.1.5.1 | Enlist People to work on new NGAO Science Aspects | 363d? | 2008-05-01 | 2009-09-21 | 130d | start no earlier than 2008-05-01 | Max [1.4%]; McGrath [0.7%] | 60h | 1,500 |
| 143 | 1.3.3.1.5.2 | **SSC & Keck Science Meeting** | 363d? | 2008-05-01 | 2009-09-21 | 130d |  |  | 180h | 3,750 |
| 144 | 1.3.3.1.5.2.1 | Prepare & Give Presentations | 363d? | 2008-05-01 | 2009-09-21 | 130d | start no earlier than 2008-05-01 | Max [3.1%]; McGrath [1.4%] | 130h | 3,000 |
| 145 | 1.3.3.1.5.2.2 | Obtain & Document Feedback | 363d? | 2008-05-01 | 2009-09-21 | 130d | start no earlier than 2008-05-01 | Max [1.4%]; McGrath [0.3%] | 50h | 750 |
| 146 | 1.3.3.1.6 | **Science Advisory Team Meetings** | 363d? | 2008-05-01 | 2009-09-21 | 130d |  |  | 280h | 12,000 |
| 147 | 1.3.3.1.6.1 | Prepare Minutes, Presentations & KAONs | 363d? | 2008-05-01 | 2009-09-21 | 130d | start no earlier than 2008-05-01 | Max [2.8%]; McGrath [2.8%]; Le Mignant [0.7%] | 180h | 7,500 |
| 148 | 1.3.3.1.6.2 | Refine Science Requirements | 363d? | 2008-05-01 | 2009-09-21 | 130d | start no earlier than 2008-05-01 | Le Mignant [0.7%] | 20h | 1,500 |
| 149 | 1.3.3.1.6.3 | Evaluate Science Impact of Proposed Changes | 363d? | 2008-05-01 | 2009-09-21 | 130d | start no earlier than 2008-05-01 | Max [1.4%]; McGrath [1.4%] | 80h | 3,000 |
| 150 | 1.3.3.2 | **Requirements** | 410d? | 2008-05-26 | 2009-12-18 | 66d |  |  | 970h | 72,750 |
| 151 | 1.3.3.2.1 | **Operations Concept Document (OCD)** | 410d? | 2008-05-26 | 2009-12-18 | 66d |  |  | 480h | 36,000 |
| 152 | 1.3.3.2.1.1 | OCD Outline | 10d? | 2008-05-26 | 2008-06-06 | 466d | start no earlier than 2008-05-26 | Le Mignant [40%]; Wizinowich [10%] | 40h | 3,000 |
| 153 | 1.3.3.2.1.2 | OCD Release 1 | 45d? | 2008-12-01 | 2009-01-30 | 296d | start no earlier than 2008-12-01 | Le Mignant [33.3%]; Other [22.2%] | 200h | 15,000 |
| 154 | 1.3.3.2.1.3 | OCD Release 2 | 80d? | 2009-08-17 | 2009-12-18 | 66d | finish no earlier than 2009-12-18 | Le Mignant [25%]; Other [12.5%] | 240h | 18,000 |

Notes:
- 150: EJ
- 151: DLM
- 152: DLM
- 153: DLM
- 154: DLM

| ID | WBS | Task | Duration | Start | Finish | Total slack | Constraint | Resources | Work | Cost |
| --- | --- | --- | --- | --- | --- | --- | --- | --- | --- | --- |
| 155 | 1.3.3.2.2 | **System Requirements (SRD)** | 270d? | 2008-12-01 | 2009-12-11 | 71d |  |  | 80h | 6,000 |
| 156 | 1.3.3.2.2.1 | SRD Release I | 10d? | 2008-12-01 | 2008-12-12 | 331d | finish no earlier than 2008-12-12 | Johansson [62.5%] | 50h | 3,750 |
| 157 | 1.3.3.2.2.2 | SRD Release 2 | 10d? | 2009-11-30 | 2009-12-11 | 71d | finish no earlier than 2009-12-11 | Johansson [37.5%] | 30h | 2,250 |
| 158 | 1.3.3.2.3 | **Functional Requirements (FRD)** | 375d? | 2008-07-14 | 2009-12-18 | 66d |  |  | 250h | 18,750 |
| 159 | 1.3.3.2.3.1 | FRD Release 1 | 35d? | 2008-07-14 | 2008-08-29 | 406d | start no earlier than 2008-07-14 | Johansson [14.3%]; Dekany [21.4%]; Wizinowich [7.1%] | 120h | 9,000 |
| 160 | 1.3.3.2.3.2 | FRD Release 2 | 35d? | 2009-11-02 | 2009-12-18 | 66d | start no earlier than 2009-11-02 | Johansson [17.9%]; Dekany [7.1%] | 70h | 5,250 |
| 161 | 1.3.3.2.3.3 | Compliance Matrix | 20d? | 2008-10-06 | 2008-10-31 | 361d | finish no earlier than 2008-10-31 | Johansson [37.5%] | 60h | 4,500 |
| 162 | 1.3.3.2.4 | Software Standards (Define & Document) | 31d? | 2008-07-04 | 2008-08-15 | 416d | start no earlier than 2008-07-04 | Johansson [32.3%] | 80h | 6,000 |
| 163 | 1.3.3.2.5 | Component Standards (Define & Document) | 25d? | 2008-11-03 | 2008-12-05 | 336d | finish no earlier than 2008-12-05 | Johansson [40%] | 80h | 6,000 |
| 164 | 1.3.3.3 | **Systems Engineering Analysis** | 427d? | 2008-05-01 | 2009-12-18 | 66d |  |  | 2532h | 189,900 |
| 165 | 1.3.3.3.1 | **Performance Budgets** | 427d? | 2008-05-01 | 2009-12-18 | 66d |  |  | 1092h | 81,900 |
| 166 | 1.3.3.3.1.1 | Requirements Flowdown Report | 15d? | 2009-11-30 | 2009-12-18 | 66d | start no earlier than 2009-11-30 | Dekany [50%] | 60h | 4,500 |
| 167 | 1.3.3.3.1.2 | **Throughput & Background Budget** | 30d? | 2008-11-03 | 2008-12-12 | 331d |  |  | 80h | 6,000 |
| 168 | 1.3.3.3.1.2.1 | Thermal Background Analysis Software with Documentation | 15d? | 2008-11-03 | 2008-11-21 | 346d | finish no earlier than 2008-11-21 | Bouchez [41.7%] | 50h | 3,750 |
| 169 | 1.3.3.3.1.2.2 | Thermal Analysis | 10d? | 2008-12-01 | 2008-12-12 | 331d | finish no earlier than 2008-12-12 | Bouchez [37.5%] | 30h | 2,250 |
| 170 | 1.3.3.3.1.3 | **Wavefront & Encircled Energy** | 347d? | 2008-05-01 | 2009-08-28 | 146d |  |  | 312h | 23,400 |
| 171 | 1.3.3.3.1.3.1 | **WFE/EE Budget Tool** | 282d? | 2008-05-01 | 2009-05-29 | 211d |  |  | 240h | 18,000 |
| 172 | 1.3.3.3.1.3.1.1 | NGS TT & TTFA Sharpening Budgets | 42d? | 2008-05-01 | 2008-06-27 | 451d | start no earlier than 2008-05-01 | Dekany [23.8%] | 80h | 6,000 |
| 173 | 1.3.3.3.1.3.1.2 | Improved Bandwidth Model | 25d? | 2008-09-01 | 2008-10-03 | 381d | start no earlier than 2008-09-01 | Dekany [40%] | 80h | 6,000 |
| 174 | 1.3.3.3.1.3.1.3 | Improved Atmospheric Dispersion Model | 15d? | 2008-09-01 | 2008-09-19 | 391d | start no earlier than 2008-09-01 | Neyman [33.3%] | 40h | 3,000 |
| 175 | 1.3.3.3.1.3.1.4 | Other | 20d? | 2009-05-04 | 2009-05-29 | 211d | start no earlier than 2009-05-04 | Dekany [25%] | 40h | 3,000 |
| 176 | 1.3.3.3.1.3.2 | **WFE/EE Performance Analysis** | 65d? | 2009-06-01 | 2009-08-28 | 146d |  |  | 72h | 5,400 |
| 177 | 1.3.3.3.1.3.2.1 | Key Science Cases Analysis | 20d? | 2009-06-01 | 2009-06-26 | 191d | start no earlier than 2009-06-01 | Dekany [15%] | 24h | 1,800 |
| 178 | 1.3.3.3.1.3.2.2 | Additional Science Case Analysis | 20d? | 2009-08-03 | 2009-08-28 | 146d | start no earlier than 2009-08-03 | Dekany [30%] | 48h | 3,600 |

Notes:
- 155: EJ
- 156: EJ
- 157: EJ
- 158: EJ
- 159: EJ
- 160: EJ
- 161: EJ
- 162: EJ
- 163: EJ
- 164: RD
- 165: RD

| ID | WBS | Task | Duration | Start | Finish | Predecessors | Total slack | Free slack | Constraint | Resources | Work | Cost |
| --- | --- | --- | --- | --- | --- | --- | --- | --- | --- | --- | --- | --- |
| 179 | 1.3.3.3.1.4 | **Astrometric Precision** | 105d? | 2008-10-06 | 2009-02-27 |  | 276d |  |  |  | 480h | 36,000 |
| 180 | 1.3.3.3.1.4.1 | Develop Astrometric Budget Tool | 55d? | 2008-10-06 | 2008-12-19 |  | 326d |  | start no earlier than 2008-10-06 | Dekany [18.2%]; Wizinowich [18.2%] | 160h | 12,000 |
| 181 | 1.3.3.3.1.4.2 | Galactic Center Astrometric Analysis | 40d? | 2009-01-05 | 2009-02-27 |  | 276d |  | start no earlier than 2009-01-05 | Dekany [50%]; Neyman [50%] | 320h | 24,000 |
| 182 | 1.3.3.3.1.5 | **Observing Efficiency** | 266d? | 2008-06-24 | 2009-06-30 |  | 189d |  |  |  | 80h | 6,000 |
| 183 | 1.3.3.3.1.5.1 | Observing Efficiency Tool | 5d? | 2008-06-24 | 2008-06-30 |  | 450d |  | finish no earlier than 2008-06-30 | Le Mignant | 40h | 3,000 |
| 184 | 1.3.3.3.1.5.2 | Observing Efficiency Analysis | 5d? | 2009-06-24 | 2009-06-30 |  | 189d |  | finish no earlier than 2009-06-30 | Le Mignant | 40h | 3,000 |
| 185 | 1.3.3.3.1.6 | **Observing Uptime** | 266d? | 2008-07-24 | 2009-07-30 |  | 167d |  |  |  | 80h | 6,000 |
| 186 | 1.3.3.3.1.6.1 | Observing Uptime Tool | 5d? | 2008-07-24 | 2008-07-30 |  | 428d |  | finish no earlier than 2008-07-30 | Johansson | 40h | 3,000 |
| 187 | 1.3.3.3.1.6.2 | Observing Uptime Analysis | 5d? | 2009-07-24 | 2009-07-30 |  | 167d |  | finish no earlier than 2009-07-30 | Johansson | 40h | 3,000 |
| 188 | 1.3.3.3.2 | **Modeling & Analysis** | 247d? | 2008-05-01 | 2009-04-10 |  | 246d |  |  |  | 960h | 72,000 |
| 189 | 1.3.3.3.2.1 | T/T Sharpening Study Report | 42d? | 2008-05-01 | 2008-06-27 |  | 451d |  | start no earlier than 2008-05-01 | Dekany [23.8%]; Neyman [71.4%] | 320h | 24,000 |
| 190 | 1.3.3.3.2.2 | Performance vs T/T NGS Report | 32d? | 2008-08-18 | 2008-09-30 |  | 384d |  | start no earlier than 2008-08-18 | Dekany [46.9%]; Neyman [46.9%] | 240h | 18,000 |
| 191 | 1.3.3.3.2.3 | Galactic Center Performance Report | 30d? | 2009-03-02 | 2009-04-10 |  | 246d |  | start no earlier than 2009-03-02 | Dekany [50%]; Neyman [50%] | 240h | 18,000 |
| 192 | 1.3.3.3.2.4 | PSF Libraries | 35d? | 2008-11-03 | 2008-12-19 |  | 326d |  | finish no earlier than 2008-12-19 | Neyman [57.1%] | 160h | 12,000 |
| 193 | 1.3.3.3.3 | PSF Calibration | 125d? | 2009-05-04 | 2009-10-23 |  | 106d |  | start no earlier than 2009-05-04 | Le Mignant [12%]; Neyman [36%] | 480h | 36,000 |
| 194 | 1.3.3.4 | **System Architecture** | 417d? | 2008-05-01 | 2009-12-04 |  | 76d |  |  |  | 1056h | 79,200 |
| 195 | 1.3.3.4.1 | **System Hardware Architecture** | 413d? | 2008-05-01 | 2009-11-30 |  | 80d |  |  |  | 264h | 19,800 |
| 196 | 1.3.3.4.1.1 | Hybrid Rayleigh / Sodium Trade Study | 25d? | 2008-06-30 | 2008-08-01 |  | 426d |  | start no earlier than 2008-06-30 | Dekany [40%]; Neyman [40%] | 160h | 12,000 |
| 197 | 1.3.3.4.1.2 | Degraded Laser Power Trade Study | 10d? | 2008-08-04 | 2008-08-15 |  | 416d |  | start no earlier than 2008-08-04 | Neyman [50%] | 40h | 3,000 |
| 198 | 1.3.3.4.1.3 | System Architecture: Evaluate & Document Changes | 413d? | 2008-05-01 | 2009-11-30 |  | 80d |  | start no earlier than 2008-05-01 | Dekany [1.9%] | 64h | 4,800 |
| 199 | 1.3.3.4.2 | **Motion Control / Electronics Architecture** | 261d? | 2008-10-01 | 2009-09-30 |  | 123d |  |  |  |  |  |
| 200 | 1.3.3.4.2.1 | Evaluate MC/Electronics Arch Options | 33d? | 2008-10-01 | 2008-11-14 |  | 315d | 0d | finish no earlier than 2008-11-14 |  |  |  |
| 201 | 1.3.3.4.2.2 | Determine/Document MC/Electronics Arch | 36d? | 2008-11-17 | 2009-01-05 | 200 | 315d |  | start no earlier than 2008-11-17 |  |  |  |
| 202 | 1.3.3.4.2.3 | MC/Electronics Architecture Design Support | 228d? | 2008-11-17 | 2009-09-30 |  | 123d |  | finish no earlier than 2009-09-30 |  |  |  |

Notes:
- 188: RD
- 193: DLM
- 194: RD

| ID | WBS | Task | Duration | Start | Finish | Predecessors | Total slack | Free slack | Constraint | Resources | Work | Cost |
| --- | --- | --- | --- | --- | --- | --- | --- | --- | --- | --- | --- | --- |
| 203 | 1.3.3.4.3 | **Software Architecture** | 308d? | 2008-07-28 | 2009-09-30 |  | 123d |  |  |  | 424h | 31,800 |
| 204 | 1.3.3.4.3.1 | Evaluate Software Architecture Options | 15d? | 2008-07-28 | 2008-08-15 |  | 391d | 0d | finish no earlier than 2008-08-15 | Johansson; Other | 160h | 12,000 |
| 205 | 1.3.3.4.3.2 | Determine/Document Software Arch Approach | 25d? | 2008-08-18 | 2008-09-19 | 204 | 391d |  | start no earlier than 2008-08-18 | Johansson | 200h | 15,000 |
| 206 | 1.3.3.4.3.3 | Software Architecture: Evaluate & Document Changes | 8d? | 2009-09-21 | 2009-09-30 |  | 123d |  | finish no earlier than 2009-09-30 | Johansson | 64h | 4,800 |
| 207 | 1.3.3.4.4 | **Operations Sequences Architecture** | 415d? | 2008-05-05 | 2009-12-04 |  | 76d |  |  |  | 368h | 27,600 |
| 208 | 1.3.3.4.4.1 | Define Required System Level Sequences | 20d? | 2008-05-05 | 2008-05-30 |  | 471d |  | start no earlier than 2008-05-05 | Le Mignant [50%] | 80h | 6,000 |
| 209 | 1.3.3.4.4.2 | Develop System Level Sequences Approach | 50d? | 2008-06-02 | 2008-08-08 |  | 421d |  | start no earlier than 2008-06-02 | Le Mignant [36%] | 144h | 10,800 |
| 210 | 1.3.3.4.4.3 | Sequences Definition Document | 15d? | 2008-08-11 | 2008-08-29 |  | 406d |  | start no earlier than 2008-08-11 | Le Mignant [66.7%] | 80h | 6,000 |
| 211 | 1.3.3.4.4.4 | Sequences: Evaluate & Document Changes | 285d? | 2008-11-03 | 2009-12-04 |  | 76d |  | start no earlier than 2008-11-03 | Le Mignant [2.8%] | 64h | 4,800 |
| 212 | 1.3.3.5 | **External Interface Control** | 100d? | 2008-10-06 | 2009-02-20 |  | 281d |  |  |  | 244h | 18,300 |
| 213 | 1.3.3.5.1 | **Observatory Interfaces** | 100d? | 2008-10-06 | 2009-02-20 |  | 281d |  |  |  | 120h | 9,000 |
| 214 | 1.3.3.5.1.1 | AO System ICD | 15d? | 2009-02-02 | 2009-02-20 |  | 281d |  | finish no earlier than 2009-02-20 | Other [33.3%] | 40h | 3,000 |
| 215 | 1.3.3.5.1.2 | Laser System ICD | 10d? | 2008-10-06 | 2008-10-17 |  | 371d |  | finish no earlier than 2008-10-17 | Chin [12.5%]; Neyman [25%]; Adkins [12.5%] | 40h | 3,000 |
| 216 | 1.3.3.5.1.3 | Science Tools ICD | 20d? | 2008-10-06 | 2008-10-31 |  | 361d |  | finish no earlier than 2008-10-31 | Le Mignant [15.6%]; Johansson | 40h | 3,000 |
| 217 | 1.3.3.5.2 | **Science Instrument Interfaces to NGAO** | 40d? | 2008-10-06 | 2008-11-28 |  | 341d |  |  |  | 124h | 9,300 |
| 218 | 1.3.3.5.2.1 | Generic Science Instrument ICD to AO | 20d? | 2008-10-06 | 2008-10-31 |  | 361d |  | finish no earlier than 2008-10-31 | Adkins [12.5%]; Other [12.5%] | 40h | 3,000 |
| 219 | 1.3.3.5.2.2 | Generic Science Instrument ICD to NGAO Science Tools | 20d? | 2008-10-06 | 2008-10-31 |  | 361d |  | finish no earlier than 2008-10-31 | Adkins [9.4%]; Le Mignant [9.4%]; Johansson | 40h | 3,000 |
| 220 | 1.3.3.5.2.3 | Interferometer Specific ICD | 20d? | 2008-11-03 | 2008-11-28 |  | 341d |  | finish no earlier than 2008-11-28 | Neyman [7.5%] | 12h | 900 |
| 221 | 1.3.3.5.2.4 | OSIRIS Specific ICD | 20d? | 2008-11-03 | 2008-11-28 |  | 341d |  | start no earlier than 2008-11-03 | Adkins [2.5%]; Kupke [1.2%]; Bell [1.2%] | 8h | 600 |
| 222 | 1.3.3.5.2.5 | NIR Camera Specific ICD | 20d? | 2008-11-03 | 2008-11-28 |  | 341d |  | start no earlier than 2008-11-03 | Adkins [1.2%]; Kupke [0.6%]; Lockwood [0.6%] | 4h | 300 |
| 223 | 1.3.3.5.2.6 | Visible Camera Specific ICD | 20d? | 2008-11-03 | 2008-11-28 |  | 341d |  | start no earlier than 2008-11-03 | Adkins [1.2%]; Kupke [0.6%]; Lockwood [0.6%] | 4h | 300 |
| 224 | 1.3.3.5.2.7 | d-IFS Specific ICD | 20d? | 2008-11-03 | 2008-11-28 |  | 341d |  | start no earlier than 2008-11-03 | Adkins [6.2%]; Wizinowich [2.5%]; Bell [1.2%] | 16h | 1,200 |
| 225 | 1.3.3.6 | **Internal Interface Control** | 85d? | 2008-08-04 | 2008-11-28 |  | 341d |  |  |  | 416h | 31,200 |
| 226 | 1.3.3.6.1 | Interface N-Squared Diagram | 40d? | 2008-08-04 | 2008-09-26 |  | 386d |  | finish no earlier than 2008-09-26 | Other [46.9%] | 150h | 11,250 |
| 227 | 1.3.3.6.2 | Interface Definition Document | 40d? | 2008-10-06 | 2008-11-28 |  | 341d |  | finish no earlier than 2008-11-28 | Other [83.1%] | 266h | 19,950 |

Notes:
- 203: EJ
- 207: DLM

| ID | WBS | Task | Duration | Start | Finish | Total slack | Constraint | Resources | Work | Cost |
| --- | --- | --- | --- | --- | --- | --- | --- | --- | --- | --- |
| 228 | 1.3.3.7 | **Configuration Control** | 15d? | 2009-08-31 | 2009-09-18 | 131d |  |  | 218h | 16,350 |
| 229 | 1.3.3.7.1 | Change Control Guidelines & Tools Definition | 15d? | 2009-08-31 | 2009-09-18 | 131d | start no earlier than 2009-08-31 | Other [60.6%]; Johansson; Gavel [50%]; Dekany [50%]; Bell | 218h | 16,350 |
| 230 | 1.3.3.8 | **Documentation Control** | 5d? | 2009-01-12 | 2009-01-16 | 306d |  |  | 40h | 3,000 |
| 231 | 1.3.3.8.1 | Document Control Guidelines & Tools Definition | 5d? | 2009-01-12 | 2009-01-16 | 306d | finish no earlier than 2009-01-16 | Johansson | 40h | 3,000 |
| 232 | 1.3.3.9 | **Technical Risk Assessment & Mitigation** | 270d? | 2008-08-18 | 2009-08-28 | 146d |  |  | 700h | 52,500 |
| 233 | 1.3.3.9.1 | **Risk Assessment** | 229.2d? | 2008-10-13 | 2009-08-28 | 146d |  |  | 100h | 7,500 |
| 234 | 1.3.3.9.1.1 | Risk Assessment v1 | 13.2d? | 2008-10-13 | 2008-10-30 | 362d | finish no earlier than 2008-10-30 | Wizinowich [28.4%]; Dekany [28.4%] | 50h | 3,750 |
| 235 | 1.3.3.9.1.2 | Risk Assessment v2 | 12d? | 2009-08-13 | 2009-08-28 | 146d | finish no earlier than 2009-08-28 | Wizinowich [31.2%]; Dekany [31.2%] | 50h | 3,750 |
| 236 | 1.3.3.9.2 | **Risk Mitigation Efforts** | 135d? | 2008-08-18 | 2009-02-20 | 281d |  |  | 600h | 45,000 |
| 237 | 1.3.3.9.2.1 | **PSF Calibration** | 100d? | 2008-09-15 | 2009-01-30 | 296d |  |  | 200h | 15,000 |
| 238 | 1.3.3.9.2.1.1 | Support/Monitor Profiler Implementation | 100d? | 2008-09-15 | 2009-01-30 | 296d | start no earlier than 2008-09-15 | Neyman [22.5%]; Wizinowich [2.5%] | 200h | 15,000 |
| 239 | 1.3.3.9.2.2 | **Sky Coverage** | 135d? | 2008-08-18 | 2009-02-20 | 281d |  |  | 400h | 30,000 |
| 240 | 1.3.3.9.2.2.1 | Prototype NIR Tip/tilt Sensor | 135d? | 2008-08-18 | 2009-02-20 | 281d | start no earlier than 2008-08-18 | Other [37%] | 400h | 30,000 |
| 241 | 1.3.3.10 | Preliminary Design Manual | 16.67d? | 2009-11-30 | 2009-12-22 | 64.33d | start no earlier than 2009-11-30 | Wizinowich [60%]; Dekany [50%]; Gavel [50%]; Other | 120h | 9,000 |
| 242 | 1.3.4 | **AO System Design** | 414d? | 2008-04-01 | 2009-10-30 | 101d |  |  | 9404h | 704,100 |
| 243 | 1.3.4.1 | AO Enclosure | 130d? | 2008-10-01 | 2009-03-31 | 254d | finish no earlier than 2009-03-31 | Bell [28.8%] | 300h | 22,500 |
| 244 | 1.3.4.2 | **Opto-Mechanical** | 414d? | 2008-04-01 | 2009-10-30 | 101d |  |  | 6729h | 503,475 |
| 245 | 1.3.4.2.1 | AO Support Structure | 20d? | 2008-11-03 | 2008-11-28 | 341d | start no earlier than 2008-11-03 | Lockwood | 160h | 12,000 |
| 246 | 1.3.4.2.2 | Rotator | 12.5d? | 2009-03-12 | 2009-03-30 | 255d | finish no earlier than 2009-03-30 | Lockwood; Kupke | 120h | 9,000 |
| 247 | 1.3.4.2.3 | Optical Relays | 40d? | 2008-12-08 | 2009-01-30 | 296d | finish no earlier than 2009-01-30 | Lockwood; Kupke | 533h | 39,975 |
| 248 | 1.3.4.2.4 | Optical Switchyard | 30d? | 2008-08-01 | 2008-09-11 | 397d | start no earlier than 2008-08-01 | Lockwood; Kupke | 400h | 30,000 |
| 249 | 1.3.4.2.5 | **LGS Wavefront Sensor Assembly** | 55d? | 2008-04-01 | 2008-06-16 | 460d |  |  | 2200h | 165,000 |
| 250 | 1.3.4.2.5.1 | Review/Update Conceptual Design | 10d? | 2008-04-01 | 2008-04-14 | 505d |  | Velur; Dekany [50%] | 120h | 9,000 |
| 251 | 1.3.4.2.5.2 | Acquisition & Dithering Requirements & Approach | 6.25d? | 2008-04-01 | 2008-04-09 | 508.75d |  | Velur; Other | 100h | 7,500 |
| 252 | 1.3.4.2.5.3 | LGS WFS Opto-Mechanical Design | 42.5d? | 2008-04-01 | 2008-05-29 | 472.5d |  | Velur; Other | 660h | 49,500 |
| 253 | 1.3.4.2.5.4 | Object Selection Opto-Mechanical Design | 5d? | 2008-04-01 | 2008-04-07 | 510d |  | Velur | 40h | 3,000 |
| 254 | 1.3.4.2.5.5 | Assembly Model | 12.5d? | 2008-04-01 | 2008-04-17 | 502.5d |  | Velur; Other | 200h | 15,000 |
| 255 | 1.3.4.2.5.6 | Throughput Model & Scattered Light Issues | 10d? | 2008-04-01 | 2008-04-14 | 505d |  | Velur | 80h | 6,000 |
| 256 | 1.3.4.2.5.7 | Motion Control Design | 10d? | 2008-04-01 | 2008-04-14 | 505d |  | Velur; Wetherell | 160h | 12,000 |
| 257 | 1.3.4.2.5.8 | Design Risks Evaluation | 10d? | 2008-04-01 | 2008-04-14 | 505d |  | Velur | 80h | 6,000 |
| 258 | 1.3.4.2.5.9 | Alignment, Integration & Test Plans | 55d? | 2008-04-01 | 2008-06-16 | 460d |  | Velur | 440h | 33,000 |
| 259 | 1.3.4.2.5.10 | Compliance Matrix | 20d? | 2008-04-01 | 2008-04-28 | 495d |  | Velur | 160h | 12,000 |
| 260 | 1.3.4.2.5.11 | Design Report | 20d? | 2008-04-01 | 2008-04-28 | 495d |  | Velur | 160h | 12,000 |

Notes:
- 228: EJ
- 230: EJ
- 232: PW
- 241: PW

| ID | WBS | Task | Duration | Start | Finish | Total slack | Resources | Work | Cost |
| --- | --- | --- | --- | --- | --- | --- | --- | --- | --- |
| 261 | 1.3.4.2.6 | **NGS WFS/TWFS Assembly** | 28d? | 2008-04-01 | 2008-05-08 | 487d |  | 936h | 70,200 |
| 262 | 1.3.4.2.6.1 | Review/Update Conceptual Design | 5d? | 2008-04-01 | 2008-04-07 | 510d | Other | 40h | 3,000 |
| 263 | 1.3.4.2.6.2 | Field Steering Compliance Check | 14d? | 2008-04-01 | 2008-04-18 | 501d | Other | 112h | 8,400 |
| 264 | 1.3.4.2.6.3 | NGS WFS/TWFS Opto-Mechanical Design | 28d? | 2008-04-01 | 2008-05-08 | 487d | Other | 224h | 16,800 |
| 265 | 1.3.4.2.6.4 | Assembly Model | 17.5d? | 2008-04-01 | 2008-04-24 | 497.5d | Other | 140h | 10,500 |
| 266 | 1.3.4.2.6.5 | Motion Control Design | 7d? | 2008-04-01 | 2008-04-09 | 508d | Other | 56h | 4,200 |
| 267 | 1.3.4.2.6.6 | Design Risks Evaluation | 3.5d? | 2008-04-01 | 2008-04-04 | 511.5d | Other | 28h | 2,100 |
| 268 | 1.3.4.2.6.7 | Alignment Plan | 28d? | 2008-04-01 | 2008-05-08 | 487d | Other | 224h | 16,800 |
| 269 | 1.3.4.2.6.8 | Compliance Matrix | 7d? | 2008-04-01 | 2008-04-09 | 508d | Other | 56h | 4,200 |
| 270 | 1.3.4.2.6.9 | Design Report | 7d? | 2008-04-01 | 2008-04-09 | 508d | Other | 56h | 4,200 |
| 271 | 1.3.4.2.7 | **Low Order Wavefront Sensor Assembly** | 50d? | 2008-04-01 | 2008-06-09 | 465d |  | 1932h | 144,900 |
| 272 | 1.3.4.2.7.1 | Review/Update Conceptual Design | 12.5d? | 2008-04-01 | 2008-04-17 | 502.5d | Other | 100h | 7,500 |
| 273 | 1.3.4.2.7.2 | Detector Evaluation & Selection | 2.5d? | 2008-04-01 | 2008-04-03 | 512.5d | Other | 20h | 1,500 |
| 274 | 1.3.4.2.7.3 | Dithering Requirements & Approach | 19d? | 2008-04-01 | 2008-04-25 | 496d | Other | 152h | 11,400 |
| 275 | 1.3.4.2.7.4 | LOWFS Opto-Mechanical Design | 50d? | 2008-04-01 | 2008-06-09 | 465d | Other | 400h | 30,000 |
| 276 | 1.3.4.2.7.5 | Object Selection Opto-Mechanical Design | 37.5d? | 2008-04-01 | 2008-05-22 | 477.5d | Other | 300h | 22,500 |
| 277 | 1.3.4.2.7.6 | Assembly Model | 20d? | 2008-04-01 | 2008-04-28 | 495d | Other | 160h | 12,000 |
| 278 | 1.3.4.2.7.7 | Thermal Model & Related Issues | 1d? | 2008-04-01 | 2008-04-01 | 514d | Other [500%] | 40h | 3,000 |
| 279 | 1.3.4.2.7.8 | Motion Control Design | 40d? | 2008-04-01 | 2008-05-26 | 475d | Other | 320h | 24,000 |
| 280 | 1.3.4.2.7.9 | Design Risks Evaluation | 10d? | 2008-04-01 | 2008-04-14 | 505d | Other | 80h | 6,000 |
| 281 | 1.3.4.2.7.10 | Alignment, Integration & Test Plans | 30d? | 2008-04-01 | 2008-05-12 | 485d | Other | 240h | 18,000 |
| 282 | 1.3.4.2.7.11 | Compliance Matrix | 5d? | 2008-04-01 | 2008-04-07 | 510d | Other | 40h | 3,000 |
| 283 | 1.3.4.2.7.12 | Design Report | 10d? | 2008-04-01 | 2008-04-14 | 505d | Other | 80h | 6,000 |
| 284 | 1.3.4.2.8 | **Tip/Tilt Vibration Mitigation** | 10d? | 2008-04-01 | 2008-04-14 | 505d |  | 80h | 6,000 |
| 285 | 1.3.4.2.8.1 | TT Vibration Mitigation Analysis | 10d? | 2008-04-01 | 2008-04-14 | 505d | Neyman | 80h | 6,000 |

| ID | WBS | Task | Duration | Start | Finish | Total slack | Constraint | Resources | Work | Cost |
| --- | --- | --- | --- | --- | --- | --- | --- | --- | --- | --- |
| 286 | 1.3.4.2.9 | **Acquisition Cameras** | 305d? | 2008-09-01 | 2009-10-30 | 101d |  |  | 128h | 8,400 |
| 287 | 1.3.4.2.9.1 | Implementation Issues | 20d? | 2008-09-01 | 2008-09-26 | 386d | start no earlier than 2008-09-01 | Neyman [12.5%]; Le Mignant [12.5%] | 40h | 3,000 |
| 288 | 1.3.4.2.9.2 | Opto-Mechanical Design | 20d? | 2009-10-01 | 2009-10-30 | 101d | start no earlier than 2009-10-01 | Neyman [35%]; Panteleev [10%]; Lockwood [10%] | 88h | 5,400 |
| 289 | 1.3.4.2.10 | **Atmospheric Dispersion Correctors** | 96d? | 2008-10-17 | 2009-02-27 | 276d |  |  | 240h | 18,000 |
| 290 | 1.3.4.2.10.1 | LOWFS ADCs | 10d? | 2008-10-17 | 2008-10-30 | 362d | finish no earlier than 2008-10-30 | Kupke; Lockwood [75%] | 140h | 10,500 |
| 291 | 1.3.4.2.10.2 | NIR Science ADC | 5d? | 2008-12-24 | 2008-12-30 | 319d | finish no earlier than 2008-12-30 | Kupke; Lockwood [25%] | 50h | 3,750 |
| 292 | 1.3.4.2.10.3 | Visible Science & NGS WFS ADC | 5d? | 2009-02-23 | 2009-02-27 | 276d | finish no earlier than 2009-02-27 | Kupke; Lockwood [25%] | 50h | 3,750 |
| 293 | 1.3.4.3 | **Alignment, Calibration & Diagnostics** | 8.33d? | 2008-04-01 | 2008-04-11 | 506.67d |  |  | 505h | 37,875 |
| 294 | 1.3.4.3.1 | **Simulator** | 8.33d? | 2008-04-01 | 2008-04-11 | 506.67d |  |  | 250h | 18,750 |
| 295 | 1.3.4.3.1.1 | Simulator Requirements & Interfaces | 5d? | 2008-04-01 | 2008-04-07 | 510d |  | Neyman; Wizinowich [60%] | 50h | 3,750 |
| 296 | 1.3.4.3.1.2 | Simulator Optical Design | 8.33d? | 2008-04-01 | 2008-04-11 | 506.67d |  | Neyman; Wizinowich [60%] | 50h | 3,750 |
| 297 | 1.3.4.3.1.3 | Simulator Mechanical Design | 6.25d? | 2008-04-01 | 2008-04-09 | 508.75d |  | Neyman; Bell | 60h | 4,500 |
| 298 | 1.3.4.3.1.4 | Simulator Electrical Design | 3.75d? | 2008-04-01 | 2008-04-04 | 511.25d |  | Neyman; Wetherell | 50h | 3,750 |
| 299 | 1.3.4.3.1.5 | Simulator Assembly, Alignment & Test Plans | 5d? | 2008-04-01 | 2008-04-07 | 510d |  | Neyman | 40h | 3,000 |
| 300 | 1.3.4.3.2 | **System Alignment Tools** | 5d? | 2008-04-01 | 2008-04-07 | 510d |  |  | 255h | 19,125 |
| 301 | 1.3.4.3.2.1 | Alignment Requirements & Interfaces | 5d? | 2008-04-01 | 2008-04-07 | 510d |  | Neyman; Kupke; Wizinowich [60%] | 60h | 4,500 |
| 302 | 1.3.4.3.2.2 | Alignment Optical Design | 5d? | 2008-04-01 | 2008-04-07 | 510d |  | Neyman; Kupke | 50h | 3,750 |
| 303 | 1.3.4.3.2.3 | Alignment Mechanical Design | 5d? | 2008-04-01 | 2008-04-07 | 510d |  | Neyman; Lockwood | 50h | 3,750 |
| 304 | 1.3.4.3.2.4 | Alignment Electrical Design | 2.5d? | 2008-04-01 | 2008-04-03 | 512.5d |  | Neyman; Wetherell | 35h | 2,625 |
| 305 | 1.3.4.3.2.5 | Alignment Assembly, Alignment & Test Plans | 5d? | 2008-04-01 | 2008-04-07 | 510d |  | Neyman; Kupke; Wizinowich [60%] | 60h | 4,500 |
| 306 | 1.3.4.4 | **Non-real-time Control** | 12.5d? | 2008-04-01 | 2008-04-17 | 502.5d |  |  | 1350h | 101,250 |
| 307 | 1.3.4.4.1 | **AO Controls Infrastructure** | 10d? | 2008-04-01 | 2008-04-14 | 505d |  |  | 180h | 13,500 |
| 308 | 1.3.4.4.1.1 | AO Controls: Distributed Controls Architecture | 10d? | 2008-04-01 | 2008-04-14 | 505d |  | Other | 80h | 6,000 |
| 309 | 1.3.4.4.1.2 | AO Controls: Computer Specification & Selection | 5d? | 2008-04-01 | 2008-04-07 | 510d |  | Other | 40h | 3,000 |
| 310 | 1.3.4.4.1.3 | AO Controls: Interface Control Document | 2.5d? | 2008-04-01 | 2008-04-03 | 512.5d |  | Other | 20h | 1,500 |
| 311 | 1.3.4.4.1.4 | AO Controls: Configuration Management Document | 2.5d? | 2008-04-01 | 2008-04-03 | 512.5d |  | Other | 20h | 1,500 |
| 312 | 1.3.4.4.1.5 | AO Controls: Summary Report | 2.5d? | 2008-04-01 | 2008-04-03 | 512.5d |  | Other | 20h | 1,500 |

| ID | WBS | Task | Type | Duration | Start | Finish | Total slack | Resources | Work | Cost |
| --- | --- | --- | --- | --- | --- | --- | --- | --- | --- | --- |
| 313 | 1.3.4.4.2 | **AO Sequencer** |  | 10d? | 2008-04-01 | 2008-04-14 | 505d |  | 140h | 10,500 |
| 314 | 1.3.4.4.2.1 | AO Sequencer: Architecture |  | 10d? | 2008-04-01 | 2008-04-14 | 505d | Other | 80h | 6,000 |
| 315 | 1.3.4.4.2.2 | AO Sequencer: Interface Control Document |  | 2.5d? | 2008-04-01 | 2008-04-03 | 512.5d | Other | 20h | 1,500 |
| 316 | 1.3.4.4.2.3 | AO Sequencer: Software Module Design |  | 1.25d? | 2008-04-01 | 2008-04-02 | 513.75d | Other | 10h | 750 |
| 317 | 1.3.4.4.2.4 | AO Sequencer: User Interface Design | milestone | 0d? | 2008-04-01 | 2008-04-01 | 515d | Other |  |  |
| 318 | 1.3.4.4.2.5 | AO Sequencer: Technical Specifications |  | 2.5d? | 2008-04-01 | 2008-04-03 | 512.5d | Other | 20h | 1,500 |
| 319 | 1.3.4.4.2.6 | AO Sequencer: Compliance Matrix | milestone | 0d? | 2008-04-01 | 2008-04-01 | 515d | Other |  |  |
| 320 | 1.3.4.4.2.7 | AO Sequencer: Test Plan | milestone | 0d? | 2008-04-01 | 2008-04-01 | 515d | Other |  |  |
| 321 | 1.3.4.4.2.8 | AO Sequencer: Summary Report |  | 1.25d? | 2008-04-01 | 2008-04-02 | 513.75d | Other | 10h | 750 |
| 322 | 1.3.4.4.3 | **AO Motion Control Software** |  | 10d? | 2008-04-01 | 2008-04-14 | 505d |  | 220h | 16,500 |
| 323 | 1.3.4.4.3.1 | Motion Control SW: Architecture |  | 10d? | 2008-04-01 | 2008-04-14 | 505d | Other | 80h | 6,000 |
| 324 | 1.3.4.4.3.2 | Motion Control SW: ICD |  | 5d? | 2008-04-01 | 2008-04-07 | 510d | Other | 40h | 3,000 |
| 325 | 1.3.4.4.3.3 | Motion Control SW: Module Design |  | 7.5d? | 2008-04-01 | 2008-04-10 | 507.5d | Other | 60h | 4,500 |
| 326 | 1.3.4.4.3.4 | Motion Control SW: User Interface Design | milestone | 0d? | 2008-04-01 | 2008-04-01 | 515d | Other |  |  |
| 327 | 1.3.4.4.3.5 | Motion Control SW: Technical Specifications |  | 2.5d? | 2008-04-01 | 2008-04-03 | 512.5d | Other | 20h | 1,500 |
| 328 | 1.3.4.4.3.6 | Motion Control SW: Compliance Matrix | milestone | 0d? | 2008-04-01 | 2008-04-01 | 515d | Other |  |  |
| 329 | 1.3.4.4.3.7 | Motion Control SW: Test Plan | milestone | 0d? | 2008-04-01 | 2008-04-01 | 515d | Other |  |  |
| 330 | 1.3.4.4.3.8 | Motion Control SW: Summary Report |  | 2.5d? | 2008-04-01 | 2008-04-03 | 512.5d | Other | 20h | 1,500 |
| 331 | 1.3.4.4.4 | **AO Device Control Software** |  | 10d? | 2008-04-01 | 2008-04-14 | 505d |  | 240h | 18,000 |
| 332 | 1.3.4.4.4.1 | Device Control: Software Architecture |  | 10d? | 2008-04-01 | 2008-04-14 | 505d | Other | 80h | 6,000 |
| 333 | 1.3.4.4.4.2 | Device Control: Interface Control Document |  | 5d? | 2008-04-01 | 2008-04-07 | 510d | Other | 40h | 3,000 |
| 334 | 1.3.4.4.4.3 | Device Control: Software Module Design |  | 10d? | 2008-04-01 | 2008-04-14 | 505d | Other | 80h | 6,000 |
| 335 | 1.3.4.4.4.4 | Device Control: User Interface Design | milestone | 0d? | 2008-04-01 | 2008-04-01 | 515d | Other |  |  |
| 336 | 1.3.4.4.4.5 | Device Control: Technical Specifications |  | 2.5d? | 2008-04-01 | 2008-04-03 | 512.5d | Other | 20h | 1,500 |
| 337 | 1.3.4.4.4.6 | Device Control: Compliance Matrix | milestone | 0d? | 2008-04-01 | 2008-04-01 | 515d | Other |  |  |
| 338 | 1.3.4.4.4.7 | Device Control: Test Plan | milestone | 0d? | 2008-04-01 | 2008-04-01 | 515d | Other |  |  |
| 339 | 1.3.4.4.4.8 | Device Control: Summary Report |  | 2.5d? | 2008-04-01 | 2008-04-03 | 512.5d | Other | 20h | 1,500 |

| ID | WBS | Task | Type | Duration | Start | Finish | Total slack | Resources | Work | Cost |
| --- | --- | --- | --- | --- | --- | --- | --- | --- | --- | --- |
| 340 | 1.3.4.4.5 | **AO Motion Control Electronics** |  | 12.5d? | 2008-04-01 | 2008-04-17 | 502.5d |  | 200h | 15,000 |
| 341 | 1.3.4.4.5.1 | Motion Control HW: Architecture Trade Study |  | 12.5d? | 2008-04-01 | 2008-04-17 | 502.5d | Wetherell | 100h | 7,500 |
| 342 | 1.3.4.4.5.2 | Motion Control HW: Electronics Specification & Selection |  | 1.25d? | 2008-04-01 | 2008-04-02 | 513.75d | Wetherell | 10h | 750 |
| 343 | 1.3.4.4.5.3 | Motion Control HW: Spreadsheet |  | 10d? | 2008-04-01 | 2008-04-14 | 505d | Wetherell | 80h | 6,000 |
| 344 | 1.3.4.4.5.4 | Motion Control HW: Compliance Matrix | milestone | 0d? | 2008-04-01 | 2008-04-01 | 515d | Wetherell |  |  |
| 345 | 1.3.4.4.5.5 | Motion Control HW: Test Plan | milestone | 0d? | 2008-04-01 | 2008-04-01 | 515d | Wetherell |  |  |
| 346 | 1.3.4.4.5.6 | Motion Control HW: Summary Report |  | 1.25d? | 2008-04-01 | 2008-04-02 | 513.75d | Wetherell | 10h | 750 |
| 347 | 1.3.4.4.6 | **Non-RTC Electronics** |  | 10d? | 2008-04-01 | 2008-04-14 | 505d |  | 140h | 10,500 |
| 348 | 1.3.4.4.6.1 | Non-RTC Electronics: Architecture |  | 10d? | 2008-04-01 | 2008-04-14 | 505d | Wetherell | 80h | 6,000 |
| 349 | 1.3.4.4.6.2 | Non-RTC Electronics: Specification & Selection |  | 5d? | 2008-04-01 | 2008-04-07 | 510d | Wetherell | 40h | 3,000 |
| 350 | 1.3.4.4.6.3 | Non-RTC Electronics: Compliance Matrix | milestone | 0d? | 2008-04-01 | 2008-04-01 | 515d | Wetherell |  |  |
| 351 | 1.3.4.4.6.4 | Non-RTC Electronics: Test Plan | milestone | 0d? | 2008-04-01 | 2008-04-01 | 515d | Wetherell |  |  |
| 352 | 1.3.4.4.6.5 | Non-RTC Electronics: Summary Report |  | 2.5d? | 2008-04-01 | 2008-04-03 | 512.5d | Wetherell | 20h | 1,500 |
| 353 | 1.3.4.4.7 | **Non-RTC System Integration & Test** |  | 2.5d? | 2008-04-01 | 2008-04-03 | 512.5d |  | 70h | 5,250 |
| 354 | 1.3.4.4.7.1 | Non-RTC I&T: Architecture |  | 2.5d? | 2008-04-01 | 2008-04-03 | 512.5d | Other; Wetherell | 40h | 3,000 |
| 355 | 1.3.4.4.7.2 | Non-RTC I&T: Electronics Specification & Selection | milestone | 0d? | 2008-04-01 | 2008-04-01 | 515d | Wetherell |  |  |
| 356 | 1.3.4.4.7.3 | Non-RTC I&T: Test Plan |  | 1.88d? | 2008-04-01 | 2008-04-02 | 513.12d | Other; Wetherell | 30h | 2,250 |
| 357 | 1.3.4.4.7.4 | Non-RTC I&T: Summary Report | milestone | 0d? | 2008-04-01 | 2008-04-01 | 515d | Other; Wetherell |  |  |
| 358 | 1.3.4.4.8 | **Acquisition, Guiding & Offload (AGO) Control** |  | 7.5d? | 2008-04-01 | 2008-04-10 | 507.5d |  | 160h | 12,000 |
| 359 | 1.3.4.4.8.1 | AGO: Architecture |  | 7.5d? | 2008-04-01 | 2008-04-10 | 507.5d | Johansson; Le Mignant | 80h | 6,000 |
| 360 | 1.3.4.4.8.2 | AGO: ICD |  | 5d? | 2008-04-01 | 2008-04-07 | 510d | Other | 40h | 3,000 |
| 361 | 1.3.4.4.8.3 | AGO: Software Module Design |  | 1.25d? | 2008-04-01 | 2008-04-02 | 513.75d | Other | 10h | 750 |
| 362 | 1.3.4.4.8.4 | AGO: User Interface | milestone | 0d? | 2008-04-01 | 2008-04-01 | 515d | Other |  |  |
| 363 | 1.3.4.4.8.5 | AGO: Technical Specification |  | 1.25d? | 2008-04-01 | 2008-04-02 | 513.75d | Other | 10h | 750 |
| 364 | 1.3.4.4.8.6 | AGO: Compliance Matrix | milestone | 0d? | 2008-04-01 | 2008-04-01 | 515d | Other |  |  |
| 365 | 1.3.4.4.8.7 | AGO: Test Plan | milestone | 0d? | 2008-04-01 | 2008-04-01 | 515d | Other |  |  |
| 366 | 1.3.4.4.8.8 | AGO: Summary Report |  | 2.5d? | 2008-04-01 | 2008-04-03 | 512.5d | Other | 20h | 1,500 |

| ID | WBS | Task | Duration | Start | Finish | Total slack | Resources | Work | Cost |
| --- | --- | --- | --- | --- | --- | --- | --- | --- | --- |
| 367 | 1.3.4.5 | **Real-time Control** | 10d? | 2008-04-01 | 2008-04-14 | 505d |  | 320h | 24,000 |
| 368 | 1.3.4.5.1 | **RTC Processor** | 1d? | 2008-04-01 | 2008-04-01 | 514d |  |  |  |
| 369 | 1.3.4.5.1.1 | RTC Technical Management | 1d? | 2008-04-01 | 2008-04-01 | 514d |  |  |  |
| 370 | 1.3.4.5.1.2 | Centroid/Wavefront Reconstruction Coding | 1d? | 2008-04-01 | 2008-04-01 | 514d |  |  |  |
| 371 | 1.3.4.5.1.3 | Centroid/Wavefront Reconstruction Testing | 1d? | 2008-04-01 | 2008-04-01 | 514d |  |  |  |
| 372 | 1.3.4.5.1.4 | Preconditioning & Scaling Coding | 1d? | 2008-04-01 | 2008-04-01 | 514d |  |  |  |
| 373 | 1.3.4.5.1.5 | Preconditioning & Scaling Testing | 1d? | 2008-04-01 | 2008-04-01 | 514d |  |  |  |
| 374 | 1.3.4.5.1.6 | Low Order WFS Code Design | 1d? | 2008-04-01 | 2008-04-01 | 514d |  |  |  |
| 375 | 1.3.4.5.1.7 | Low Order WFS Code Testing | 1d? | 2008-04-01 | 2008-04-01 | 514d |  |  |  |
| 376 | 1.3.4.5.1.8 | Layer Combining & DM Processing Coding | 1d? | 2008-04-01 | 2008-04-01 | 514d |  |  |  |
| 377 | 1.3.4.5.1.9 | Centroid Distance from Camera Issues | 1d? | 2008-04-01 | 2008-04-01 | 514d |  |  |  |
| 378 | 1.3.4.5.1.10 | Radial versus Rectilinear Voxels | 1d? | 2008-04-01 | 2008-04-01 | 514d |  |  |  |
| 379 | 1.3.4.5.1.11 | Define Required Bit Resolution | 1d? | 2008-04-01 | 2008-04-01 | 514d |  |  |  |
| 380 | 1.3.4.5.1.12 | Characterize SEU | 1d? | 2008-04-01 | 2008-04-01 | 514d |  |  |  |
| 381 | 1.3.4.5.1.13 | Power Characterization and Parameter Estimation | 1d? | 2008-04-01 | 2008-04-01 | 514d |  |  |  |
| 382 | 1.3.4.5.1.14 | Voxel Communication Parameters | 1d? | 2008-04-01 | 2008-04-01 | 514d |  |  |  |
| 383 | 1.3.4.5.1.15 | Diagnostic Control & I/O | 1d? | 2008-04-01 | 2008-04-01 | 514d |  |  |  |
| 384 | 1.3.4.5.1.16 | Monitoring Control & I/O | 1d? | 2008-04-01 | 2008-04-01 | 514d |  |  |  |
| 385 | 1.3.4.5.1.17 | Testing | 1d? | 2008-04-01 | 2008-04-01 | 514d |  |  |  |
| 386 | 1.3.4.5.1.18 | Documentation | 1d? | 2008-04-01 | 2008-04-01 | 514d |  |  |  |
| 387 | 1.3.4.5.2 | **DMs & Tip/Tilt Stages** | 10d? | 2008-04-01 | 2008-04-14 | 505d |  | 320h | 24,000 |
| 388 | 1.3.4.5.2.1 | **Woofer DM/TT** | 5d? | 2008-04-01 | 2008-04-07 | 510d |  | 132h | 9,900 |
| 389 | 1.3.4.5.2.1.1 | Define Requirements | 4d? | 2008-04-01 | 2008-04-04 | 511d | Gavel [50%] | 16h | 1,200 |
| 390 | 1.3.4.5.2.1.2 | Evaluate Tip/Tilt Mount Options | 5d? | 2008-04-01 | 2008-04-07 | 510d | Lockwood; Gavel [50%] | 44h | 3,300 |
| 391 | 1.3.4.5.2.1.3 | Evaluate Combined DM & Tip/Tilt Performance | 4d? | 2008-04-01 | 2008-04-04 | 511d | Gavel [50%] | 16h | 1,200 |
| 392 | 1.3.4.5.2.1.4 | Select Tip/Tilt Mount | 1d? | 2008-04-01 | 2008-04-01 | 514d | Gavel [50%]; Lockwood | 8h | 600 |
| 393 | 1.3.4.5.2.1.5 | Design Mechanical Package | 5d? | 2008-04-01 | 2008-04-07 | 510d | Lockwood | 40h | 3,000 |
| 394 | 1.3.4.5.2.1.6 | Obtain Quotes | 2d? | 2008-04-01 | 2008-04-02 | 513d | Lockwood [50%] | 8h | 600 |

| ID | WBS | Task | Duration | Start | Finish | Predecessors | Total slack | Free slack | Resources | Work | Cost |
| --- | --- | --- | --- | --- | --- | --- | --- | --- | --- | --- | --- |
| 395 | 1.3.4.5.2.2 | **Tweeter DM/TT** | 2.5d? | 2008-04-01 | 2008-04-03 |  | 512.5d |  |  | 48h | 3,600 |
| 396 | 1.3.4.5.2.2.1 | Define Requirements | 2d? | 2008-04-01 | 2008-04-02 |  | 513d |  | Gavel [50%] | 8h | 600 |
| 397 | 1.3.4.5.2.2.2 | Evaluate Options & Select Tip/Tilt Mount | 2.5d? | 2008-04-01 | 2008-04-03 |  | 512.5d |  | Lockwood; Gavel [50%] | 28h | 2,100 |
| 398 | 1.3.4.5.2.2.3 | Design Mechanical Package | 1d? | 2008-04-01 | 2008-04-01 |  | 514d |  | Lockwood | 8h | 600 |
| 399 | 1.3.4.5.2.2.4 | Obtain Quotes | 1d? | 2008-04-01 | 2008-04-01 |  | 514d |  | Gavel [50%] | 4h | 300 |
| 400 | 1.3.4.5.2.3 | **LOWFS DM/TT** | 10d? | 2008-04-01 | 2008-04-14 |  | 505d |  |  | 140h | 10,500 |
| 401 | 1.3.4.5.2.3.1 | Define Requirements including LOWFS Interface | 2.5d? | 2008-04-01 | 2008-04-03 |  | 512.5d |  | Gavel [50%]; Velur | 28h | 2,100 |
| 402 | 1.3.4.5.2.3.2 | Evaluate Options & Select Tip/Tilt Mount | 2.5d? | 2008-04-01 | 2008-04-03 |  | 512.5d |  | Lockwood; Gavel [50%] | 28h | 2,100 |
| 403 | 1.3.4.5.2.3.3 | Design Mechanical Package | 10d? | 2008-04-01 | 2008-04-14 |  | 505d |  | Lockwood | 80h | 6,000 |
| 404 | 1.3.4.5.2.3.4 | Obtain Quotes | 1d? | 2008-04-01 | 2008-04-01 |  | 514d |  | Gavel [50%] | 4h | 300 |
| 405 | 1.3.4.6 | **AO System Lab I&T** | 1d? | 2008-04-01 | 2008-04-01 |  | 514d |  |  | 200h | 15,000 |
| 406 | 1.3.4.6.1 | AO System Lab I&T Scope Definition | 1d? | 2008-04-01 | 2008-04-01 |  | 514d |  | Wizinowich [200%] | 16h | 1,200 |
| 407 | 1.3.4.6.2 | AO System Lab Facility Plan | 1d? | 2008-04-01 | 2008-04-01 |  | 514d |  | Neyman [300%] | 24h | 1,800 |
| 408 | 1.3.4.6.3 | AO System Lab Integration Plan | 1d? | 2008-04-01 | 2008-04-01 |  | 514d |  | Neyman [1000%] | 80h | 6,000 |
| 409 | 1.3.4.6.4 | AO System Lab Test Plan | 1d? | 2008-04-01 | 2008-04-01 |  | 514d |  | Neyman [1000%] | 80h | 6,000 |
| 410 | 1.3.5 | **Laser System Design** | 280d? | 2008-04-01 | 2009-04-27 |  | 235d |  |  | 2484h | 186,300 |
| 411 | 1.3.5.1 | **Laser Enclosure (LE)** | 5d? | 2008-04-01 | 2008-04-07 |  | 510d |  |  | 160h | 12,000 |
| 412 | 1.3.5.1.1 | LE Requirements & Interfaces | 2.5d? | 2008-04-01 | 2008-04-03 |  | 512.5d |  | Chin; Medeiros | 40h | 3,000 |
| 413 | 1.3.5.1.2 | LE Mechanical Design | 5d? | 2008-04-01 | 2008-04-07 |  | 510d |  | Chin; Medeiros | 50h | 3,750 |
| 414 | 1.3.5.1.3 | LE Environmental Control Design | 5d? | 2008-04-01 | 2008-04-07 |  | 510d |  | Chin; Nance | 50h | 3,750 |
| 415 | 1.3.5.1.4 | LE Assembly & Test Plans | 1d? | 2008-04-01 | 2008-04-01 |  | 514d |  | Chin; Nance; Medeiros | 20h | 1,500 |
| 416 | 5.2.3 | **Laser** | 280d? | 2008-04-01 | 2009-04-27 |  | 235d |  |  | 820h | 61,500 |
| 417 | 1.3.5.2.1 | Laser Project Management | 18.75d? | 2008-04-01 | 2008-04-25 |  | 496.25d |  | Adkins; Kissner | 300h | 22,500 |
| 418 | 5.2.3.1 | **Laser Requirements** | 110d | 2008-04-01 | 2008-09-01 |  | 235d |  |  | 160h | 12,000 |
| 419 | 5.2.3.1.1 | Laser Performance Analysis | 20d | 2008-04-01 | 2008-04-28 |  | 235d | 0d | Adkins [25%] | 40h | 3,000 |
| 420 | 5.2.3.1.2 | Laser Requirements Analysis | 20d | 2008-04-29 | 2008-05-26 | 419 | 235d | 0d | Adkins [25%] | 40h | 3,000 |
| 421 | 5.2.3.1.3 | Laser Requirements Development | 20d | 2008-05-27 | 2008-06-23 | 420 | 235d | 0d | Adkins [25%] | 40h | 3,000 |
| 422 | 5.2.3.1.4 | Laser Requirements Drafting and Revisions | 50d | 2008-06-24 | 2008-09-01 | 421 | 235d | 0d | Adkins [10%] | 40h | 3,000 |

Notes:
- 411: JC
- 412: JC
- 413: DM
- 414: CN
- 415: JC
- 416: SA
- 417: SA
- 418: SA

| ID | WBS | Task | Duration | Start | Finish | Predecessors | Total slack | Free slack | Resources | Work | Cost |
| --- | --- | --- | --- | --- | --- | --- | --- | --- | --- | --- | --- |
| 423 | 5.2.3.2 | **Laser Preliminary ICD** | 20d | 2008-06-24 | 2008-07-21 |  | 435d |  |  | 40h | 3,000 |
| 424 | 5.2.3.2.1 | Laser ICD Drafting and Revisions | 20d | 2008-06-24 | 2008-07-21 | 421 | 435d |  | Adkins [25%] | 40h | 3,000 |
| 425 | 5.2.3.3 | **Laser Request for Proposals (RFP)** | 90d | 2008-09-02 | 2009-01-05 |  | 235d |  |  | 120h | 9,000 |
| 426 | 5.2.3.3.1 | Laser Proposal Drafting | 20d | 2008-09-02 | 2008-09-29 | 422 | 235d | 0d | Adkins [25%] | 40h | 3,000 |
| 427 | 5.2.3.3.2 | Laser Proposal Release | 10d | 2008-09-30 | 2008-10-13 | 426 | 235d | 0d | Adkins [25%]; Kissner [30%] | 40h | 3,000 |
| 428 | 5.2.3.3.3 | Laser Proposal Response Period | 3mo | 2008-10-14 | 2009-01-05 | 427 | 235d | 0d | Adkins [3.3%]; Kissner [5%] | 40h | 3,000 |
| 429 | 5.2.3.4 | **Laser RFP Response Report** | 40d | 2009-01-06 | 2009-03-02 |  | 235d |  |  | 120h | 9,000 |
| 430 | 5.2.3.4.1 | Laser Proposal Evaluation | 20d | 2009-01-06 | 2009-02-02 | 428 | 235d | 0d | Adkins [25%] | 40h | 3,000 |
| 431 | 5.2.3.4.2 | Laser Response Discussions | 20d | 2009-02-03 | 2009-03-02 | 430 | 275d |  | Adkins [25%] | 40h | 3,000 |
| 432 | 5.2.3.4.3 | Laser Report Drafting and Revisions | 20d | 2009-02-03 | 2009-03-02 | 430 | 235d | 0d | Adkins [25%] | 40h | 3,000 |
| 433 | 5.2.3.5 | **Laser Contract** | 40d | 2009-03-03 | 2009-04-27 |  | 235d |  |  | 80h | 6,000 |
| 434 | 5.2.3.5.1 | Laser Contract Drafting and Revisions | 20d | 2009-03-03 | 2009-03-30 | 432 | 235d | 0d | Adkins [25%] | 40h | 3,000 |
| 435 | 5.2.3.5.2 | Laser Contract Negotiations | 20d | 2009-03-31 | 2009-04-27 | 434 | 235d |  | Adkins [25%] | 40h | 3,000 |
| 436 | 1.3.5.3 | **Laser Launch Facility (LLF)** | 25d? | 2008-04-01 | 2008-05-05 |  | 490d |  |  | 856h | 64,200 |
| 437 | 1.3.5.3.1 | LLF Requirements & Interfaces | 10d? | 2008-04-01 | 2008-04-14 |  | 505d |  | Neyman; Chin | 100h | 7,500 |
| 438 | 1.3.5.3.2 | LLF Optical Design | 25d? | 2008-04-01 | 2008-05-05 |  | 490d |  | Neyman; Other | 260h | 19,500 |
| 439 | 1.3.5.3.3 | LLF Launch Telescope Preliminary Design Contract | 7.5d? | 2008-04-01 | 2008-04-10 |  | 507.5d |  | Neyman; Chin; Other | 96h | 7,200 |
| 440 | 1.3.5.3.4 | LLF Mechanical Design | 25d? | 2008-04-01 | 2008-05-05 |  | 490d |  | Neyman; Medeiros | 220h | 16,500 |
| 441 | 1.3.5.3.5 | LLF Electrical Design | 12.5d? | 2008-04-01 | 2008-04-17 |  | 502.5d |  | Neyman; Wetherell | 120h | 9,000 |
| 442 | 1.3.5.3.6 | LLF Assembly, Alignment & Test Plans | 6.25d? | 2008-04-01 | 2008-04-09 |  | 508.75d |  | Neyman; Chin | 60h | 4,500 |
| 443 | 1.3.5.4 | **Laser Safety Systems** | 5d? | 2008-04-01 | 2008-04-07 |  | 510d |  |  | 170h | 12,750 |
| 444 | 1.3.5.4.1 | **Personnel & Equipment Safety System** | 5d? | 2008-04-01 | 2008-04-07 |  | 510d |  |  | 130h | 9,750 |
| 445 | 1.3.5.4.1.1 | Safety Requirements & Interfaces | 5d? | 2008-04-01 | 2008-04-07 |  | 510d |  | Chin | 40h | 3,000 |
| 446 | 1.3.5.4.1.2 | Safety Algorithms, Diagrams & Dataflow | 2.5d? | 2008-04-01 | 2008-04-03 |  | 512.5d |  | Other | 20h | 1,500 |
| 447 | 1.3.5.4.1.3 | Safety Communication Protocols & Methods | 2.5d? | 2008-04-01 | 2008-04-03 |  | 512.5d |  | Other | 20h | 1,500 |
| 448 | 1.3.5.4.1.4 | Safety Performance Estimate | 2.5d? | 2008-04-01 | 2008-04-03 |  | 512.5d |  | Other | 20h | 1,500 |
| 449 | 1.3.5.4.1.5 | Safety Electronics, Shutter & Interlocks | 1.25d? | 2008-04-01 | 2008-04-02 |  | 513.75d |  | Other | 10h | 750 |
| 450 | 1.3.5.4.1.6 | Safety Test Plans | 1.25d? | 2008-04-01 | 2008-04-02 |  | 513.75d |  | Chin; Other | 20h | 1,500 |

Notes:
- 423: SA
- 425: SA
- 429: SA
- 433: SA
- 436: CN
- 444: JC

| ID | WBS | Task | Duration | Start | Finish | Total slack | Resources | Work | Cost |
| --- | --- | --- | --- | --- | --- | --- | --- | --- | --- |
| 451 | 1.3.5.4.2 | **Laser Traffic Control System (LTCS) Modifications** | 1d? | 2008-04-01 | 2008-04-01 | 514d |  | 40h | 3,000 |
| 452 | 1.3.5.4.2.1 | LTCS Requirements & Interfaces | 1d? | 2008-04-01 | 2008-04-01 | 514d | Summers | 8h | 600 |
| 453 | 1.3.5.4.2.2 | LTCS Algorithms, Diagrams & Dataflow | 1d? | 2008-04-01 | 2008-04-01 | 514d | Summers | 8h | 600 |
| 454 | 1.3.5.4.2.3 | LTCS Communication Protocols & Methods | 1d? | 2008-04-01 | 2008-04-01 | 514d | Summers | 8h | 600 |
| 455 | 1.3.5.4.2.4 | LTCS Performance Estimate | 1d? | 2008-04-01 | 2008-04-01 | 514d | Summers | 8h | 600 |
| 456 | 1.3.5.4.2.5 | LTCS Test Plans | 1d? | 2008-04-01 | 2008-04-01 | 514d | Summers | 8h | 600 |
| 457 | 1.3.5.5 | **Laser System Control (LSC)** | 10d? | 2008-04-01 | 2008-04-14 | 505d |  | 430h | 32,250 |
| 458 | 1.3.5.5.1 | LSC Requirements & Interfaces | 1d? | 2008-04-01 | 2008-04-01 | 514d |  |  |  |
| 459 | 1.3.5.5.2 | **LSC Software** | 10d? | 2008-04-01 | 2008-04-14 | 505d |  | 220h | 16,500 |
| 460 | 1.3.5.5.2.1 | LSC Software Requirements & Interfaces | 3.75d? | 2008-04-01 | 2008-04-04 | 511.25d | Other; Neyman; Chin | 60h | 4,500 |
| 461 | 1.3.5.5.2.2 | LSC Sequencer Software | 10d? | 2008-04-01 | 2008-04-14 | 505d | Other | 80h | 6,000 |
| 462 | 1.3.5.5.2.3 | LSC Motion Control Software | 5d? | 2008-04-01 | 2008-04-07 | 510d | Other | 40h | 3,000 |
| 463 | 1.3.5.5.2.4 | LSC Device Control Software | 5d? | 2008-04-01 | 2008-04-07 | 510d | Other | 40h | 3,000 |
| 464 | 1.3.5.5.3 | **LSC Hardware** | 10d? | 2008-04-01 | 2008-04-14 | 505d |  | 210h | 15,750 |
| 465 | 1.3.5.5.3.1 | LSC Hardware Requirements & Interfaces | 3.75d? | 2008-04-01 | 2008-04-04 | 511.25d | Neyman; Wetherell; Chin | 60h | 4,500 |
| 466 | 1.3.5.5.3.2 | LSC Motion Control Hardware | 10d? | 2008-04-01 | 2008-04-14 | 505d | Wetherell | 80h | 6,000 |
| 467 | 1.3.5.5.3.3 | LSC Device Control Hardware | 8.75d? | 2008-04-01 | 2008-04-11 | 506.25d | Wetherell | 70h | 5,250 |
| 468 | 1.3.5.6 | Laser System Lab I&T Plan | 4d? | 2008-04-01 | 2008-04-04 | 511d | Neyman; Chin; Nance | 48h | 3,600 |
| 469 | 1.3.6 | **Science Operations Tools Design** | 5d? | 2008-04-01 | 2008-04-07 | 510d |  | 1800h | 135,000 |
| 470 | 1.3.6.1 | **Multi-Systems Command Sequencer (MCS)** | 5d? | 2008-04-01 | 2008-04-07 | 510d |  | 620h | 46,500 |
| 471 | 1.3.6.1.1 | **MCS Infrastructure** | 5d? | 2008-04-01 | 2008-04-07 | 510d |  | 180h | 13,500 |
| 472 | 1.3.6.1.1.1 | **MCS Infrastructure Architecture** | 5d? | 2008-04-01 | 2008-04-07 | 510d |  | 140h | 10,500 |
| 473 | 1.3.6.1.1.1.1 | MCS Architecture | 3.75d? | 2008-04-01 | 2008-04-04 | 511.25d | Johansson; Le Mignant | 40h | 3,000 |
| 474 | 1.3.6.1.1.1.2 | MCS Operations Concept Document | 5d? | 2008-04-01 | 2008-04-07 | 510d | Johansson | 40h | 3,000 |
| 475 | 1.3.6.1.1.1.3 | MCS Software Requirements | 5d? | 2008-04-01 | 2008-04-07 | 510d | Johansson | 40h | 3,000 |
| 476 | 1.3.6.1.1.1.4 | MCS Module Definitions | 2.5d? | 2008-04-01 | 2008-04-03 | 512.5d | Johansson | 20h | 1,500 |

Notes:
- 451: DS
- 469: DLM

| ID | WBS | Task | Duration | Start | Finish | Total slack | Resources | Work | Cost |
| --- | --- | --- | --- | --- | --- | --- | --- | --- | --- |
| 477 | 1.3.6.1.1.2 | **Coordination Sequence Support Library** | 2.5d? | 2008-04-01 | 2008-04-03 | 512.5d |  | 20h | 1,500 |
| 478 | 1.3.6.1.1.2.1 | Functional Requirements | 2.5d? | 2008-04-01 | 2008-04-03 | 512.5d | Johansson | 20h | 1,500 |
| 479 | 1.3.6.1.1.2.2 | Interface Definitions | 1d? | 2008-04-01 | 2008-04-01 | 514d |  |  |  |
| 480 | 1.3.6.1.1.3 | **Command Interface** | 1.25d? | 2008-04-01 | 2008-04-02 | 513.75d |  | 10h | 750 |
| 481 | 1.3.6.1.1.3.1 | Functional Requirements | 1.25d? | 2008-04-01 | 2008-04-02 | 513.75d | Johansson | 10h | 750 |
| 482 | 1.3.6.1.1.3.2 | Interface Definitions | 1d? | 2008-04-01 | 2008-04-01 | 514d |  |  |  |
| 483 | 1.3.6.1.1.4 | **System Health** | 1.25d? | 2008-04-01 | 2008-04-02 | 513.75d |  | 10h | 750 |
| 484 | 1.3.6.1.1.4.1 | Functional Requirements | 1.25d? | 2008-04-01 | 2008-04-02 | 513.75d | Johansson | 10h | 750 |
| 485 | 1.3.6.1.1.4.2 | Interface Definitions | 1d? | 2008-04-01 | 2008-04-01 | 514d |  |  |  |
| 486 | 1.3.6.1.2 | **Setup Sequences: Configuration & Calibration** | 1d? | 2008-04-01 | 2008-04-01 | 514d |  | 100h | 7,500 |
| 487 | 1.3.6.1.2.1 | **Setup Sequences Common Structure** | 1d? | 2008-04-01 | 2008-04-01 | 514d |  | 60h | 4,500 |
| 488 | 1.3.6.1.2.1.1 | Setup Sequences Operations Concept Document | 1d? | 2008-04-01 | 2008-04-01 | 514d | Johansson [250%] | 20h | 1,500 |
| 489 | 1.3.6.1.2.1.2 | Setup Sequences Software Requirements | 1d? | 2008-04-01 | 2008-04-01 | 514d | Johansson [250%] | 20h | 1,500 |
| 490 | 1.3.6.1.2.1.3 | Setup Sequences Module Definitions | 1d? | 2008-04-01 | 2008-04-01 | 514d | Johansson [250%] | 20h | 1,500 |
| 491 | 1.3.6.1.2.2 | **Configuration Sequences** | 1d? | 2008-04-01 | 2008-04-01 | 514d |  | 20h | 1,500 |
| 492 | 1.3.6.1.2.2.1 | Functional Requirements | 1d? | 2008-04-01 | 2008-04-01 | 514d | Le Mignant [250%] | 20h | 1,500 |
| 493 | 1.3.6.1.2.2.2 | Interface Definitions | 1d? | 2008-04-01 | 2008-04-01 | 514d |  |  |  |
| 494 | 1.3.6.1.2.3 | **Calibration Sequences** | 1d? | 2008-04-01 | 2008-04-01 | 514d |  | 20h | 1,500 |
| 495 | 1.3.6.1.2.3.1 | Functional Requirements | 1d? | 2008-04-01 | 2008-04-01 | 514d | Le Mignant [250%] | 20h | 1,500 |
| 496 | 1.3.6.1.2.3.2 | Interface Definitions | 1d? | 2008-04-01 | 2008-04-01 | 514d |  |  |  |
| 497 | 1.3.6.1.3 | **Observing Sequences** | 2.5d? | 2008-04-01 | 2008-04-03 | 512.5d |  | 240h | 18,000 |
| 498 | 1.3.6.1.3.1 | **Observing Sequences Common Structure** | 2.5d? | 2008-04-01 | 2008-04-03 | 512.5d |  | 120h | 9,000 |
| 499 | 1.3.6.1.3.1.1 | Observing Sequences Operations Concept Document | 1.25d? | 2008-04-01 | 2008-04-02 | 513.75d | Le Mignant [500%]; Johansson | 40h | 3,000 |
| 500 | 1.3.6.1.3.1.2 | Observing Sequences Software Requirements | 1d? | 2008-04-01 | 2008-04-01 | 514d | Johansson [500%] | 40h | 3,000 |
| 501 | 1.3.6.1.3.1.3 | Observing Sequences Module Definitions | 2.5d? | 2008-04-01 | 2008-04-03 | 512.5d | Johansson [500%]; Le Mignant | 40h | 3,000 |

| ID | WBS | Task | Duration | Start | Finish | Total slack | Resources | Work | Cost |
| --- | --- | --- | --- | --- | --- | --- | --- | --- | --- |
| 502 | 1.3.6.1.3.2 | **Acquisition Sequences** | 1.25d? | 2008-04-01 | 2008-04-02 | 513.75d |  | 60h | 4,500 |
| 503 | 1.3.6.1.3.2.1 | Functional Requirements | 1.25d? | 2008-04-01 | 2008-04-02 | 513.75d | Le Mignant [500%]; Johansson | 40h | 3,000 |
| 504 | 1.3.6.1.3.2.2 | Interface Definitions | 1d? | 2008-04-01 | 2008-04-01 | 514d | Johansson [250%] | 20h | 1,500 |
| 505 | 1.3.6.1.3.3 | **Observing Sequences** | 1d? | 2008-04-01 | 2008-04-01 | 514d |  | 20h | 1,500 |
| 506 | 1.3.6.1.3.3.1 | Functional Requirements | 0.5d? | 2008-04-01 | 2008-04-01 | 514.5d | Le Mignant [500%] | 20h | 1,500 |
| 507 | 1.3.6.1.3.3.2 | Interface Definitions | 1d? | 2008-04-01 | 2008-04-01 | 514d |  |  |  |
| 508 | 1.3.6.1.3.4 | **Quality Monitoring Sequences** | 2.5d? | 2008-04-01 | 2008-04-03 | 512.5d |  | 20h | 1,500 |
| 509 | 1.3.6.1.3.4.1 | Functional Requirements | 2.5d? | 2008-04-01 | 2008-04-03 | 512.5d | Le Mignant | 20h | 1,500 |
| 510 | 1.3.6.1.3.4.2 | Interface Definitions | 1d? | 2008-04-01 | 2008-04-01 | 514d |  |  |  |
| 511 | 1.3.6.1.3.5 | **Optimization Sequences** | 1d? | 2008-04-01 | 2008-04-01 | 514d |  | 20h | 1,500 |
| 512 | 1.3.6.1.3.5.1 | Functional Requirements | 1d? | 2008-04-01 | 2008-04-01 | 514d | Le Mignant [250%] | 20h | 1,500 |
| 513 | 1.3.6.1.3.5.2 | Interface Definitions | 1d? | 2008-04-01 | 2008-04-01 | 514d |  |  |  |
| 514 | 1.3.6.1.4 | **Alarm Handler & Troubleshooting Sequences** | 2.5d? | 2008-04-01 | 2008-04-03 | 512.5d |  | 100h | 7,500 |
| 515 | 1.3.6.1.4.1 | **Alarm Handler & Troubleshooting Common Structure** | 2.5d? | 2008-04-01 | 2008-04-03 | 512.5d |  | 100h | 7,500 |
| 516 | 1.3.6.1.4.1.1 | Alarm & Troubleshooting Operations Concept Document | 1.25d? | 2008-04-01 | 2008-04-02 | 513.75d | Le Mignant [500%]; Johansson | 40h | 3,000 |
| 517 | 1.3.6.1.4.1.2 | Alarm & Troubleshooting Software Requirements | 0.5d? | 2008-04-01 | 2008-04-01 | 514.5d | Johansson [500%] | 20h | 1,500 |
| 518 | 1.3.6.1.4.1.3 | Alarm & Troubleshooting Module Definitions | 2.5d? | 2008-04-01 | 2008-04-03 | 512.5d | Johansson [250%]; Le Mignant | 40h | 3,000 |
| 519 | 1.3.6.1.4.2 | **Alarm Handler Sequences** | 1d? | 2008-04-01 | 2008-04-01 | 514d |  |  |  |
| 520 | 1.3.6.1.4.2.1 | Functional Requirements | 1d? | 2008-04-01 | 2008-04-01 | 514d |  |  |  |
| 521 | 1.3.6.1.4.2.2 | Interface Definitions | 1d? | 2008-04-01 | 2008-04-01 | 514d |  |  |  |
| 522 | 1.3.6.1.4.3 | **Troubleshooting Sequences** | 1d? | 2008-04-01 | 2008-04-01 | 514d |  |  |  |
| 523 | 1.3.6.1.4.3.1 | Functional Requirements | 1d? | 2008-04-01 | 2008-04-01 | 514d |  |  |  |
| 524 | 1.3.6.1.4.3.2 | Interface Definitions | 1d? | 2008-04-01 | 2008-04-01 | 514d |  |  |  |
| 525 | 1.3.6.2 | **User Interfaces** | 5d? | 2008-04-01 | 2008-04-07 | 510d |  | 500h | 37,500 |
| 526 | 1.3.6.2.1 | **User Interface (UI) Infrastructure** | 4.38d? | 2008-04-01 | 2008-04-07 | 510.62d |  | 180h | 13,500 |
| 527 | 1.3.6.2.1.1 | **UI Infrastructure Architecture** | 4.38d? | 2008-04-01 | 2008-04-07 | 510.62d |  | 120h | 9,000 |
| 528 | 1.3.6.2.1.1.1 | UI Architecture | 4.38d? | 2008-04-01 | 2008-04-07 | 510.62d | Johansson; Le Mignant | 40h | 3,000 |
| 529 | 1.3.6.2.1.1.2 | UI Operations Concept Document | 2.5d? | 2008-04-01 | 2008-04-03 | 512.5d | Le Mignant; Johansson | 40h | 3,000 |
| 530 | 1.3.6.2.1.1.3 | UI Software Requirements | 2.5d? | 2008-04-01 | 2008-04-03 | 512.5d | Johansson | 20h | 1,500 |
| 531 | 1.3.6.2.1.1.4 | UI Module Definitions | 1d? | 2008-04-01 | 2008-04-01 | 514d | Johansson [250%] | 20h | 1,500 |

| ID | WBS | Task | Duration | Start | Finish | Total slack | Resources | Work | Cost |
| --- | --- | --- | --- | --- | --- | --- | --- | --- | --- |
| 532 | 1.3.6.2.1.2 | **UI Command Interface to MCS** | 2.5d? | 2008-04-01 | 2008-04-03 | 512.5d |  | 40h | 3,000 |
| 533 | 1.3.6.2.1.2.1 | Functional Requirements | 2.5d? | 2008-04-01 | 2008-04-03 | 512.5d | Johansson | 20h | 1,500 |
| 534 | 1.3.6.2.1.2.2 | Interface Definitions | 2.5d? | 2008-04-01 | 2008-04-03 | 512.5d | Johansson | 20h | 1,500 |
| 535 | 1.3.6.2.1.3 | **UI Command Interface to Pre- & Post-Observing Tools** | 2.5d? | 2008-04-01 | 2008-04-03 | 512.5d |  | 20h | 1,500 |
| 536 | 1.3.6.2.1.3.1 | Functional Requirements | 2.5d? | 2008-04-01 | 2008-04-03 | 512.5d | Johansson | 20h | 1,500 |
| 537 | 1.3.6.2.1.3.2 | Interface Definitions | 1d? | 2008-04-01 | 2008-04-01 | 514d |  |  |  |
| 538 | 1.3.6.2.2 | **Setup User Interfaces** | 2.5d? | 2008-04-01 | 2008-04-03 | 512.5d |  | 80h | 6,000 |
| 539 | 1.3.6.2.2.1 | **Setup UI Common Structure** | 2.5d? | 2008-04-01 | 2008-04-03 | 512.5d |  | 50h | 3,750 |
| 540 | 1.3.6.2.2.1.1 | Setup UI Operations Concept Document | 2.5d? | 2008-04-01 | 2008-04-03 | 512.5d | Le Mignant | 20h | 1,500 |
| 541 | 1.3.6.2.2.1.2 | Setup UI Software Requirements | 1.25d? | 2008-04-01 | 2008-04-02 | 513.75d | Johansson | 10h | 750 |
| 542 | 1.3.6.2.2.1.3 | Setup UI Module Definitions | 2.5d? | 2008-04-01 | 2008-04-03 | 512.5d | Johansson | 20h | 1,500 |
| 543 | 1.3.6.2.2.2 | **Setup UI Configurations** | 1.88d? | 2008-04-01 | 2008-04-02 | 513.12d |  | 15h | 1,125 |
| 544 | 1.3.6.2.2.2.1 | Functional Requirements | 1.88d? | 2008-04-01 | 2008-04-02 | 513.12d | Le Mignant | 15h | 1,125 |
| 545 | 1.3.6.2.2.2.2 | Interface Definitions | 1d? | 2008-04-01 | 2008-04-01 | 514d |  |  |  |
| 546 | 1.3.6.2.2.3 | **Setup UI Calibrations** | 1.88d? | 2008-04-01 | 2008-04-02 | 513.12d |  | 15h | 1,125 |
| 547 | 1.3.6.2.2.3.1 | Functional Requirements | 1.88d? | 2008-04-01 | 2008-04-02 | 513.12d | Le Mignant | 15h | 1,125 |
| 548 | 1.3.6.2.2.3.2 | Interface Definitions | 1d? | 2008-04-01 | 2008-04-01 | 514d |  |  |  |
| 549 | 1.3.6.2.3 | **Observations User Interfaces** | 5d? | 2008-04-01 | 2008-04-07 | 510d |  | 240h | 18,000 |
| 550 | 1.3.6.2.3.1 | **Observations UI Common Structure** | 5d? | 2008-04-01 | 2008-04-07 | 510d |  | 130h | 9,750 |
| 551 | 1.3.6.2.3.1.1 | Observations UI Operations Concept Document | 3.75d? | 2008-04-01 | 2008-04-04 | 511.25d | Le Mignant; Johansson | 40h | 3,000 |
| 552 | 1.3.6.2.3.1.2 | Observations UI Software Requirements | 1.25d? | 2008-04-01 | 2008-04-02 | 513.75d | Johansson | 10h | 750 |
| 553 | 1.3.6.2.3.1.3 | Observations UI Module Definitions | 5d? | 2008-04-01 | 2008-04-07 | 510d | Johansson; Le Mignant | 80h | 6,000 |
| 554 | 1.3.6.2.3.2 | **Acquisition & AO Control UI** | 2.5d? | 2008-04-01 | 2008-04-03 | 512.5d |  | 30h | 2,250 |
| 555 | 1.3.6.2.3.2.1 | Functional Requirements | 2.5d? | 2008-04-01 | 2008-04-03 | 512.5d | Le Mignant | 20h | 1,500 |
| 556 | 1.3.6.2.3.2.2 | Interface Definitions | 1.25d? | 2008-04-01 | 2008-04-02 | 513.75d | Johansson | 10h | 750 |

| ID | WBS | Task | Type | Duration | Start | Finish | Total slack | Resources | Work | Cost |
| --- | --- | --- | --- | --- | --- | --- | --- | --- | --- | --- |
| 557 | 1.3.6.2.3.3 | **Observing Sequences UI** |  | 2.5d? | 2008-04-01 | 2008-04-03 | 512.5d |  | 20h | 1,500 |
| 558 | 1.3.6.2.3.3.1 | Functional Requirements |  | 2.5d? | 2008-04-01 | 2008-04-03 | 512.5d | Le Mignant | 20h | 1,500 |
| 559 | 1.3.6.2.3.3.2 | Interface Definitions |  | 1d? | 2008-04-01 | 2008-04-01 | 514d |  |  |  |
| 560 | 1.3.6.2.3.4 | **Status & Graph UI** |  | 2.5d? | 2008-04-01 | 2008-04-03 | 512.5d |  | 20h | 1,500 |
| 561 | 1.3.6.2.3.4.1 | Functional Requirements |  | 2.5d? | 2008-04-01 | 2008-04-03 | 512.5d | Le Mignant | 20h | 1,500 |
| 562 | 1.3.6.2.3.4.2 | Interface Definitions |  | 1d? | 2008-04-01 | 2008-04-01 | 514d |  |  |  |
| 563 | 1.3.6.2.3.5 | **Advanced Monitoring UI** |  | 2.5d? | 2008-04-01 | 2008-04-03 | 512.5d |  | 20h | 1,500 |
| 564 | 1.3.6.2.3.5.1 | Functional Requirements |  | 2.5d? | 2008-04-01 | 2008-04-03 | 512.5d | Le Mignant | 20h | 1,500 |
| 565 | 1.3.6.2.3.5.2 | Interface Definitions |  | 1d? | 2008-04-01 | 2008-04-01 | 514d |  |  |  |
| 566 | 1.3.6.2.3.6 | **Optimization & Troubleshooting UI** |  | 2.5d? | 2008-04-01 | 2008-04-03 | 512.5d |  | 20h | 1,500 |
| 567 | 1.3.6.2.3.6.1 | Functional Requirements |  | 2.5d? | 2008-04-01 | 2008-04-03 | 512.5d | Le Mignant | 20h | 1,500 |
| 568 | 1.3.6.2.3.6.2 | Interface Definitions |  | 1d? | 2008-04-01 | 2008-04-01 | 514d |  |  |  |
| 569 | 1.3.6.3 | **Pre- & Post-Observing Science Support Tools** |  | 5d? | 2008-04-01 | 2008-04-07 | 510d |  | 610h | 45,750 |
| 570 | 1.3.6.3.1 | **User Documentation** |  | 1.25d? | 2008-04-01 | 2008-04-02 | 513.75d |  | 20h | 1,500 |
| 571 | 1.3.6.3.1.1 | User Documentation Operations Concept |  | 1.25d? | 2008-04-01 | 2008-04-02 | 513.75d | Le Mignant | 10h | 750 |
| 572 | 1.3.6.3.1.2 | User Documentation Functional Requirements |  | 1d? | 2008-04-01 | 2008-04-01 | 514d | Le Mignant [125%] | 10h | 750 |
| 573 | 1.3.6.3.2 | **Science Observations Planning Tools** |  | 5d? | 2008-04-01 | 2008-04-07 | 510d |  | 340h | 25,500 |
| 574 | 1.3.6.3.2.1 | **NGS Star Finder** |  | 5d? | 2008-04-01 | 2008-04-07 | 510d |  | 60h | 4,500 |
| 575 | 1.3.6.3.2.1.1 | Operations Concept |  | 2.5d? | 2008-04-01 | 2008-04-03 | 512.5d | Le Mignant | 20h | 1,500 |
| 576 | 1.3.6.3.2.1.2 | Functional Requirements & Use Case Definitions |  | 5d? | 2008-04-01 | 2008-04-07 | 510d | Le Mignant | 40h | 3,000 |
| 577 | 1.3.6.3.2.1.3 | Interface Definitions | milestone | 0d? | 2008-04-01 | 2008-04-01 | 515d |  |  |  |
| 578 | 1.3.6.3.2.1.4 | Module Definitions | milestone | 0d? | 2008-04-01 | 2008-04-01 | 515d |  |  |  |
| 579 | 1.3.6.3.2.2 | **Performance Prediction Tool** |  | 5d? | 2008-04-01 | 2008-04-07 | 510d |  | 140h | 10,500 |
| 580 | 1.3.6.3.2.2.1 | Operations Concept |  | 5d? | 2008-04-01 | 2008-04-07 | 510d | Le Mignant | 40h | 3,000 |
| 581 | 1.3.6.3.2.2.2 | Functional Requirements & Use Case Definitions |  | 5d? | 2008-04-01 | 2008-04-07 | 510d | Le Mignant | 40h | 3,000 |
| 582 | 1.3.6.3.2.2.3 | Interface Definitions |  | 2.5d? | 2008-04-01 | 2008-04-03 | 512.5d | Johansson | 20h | 1,500 |
| 583 | 1.3.6.3.2.2.4 | Module Definitions |  | 2.5d? | 2008-04-01 | 2008-04-03 | 512.5d | Johansson; Le Mignant | 40h | 3,000 |

| ID | WBS | Task | Duration | Start | Finish | Total slack | Resources | Work | Cost |
| --- | --- | --- | --- | --- | --- | --- | --- | --- | --- |
| 584 | 1.3.6.3.2.3 | **Observation Planning & Efficiency Tool** | 5d? | 2008-04-01 | 2008-04-07 | 510d |  | 140h | 10,500 |
| 585 | 1.3.6.3.2.3.1 | Operations Concept | 5d? | 2008-04-01 | 2008-04-07 | 510d | Le Mignant | 40h | 3,000 |
| 586 | 1.3.6.3.2.3.2 | Functional Requirements & Use Case Definitions | 5d? | 2008-04-01 | 2008-04-07 | 510d | Le Mignant | 40h | 3,000 |
| 587 | 1.3.6.3.2.3.3 | Interface Definitions | 2.5d? | 2008-04-01 | 2008-04-03 | 512.5d | Johansson | 20h | 1,500 |
| 588 | 1.3.6.3.2.3.4 | Module Definitions | 2.5d? | 2008-04-01 | 2008-04-03 | 512.5d | Johansson; Le Mignant | 40h | 3,000 |
| 589 | 1.3.6.3.2.4 | **Laser Clearinghouse Coordination Tool** | 2.5d? | 2008-04-01 | 2008-04-03 | 512.5d |  |  |  |
| 590 | 1.3.6.3.2.4.1 | Operations Concept | 2.5d? | 2008-04-01 | 2008-04-03 | 512.5d |  |  |  |
| 591 | 1.3.6.3.2.4.2 | Functional Requirements & Use Case Definitions | 2.5d? | 2008-04-01 | 2008-04-03 | 512.5d |  |  |  |
| 592 | 1.3.6.3.2.4.3 | Interface Definitions | 1d? | 2008-04-01 | 2008-04-01 | 514d |  |  |  |
| 593 | 1.3.6.3.2.4.4 | Module Definitions | 1d? | 2008-04-01 | 2008-04-01 | 514d |  |  |  |
| 594 | 1.3.6.3.3 | **Data Products** | 5d? | 2008-04-01 | 2008-04-07 | 510d |  | 250h | 18,750 |
| 595 | 1.3.6.3.3.1 | **Generic Data Products** | 5d? | 2008-04-01 | 2008-04-07 | 510d |  | 80h | 6,000 |
| 596 | 1.3.6.3.3.1.1 | Operations Concept | 2.5d? | 2008-04-01 | 2008-04-03 | 512.5d | Le Mignant | 20h | 1,500 |
| 597 | 1.3.6.3.3.1.2 | Functional Requirements & Use Case Definitions | 5d? | 2008-04-01 | 2008-04-07 | 510d | Le Mignant | 40h | 3,000 |
| 598 | 1.3.6.3.3.1.3 | Interface Definitions | 2.5d? | 2008-04-01 | 2008-04-03 | 512.5d | Johansson | 20h | 1,500 |
| 599 | 1.3.6.3.3.2 | **Science Data Quality Assessment** | 5d? | 2008-04-01 | 2008-04-07 | 510d |  | 160h | 12,000 |
| 600 | 1.3.6.3.3.2.1 | **Quality Metrics & Logged Information** | 5d? | 2008-04-01 | 2008-04-07 | 510d |  | 80h | 6,000 |
| 601 | 1.3.6.3.3.2.1.1 | Operations Concept | 5d? | 2008-04-01 | 2008-04-07 | 510d | Le Mignant | 40h | 3,000 |
| 602 | 1.3.6.3.3.2.1.2 | Functional Requirements & Use Case Definitions | 5d? | 2008-04-01 | 2008-04-07 | 510d | Le Mignant | 40h | 3,000 |
| 603 | 1.3.6.3.3.2.1.3 | Interface Definitions | 1d? | 2008-04-01 | 2008-04-01 | 514d |  |  |  |
| 604 | 1.3.6.3.3.2.2 | **PSF Calibration** | 5d? | 2008-04-01 | 2008-04-07 | 510d |  | 80h | 6,000 |
| 605 | 1.3.6.3.3.2.2.1 | Operations Concept | 5d? | 2008-04-01 | 2008-04-07 | 510d | Le Mignant | 40h | 3,000 |
| 606 | 1.3.6.3.3.2.2.2 | Functional Requirements & Use Case Definitions | 5d? | 2008-04-01 | 2008-04-07 | 510d | Le Mignant | 40h | 3,000 |
| 607 | 1.3.6.3.3.2.2.3 | Interface Definitions | 1d? | 2008-04-01 | 2008-04-01 | 514d |  |  |  |
| 608 | 1.3.6.3.3.2.2.4 | Module Definitions | 1d? | 2008-04-01 | 2008-04-01 | 514d |  |  |  |

| ID | WBS | Task | Type | Duration | Start | Finish | Total slack | Constraint | Resources | Work | Cost |
| --- | --- | --- | --- | --- | --- | --- | --- | --- | --- | --- | --- |
| 609 | 1.3.6.3.3.3 | **Science Data Archiving** |  | 1.25d? | 2008-04-01 | 2008-04-02 | 513.75d |  |  | 10h | 750 |
| 610 | 1.3.6.3.3.3.1 | Operations Concept |  | 1.25d? | 2008-04-01 | 2008-04-02 | 513.75d |  | Le Mignant | 10h | 750 |
| 611 | 1.3.6.3.3.3.2 | Functional Requirements & Use Case Definitions |  | 1d? | 2008-04-01 | 2008-04-01 | 514d |  |  |  |  |
| 612 | 1.3.6.3.3.3.3 | Interface Definitions |  | 1d? | 2008-04-01 | 2008-04-01 | 514d |  |  |  |  |
| 613 | 1.3.6.4 | **Data Server** |  | 5d? | 2008-04-01 | 2008-04-07 | 510d |  |  | 70h | 5,250 |
| 614 | 1.3.6.4.1 | Data Server: Architecture |  | 5d? | 2008-04-01 | 2008-04-07 | 510d |  | Johansson | 40h | 3,000 |
| 615 | 1.3.6.4.2 | Data Server: HW & SW Specification & Selection |  | 2.5d? | 2008-04-01 | 2008-04-03 | 512.5d |  | Johansson | 20h | 1,500 |
| 616 | 1.3.6.4.3 | Data Server: Software Design | milestone | 0d? | 2008-04-01 | 2008-04-01 | 515d |  | Johansson |  |  |
| 617 | 1.3.6.4.4 | Data Server: Compliance Matrix | milestone | 0d? | 2008-04-01 | 2008-04-01 | 515d |  | Johansson |  |  |
| 618 | 1.3.6.4.5 | Data Server: Test Plan | milestone | 0d? | 2008-04-01 | 2008-04-01 | 515d |  | Johansson |  |  |
| 619 | 1.3.6.4.6 | Data Server: Summary Report |  | 1.25d? | 2008-04-01 | 2008-04-02 | 513.75d |  | Johansson | 10h | 750 |
| 620 | 1.3.7 | **Telescope & Summit Engineering Design** |  | 219d? | 2008-04-01 | 2009-01-30 | 296d |  |  | 1221h | 91,575 |
| 621 | 1.3.7.1 | Telescope Performance |  | 1d? | 2008-04-01 | 2008-04-01 | 514d |  |  |  |  |
| 622 | 1.3.7.2 | **Infrastructure Modifications for AO** |  | 17.5d? | 2008-04-01 | 2008-04-24 | 497.5d |  |  | 660h | 49,500 |
| 623 | 1.3.7.2.1 | Infrastructure Requirements & Interfaces |  | 7.5d? | 2008-04-01 | 2008-04-10 | 507.5d |  | Bell; Wetherell; Wizinowich [60%] | 90h | 6,750 |
| 624 | 1.3.7.2.2 | Infrastructure Mechanical Modifications |  | 15d? | 2008-04-01 | 2008-04-21 | 500d |  | Bell; Medeiros; Tech | 160h | 12,000 |
| 625 | 1.3.7.2.3 | Infrastructure Electrical Modifications |  | 15d? | 2008-04-01 | 2008-04-21 | 500d |  | Nance | 120h | 9,000 |
| 626 | 1.3.7.2.4 | Infrastructure Glycol Cooling Modifications |  | 17.5d? | 2008-04-01 | 2008-04-24 | 497.5d |  | Nance | 140h | 10,500 |
| 627 | 1.3.7.2.5 | Infrastructure CCR Modifications |  | 5d? | 2008-04-01 | 2008-04-07 | 510d |  | Nance | 40h | 3,000 |
| 628 | 1.3.7.2.6 | Infrastructure Implementation & Test Plans |  | 6.25d? | 2008-04-01 | 2008-04-09 | 508.75d |  | Bell; Medeiros; Nance; Chin | 110h | 8,250 |
| 629 | 1.3.7.3 | **Infrastructure modifications for Laser System** |  | 6.25d? | 2008-04-01 | 2008-04-09 | 508.75d |  |  | 280h | 21,000 |
| 630 | 1.3.7.3.1 | Infrastructure Requirements & Interfaces |  | 5d? | 2008-04-01 | 2008-04-07 | 510d |  | Bell; Chin; Nance | 70h | 5,250 |
| 631 | 1.3.7.3.2 | Infrastructure Mechanical Modifications |  | 6.25d? | 2008-04-01 | 2008-04-09 | 508.75d |  | Medeiros | 50h | 3,750 |
| 632 | 1.3.7.3.3 | Infrastructure Electrical Modifications |  | 5d? | 2008-04-01 | 2008-04-07 | 510d |  | Nance | 40h | 3,000 |
| 633 | 1.3.7.3.4 | Infrastructure Glycol Cooling Modifications |  | 6.25d? | 2008-04-01 | 2008-04-09 | 508.75d |  | Nance | 50h | 3,750 |
| 634 | 1.3.7.3.5 | Infrastructure Implementation & Test Plans |  | 5d? | 2008-04-01 | 2008-04-07 | 510d |  | Bell; Chin; Medeiros; Nance | 70h | 5,250 |
| 635 | 1.3.7.4 | OSIRIS Modifications |  | 10d? | 2009-01-19 | 2009-01-30 | 296d | finish no earlier than 2009-01-30 | Adkins; Other; Medeiros | 220h | 16,500 |

Notes:
- 613: EJ
- 622: JB
- 623: JB
- 624: DM
- 625: CN
- 626: CN
- 627: CN
- 628: JB
- 629: JB
- 630: JB
- 631: DM
- 632: CN
- 633: CN
- 634: JB
- 635: SA

| ID | WBS | Task | Duration | Start | Finish | Total slack | Resources | Work | Cost |
| --- | --- | --- | --- | --- | --- | --- | --- | --- | --- |
| 636 | 1.3.7.5 | **Interferometer Modifications** | 5.21d? | 2008-04-01 | 2008-04-08 | 509.79d |  | 61h | 4,575 |
| 637 | 1.3.7.5.1 | Optical Design of Post Field Selector Optics | 5.21d? | 2008-04-01 | 2008-04-08 | 509.79d | Wizinowich [60%]; Kupke | 45h | 3,375 |
| 638 | 1.3.7.5.2 | Evaluation of Optical Design Impact on Interferometer | 3.33d? | 2008-04-01 | 2008-04-04 | 511.67d | Wizinowich [60%] | 16h | 1,200 |
| 639 | 1.3.8 | **Telescope Integration & Test** | 7.5d? | 2008-04-01 | 2008-04-10 | 507.5d |  | 622h | 46,650 |
| 640 | 1.3.8.1 | **Old AO/Laser Removal** | 1d? | 2008-04-01 | 2008-04-01 | 514d |  | 120h | 9,000 |
| 641 | 1.3.8.1.1 | AO Removal Plan | 1d? | 2008-04-01 | 2008-04-01 | 514d | Other [750%] | 60h | 4,500 |
| 642 | 1.3.8.1.2 | Laser Removal Plan | 1d? | 2008-04-01 | 2008-04-01 | 514d | Other [750%] | 60h | 4,500 |
| 643 | 1.3.8.2 | Laser Enclosure Integration | 1d? | 2008-04-01 | 2008-04-01 | 514d |  |  |  |
| 644 | 1.3.8.3 | AO Enclosure Integration | 1d? | 2008-04-01 | 2008-04-01 | 514d |  |  |  |
| 645 | 1.3.8.4 | **AO System Install + I&T** | 5d? | 2008-04-01 | 2008-04-07 | 510d |  | 170h | 12,750 |
| 646 | 1.3.8.4.1 | Opto-Mechanical Integration Plan | 0.6d? | 2008-04-01 | 2008-04-01 | 514.4d | Other [1250%] | 60h | 4,500 |
| 647 | 1.3.8.4.2 | Electronics Integration Plan | 1d? | 2008-04-01 | 2008-04-01 | 514d | Wetherell [500%] | 40h | 3,000 |
| 648 | 1.3.8.4.3 | Computer Integration Plan | 2.5d? | 2008-04-01 | 2008-04-03 | 512.5d | Chock | 20h | 1,500 |
| 649 | 1.3.8.4.4 | AO System Integration Plan | 5d? | 2008-04-01 | 2008-04-07 | 510d | Other | 40h | 3,000 |
| 650 | 1.3.8.4.5 | AO System Test Plan | 1d? | 2008-04-01 | 2008-04-01 | 514d | Other [125%] | 10h | 750 |
| 651 | 1.3.8.5 | **Laser System Install + I&T** | 7.5d? | 2008-04-01 | 2008-04-10 | 507.5d |  | 212h | 15,900 |
| 652 | 1.3.8.5.1 | Laser System Installation & Integration Plan | 7.5d? | 2008-04-01 | 2008-04-10 | 507.5d | Chin; Nance; Medeiros; Wetherell; Neyman; Adkins | 148h | 11,100 |
| 653 | 1.3.8.5.2 | Laser System Test Plan | 5d? | 2008-04-01 | 2008-04-07 | 510d | Neyman; Wetherell; Other; Chin; Adkins | 64h | 4,800 |
| 654 | 1.3.8.6 | LGS AO System On-sky I&T Plan | 4.17d? | 2008-04-01 | 2008-04-07 | 510.83d | Le Mignant; Wizinowich [60%] | 40h | 3,000 |
| 655 | 1.3.8.7 | Performance Characterization | 1d? | 2008-04-01 | 2008-04-01 | 514d |  |  |  |
| 656 | 1.3.8.8 | Science Verification Plan | 7.5d? | 2008-04-01 | 2008-04-10 | 507.5d | Le Mignant; Wizinowich [60%] | 80h | 6,000 |
| 657 | 1.3.9 | **Operations Transition** | 7d? | 2008-04-01 | 2008-04-09 | 508d |  | 166h | 12,450 |
| 658 | 1.3.9.1 | **Operations Plans** | 7d? | 2008-04-01 | 2008-04-09 | 508d |  | 96h | 7,200 |
| 659 | 1.3.9.1.1 | Operations Support Plan | 1d? | 2008-04-01 | 2008-04-01 | 514d | Le Mignant [500%] | 40h | 3,000 |
| 660 | 1.3.9.1.2 | Operations Maintenance & Spares Plan Template | 7d? | 2008-04-01 | 2008-04-09 | 508d | Other | 56h | 4,200 |

Notes:
- 636: PW
- 637: PW
- 638: PW
- 651: JC
- 652: JC
- 653: CN
- 654: DLM
- 656: DLM
- 657: DLM
- 659: DLM

| ID | WBS | Task | Duration | Start | Finish | Total slack | Resources | Work | Cost |
| --- | --- | --- | --- | --- | --- | --- | --- | --- | --- |
| 661 | 1.3.9.2 | **Operations Handover** | 5d? | 2008-04-01 | 2008-04-07 | 510d |  | 70h | 5,250 |
| 662 | 1.3.9.2.1 | Operations Personnel Training Plan | 5d? | 2008-04-01 | 2008-04-07 | 510d | Le Mignant; Wizinowich [60%] | 50h | 3,750 |
| 663 | 1.3.9.2.2 | Documentation Transition Plan | 2.5d? | 2008-04-01 | 2008-04-03 | 512.5d | Le Mignant | 20h | 1,500 |

Notes:
- 661: DLM
- 662: DLM
- 663: DLM
