# NGAO PD schedule v0

Schedule from MS Project, 2008-04-01 to 2009-12-30.
CARA

## Calendars

- Standard: Mon-Fri 08:00-12:00, 13:00-17:00; Sat-Sun off.

## Resources

| Resource |
| --- |
| Manager |
| Scientist |
| Engineer |

## Schedule

| ID | WBS | Task | Type | Duration | Start | Finish | Total slack | Constraint | Work |
| --- | --- | --- | --- | --- | --- | --- | --- | --- | --- |
| 1 | 0 | **NGAO Preliminary Design Phase Schedule** |  | 457d? | 2008-04-01 | 2009-12-30 | 0d |  | 24320h |
| 2 | 1 | **PD Phase Management** |  | 457d? | 2008-04-01 | 2009-12-30 | 0d |  | 2860h |
| 3 | 1.1.1 | Planning |  | 435d? | 2008-04-01 | 2009-11-30 | 22d | start no earlier than 2008-04-01 | 200h |
| 4 | 1.1.2 | **Programmatic Risk Assessment & Mitigation** |  | 435d? | 2008-04-01 | 2009-11-30 | 22d |  | 400h |
| 5 | 1.1.2.1 | Risk Assessment |  | 435d? | 2008-04-01 | 2009-11-30 | 22d |  | 100h |
| 6 | 1.1.2.2 | Risk Mitigation |  | 435d? | 2008-04-01 | 2009-11-30 | 22d | start no earlier than 2008-04-01 | 160h |
| 7 | 1.1.2.3 | Laser Vendor & Cost |  | 305d? | 2008-06-02 | 2009-07-31 | 108d | start no earlier than 2008-06-02 | 140h |
| 8 | 1.1.3 | Project Meetings |  | 435d? | 2008-04-01 | 2009-11-30 | 22d |  | 1600h |
| 9 | 1.1.4 | Tracking and Reporting |  | 435d? | 2008-04-01 | 2009-11-30 | 22d |  | 200h |
| 10 | 1.1.5 | **Preliminary Design Report & Review** |  | 65d? | 2009-10-01 | 2009-12-30 | 0d |  | 460h |
| 11 | 1.1.5.1 | Preliminary Design Report |  | 43d? | 2009-10-01 | 2009-11-30 | 22d | start no earlier than 2009-10-01 | 160h |
| 12 | 1.1.5.2 | Preliminary Design Review Support |  | 43d? | 2009-11-02 | 2009-12-30 | 0d | finish no earlier than 2009-12-30 | 300h |
| 13 | 1.1.5.3 | Preliminary Design Review | milestone | 0d | 2009-12-15 | 2009-12-15 | 12d | start no earlier than 2009-12-15 |  |
| 14 | 1.2 | **Systems Engineering** |  | 435d? | 2008-04-01 | 2009-11-30 | 22d |  | 6590h |
| 15 | 1.2.1 | **Requirements** |  | 435d? | 2008-04-01 | 2009-11-30 | 22d |  | 1050h |
| 16 | 1.2.1.1 | Science Requirements |  | 435d? | 2008-04-01 | 2009-11-30 | 22d |  | 380h |
| 17 | 1.2.1.2 | System Requirements |  | 435d? | 2008-04-01 | 2009-11-30 | 22d |  | 170h |
| 18 | 1.2.1.3 | Functional Requirements |  | 435d? | 2008-04-01 | 2009-11-30 | 22d |  | 500h |
| 19 | 1.2.2 | **Performance Budgets** |  | 347d? | 2008-08-01 | 2009-11-30 | 22d |  | 1600h |
| 20 | 1.2.2.1 | Throughput & Backgroound |  | 65d? | 2008-08-01 | 2009-04-30 | 174d | start no earlier than 2008-08-01 | 100h |
| 21 | 1.2.2.2 | Wavefront & Encircled Energy |  | 86d? | 2008-09-01 | 2009-05-29 | 153d | start no earlier than 2008-09-01 | 300h |
| 22 | 1.2.2.3 | Astrometric |  | 88d? | 2008-10-01 | 2009-06-30 | 131d | start no earlier than 2008-10-01 | 300h |
| 23 | 1.2.2.4 | Photometric |  | 88d? | 2008-11-03 | 2009-07-31 | 108d | start no earlier than 2008-11-03 | 300h |
| 24 | 1.2.2.5 | Companion Sensitivity |  | 86d? | 2008-12-01 | 2009-08-31 | 87d | start no earlier than 2008-12-01 | 250h |
| 25 | 1.2.2.6 | Polarimetry |  | 64d? | 2009-01-01 | 2009-09-30 | 65d | start no earlier than 2009-01-01 | 50h |
| 26 | 1.2.2.7 | Observing Efficiency |  | 64d? | 2009-02-02 | 2009-10-30 | 43d | start no earlier than 2009-02-02 | 150h |
| 27 | 1.2.2.8 | Observing Uptime |  | 65d? | 2009-03-02 | 2009-11-30 | 22d | start no earlier than 2009-03-02 | 150h |

| ID | WBS | Task | Duration | Start | Finish | Total slack | Constraint | Work |
| --- | --- | --- | --- | --- | --- | --- | --- | --- |
| 28 | 1.2.3 | **Technical Risk Assessment & Mitigation** | 435d? | 2008-04-01 | 2009-11-30 | 22d |  | 2500h |
| 29 | 1.2.3.1 | Risk Assessment | 435d? | 2008-04-01 | 2009-11-30 | 22d |  | 200h |
| 30 | 1.2.3.2 | **Risk Mitigation Efforts** | 370d? | 2008-05-01 | 2009-09-30 | 65d |  | 2300h |
| 31 | 1.2.3.2.1 | CCID-56 | 175d? | 2008-05-01 | 2008-12-31 | 260d | start no earlier than 2008-05-01 | 500h |
| 32 | 1.2.3.2.2 | Atmospheric Profiler | 217d? | 2008-06-02 | 2009-03-31 | 196d | start no earlier than 2008-06-02 | 500h |
| 33 | 1.2.3.2.3 | Single Laser Tomography | 239d? | 2008-07-01 | 2009-05-29 | 153d | start no earlier than 2008-07-01 | 500h |
| 34 | 1.2.3.2.4 | Tip/Tilt Vibration Analysis | 195d? | 2008-09-01 | 2009-05-29 | 153d | start no earlier than 2008-09-01 | 500h |
| 35 | 1.2.3.2.5 | Other | 348d? | 2008-06-02 | 2009-09-30 | 65d | start no earlier than 2008-06-02 | 300h |
| 36 | 1.2.4 | **System Architecture** | 109d? | 2008-04-01 | 2008-08-29 | 348d |  | 1040h |
| 37 | 1.2.4.1 | Opto-Mechanical Architecture | 109d? | 2008-04-01 | 2008-08-29 | 348d |  | 400h |
| 38 | 1.2.4.2 | Software Architecture | 109d? | 2008-04-01 | 2008-08-29 | 348d |  | 360h |
| 39 | 1.2.4.3 | Motion Control / Electronics Architecture | 109d? | 2008-04-01 | 2008-08-29 | 348d |  | 280h |
| 40 | 1.2.5 | System Design Manual | 174d? | 2008-08-01 | 2009-11-30 | 22d | start no earlier than 2008-08-01 | 400h |
| 41 | 1.3 | **AO Facility Design** | 174d? | 2008-09-01 | 2009-04-30 | 174d |  | 7000h |
| 42 | 1.3.1 | AO Enclosure | 130d? | 2008-10-01 | 2009-03-31 | 196d | start no earlier than 2008-10-01 | 600h |
| 43 | 1.3.2 | Opto-mechanical | 174d? | 2008-09-01 | 2009-04-30 | 174d | start no earlier than 2008-09-01 | 3200h |
| 44 | 1.3.3 | Non-real-time Control | 174d? | 2008-09-01 | 2009-04-30 | 174d | start no earlier than 2008-09-01 | 1200h |
| 45 | 1.3.4 | Real-time Control | 174d? | 2008-09-01 | 2009-04-30 | 174d | start no earlier than 2008-09-01 | 2000h |
| 46 | 1.4 | **Laser Facility Design** | 153d? | 2009-04-01 | 2009-10-30 | 43d |  | 3300h |
| 47 | 1.4.1 | Laser Enclosure | 87d? | 2009-05-01 | 2009-08-31 | 87d | start no earlier than 2009-05-01 | 300h |
| 48 | 1.4.2 | Laser | 153d? | 2009-04-01 | 2009-10-30 | 43d | start no earlier than 2009-04-01 | 500h |
| 49 | 1.4.3 | Laser Launch Facility | 131d? | 2009-04-01 | 2009-09-30 | 65d | start no earlier than 2009-04-01 | 1000h |
| 50 | 1.4.4 | Laser Safety Systems | 109d? | 2009-05-01 | 2009-09-30 | 65d | start no earlier than 2009-05-01 | 500h |
| 51 | 1.4.5 | Laser System Control | 109d? | 2009-04-01 | 2009-09-30 | 65d | start no earlier than 2009-04-01 | 1000h |

| ID | WBS | Task | Duration | Start | Finish | Total slack | Constraint | Work |
| --- | --- | --- | --- | --- | --- | --- | --- | --- |
| 52 | 1.5 | **Science Operations Design** | 348d? | 2008-06-02 | 2009-09-30 | 65d |  | 1800h |
| 53 | 1.5.1 | Astronomical Observations Operations | 348d? | 2008-06-02 | 2009-09-30 | 65d | start no earlier than 2008-06-02 | 800h |
| 54 | 1.5.2 | AO-Instrument Operations | 348d? | 2008-06-02 | 2009-09-30 | 65d | start no earlier than 2008-06-02 | 1000h |
| 55 | 1.6 | **Science Instrument Interfaces** | 239d? | 2008-05-01 | 2009-03-31 | 196d |  | 1270h |
| 56 | 1.6.1 | **Instrument Requirements Input & Review** | 239d? | 2008-05-01 | 2009-03-31 | 196d |  | 580h |
| 57 | 1.6.1.1 | NIR Camera Requirements | 109d? | 2008-06-02 | 2008-11-28 | 283d | start no earlier than 2008-06-02 | 150h |
| 58 | 1.6.1.2 | DNIRI Requirements | 239d? | 2008-05-01 | 2009-03-31 | 196d | start no earlier than 2008-05-01 | 300h |
| 59 | 1.6.1.3 | Visble Camera Requirements | 110d? | 2008-09-01 | 2009-01-30 | 238d | start no earlier than 2008-09-01 | 130h |
| 60 | 1.6.2 | **Interface Control Documents (ICDs)** | 152d? | 2008-05-01 | 2008-11-28 | 283d |  | 690h |
| 61 | 1.6.2.1 | Generic ICD | 66d? | 2008-05-01 | 2008-07-31 | 369d | start no earlier than 2008-05-01 | 150h |
| 62 | 1.6.2.2 | Interferometer | 66d? | 2008-05-01 | 2008-07-31 | 369d | start no earlier than 2008-05-01 | 120h |
| 63 | 1.6.2.3 | NIR Camera ICD | 43d? | 2008-08-01 | 2008-09-30 | 326d | start no earlier than 2008-08-01 | 120h |
| 64 | 1.6.2.4 | DNIRI ICD | 89d? | 2008-07-01 | 2008-10-31 | 303d | start no earlier than 2008-07-01 | 200h |
| 65 | 1.6.2.5 | Visible Camera ICD | 43d? | 2008-10-01 | 2008-11-28 | 283d | start no earlier than 2008-10-01 | 100h |
| 66 | 1.7 | **Systems Engineering Management Plan** | 238d? | 2009-01-01 | 2009-11-30 | 22d |  | 1500h |
| 67 | 1.7.1 | Project Plan | 109d? | 2009-07-01 | 2009-11-30 | 22d | start no earlier than 2009-07-01 | 640h |
| 68 | 1.7.2 | Risk Assessment & Management Plan | 65d? | 2009-08-03 | 2009-10-30 | 43d | start no earlier than 2009-08-03 | 100h |
| 69 | 1.7.3 | Detailed Design Phase Plan | 107d? | 2009-01-01 | 2009-10-30 | 43d | start no earlier than 2009-01-01 | 260h |
| 70 | 1.7.4 | Integration and Test Plans | 109d? | 2009-04-01 | 2009-08-31 | 87d | start no earlier than 2009-04-01 | 300h |
| 71 | 1.7.5 | SEMP Document | 43d? | 2009-10-01 | 2009-11-30 | 22d | start no earlier than 2009-10-01 | 200h |
| 72 | 2 | **NGAO Science Instruments System Design** | 413d? | 2008-05-01 | 2009-11-30 | 22d |  |  |
| 73 | 2.1 | NIR Camera System Design | 391d? | 2008-06-02 | 2009-11-30 | 22d | start no earlier than 2008-06-02 |  |
| 74 | 2.2 | DNIRI System Design | 413d? | 2008-05-01 | 2009-11-30 | 22d | finish no earlier than 2009-11-30 |  |
| 75 | 2.3 | Visible Camera System Design | 347d? | 2008-08-01 | 2009-11-30 | 22d | finish no earlier than 2009-11-30 |  |
