# NGAO PD schedule v1_0

Schedule from MS Project, 2006-01-02 to 2009-12-30.
CARA

## Calendars

- Standard: Mon-Fri 08:00-12:00, 13:00-17:00; Sat-Sun off.

## Resources

| Resource |
| --- |
| Manager |
| Scientist |
| Engineer |

## Schedule

| ID | WBS | Task | Type | Duration | Start | Finish | Predecessors | Total slack | Free slack | Constraint | Work |
| --- | --- | --- | --- | --- | --- | --- | --- | --- | --- | --- | --- |
| 1 | 0 | **NGAO AO System Preliminary Design Phase Milestones** |  | 1033d | 2006-01-02 | 2009-12-16 |  | 10d |  |  |  |
| 2 | 0.1 | Project Start | milestone | 0d | 2006-01-02 | 2006-01-02 |  | 1508d |  | start no earlier than 2006-01-02 |  |
| 3 | 0.2 | **AO System Design Reviews** |  | 444d | 2008-04-03 | 2009-12-16 |  | 10d |  |  |  |
| 4 | 0.2.1 | System Design Review | milestone | 0d | 2008-04-03 | 2008-04-03 | 25 | 19d | 0d |  |  |
| 5 | 0.2.2 | Preliminary Design Review | milestone | 0d | 2009-12-16 | 2009-12-16 | 28 | 475d |  |  |  |
| 6 | 1 | **NGAO Project** |  | 919d | 2006-06-23 | 2009-12-30 |  | 0d |  |  | 24050h |
| 7 | 1.1 | **Management** |  | 919d | 2006-06-23 | 2009-12-30 |  | 0d |  |  | 4370h |
| 8 | 1.1.1 | **Project Management** |  | 900d | 2006-06-23 | 2009-12-03 |  | 19d |  |  | 2200h |
| 9 | 1.1.1.1 | **Proposal** |  | 0d | 2006-06-23 | 2006-06-23 |  | 919d |  |  |  |
| 10 | 1.1.1.1.1 | Proposal to SSC | milestone | 0d | 2006-06-23 | 2006-06-23 |  | 919d |  | start no earlier than 2006-06-23 |  |
| 11 | 1.1.1.2 | **Programmatic Risk Assessment & Mitigation** |  | 435d | 2008-04-04 | 2009-12-03 |  | 19d |  |  | 400h |
| 12 | 1.1.1.2.1 | Risk Assessment |  | 435d | 2008-04-04 | 2009-12-03 | 4 | 19d |  |  | 100h |
| 13 | 1.1.1.2.2 | Risk Mitigation |  | 435d | 2008-04-04 | 2009-12-03 | 4 | 19d |  | start no earlier than 2008-04-01 | 160h |
| 14 | 1.1.1.2.3 | Laser Vendor & Cost |  | 305d | 2008-06-02 | 2009-07-31 | 4 | 108d |  | start no earlier than 2008-06-02 | 140h |
| 15 | 1.1.1.3 | **Project Meetings** |  | 435d | 2008-04-04 | 2009-12-03 |  | 19d |  |  | 1600h |
| 16 | 1.1.1.3.1 | Project Meetings |  | 435d | 2008-04-04 | 2009-12-03 | 4 | 19d |  |  | 1600h |
| 17 | 1.1.1.4 | **Schedule and Budget Maintenance** |  | 435d | 2008-04-04 | 2009-12-03 |  | 19d |  |  | 200h |
| 18 | 1.1.1.4.1 | Planning |  | 435d | 2008-04-04 | 2009-12-03 | 4 | 19d |  | start no earlier than 2008-04-01 | 100h |
| 19 | 1.1.1.4.2 | Tracking and Reporting |  | 435d | 2008-04-04 | 2009-12-03 | 4 | 19d |  |  | 100h |
| 20 | 1.1.2 | **Reporting** |  | 435d | 2008-04-22 | 2009-12-21 |  | 7d |  |  | 290h |
| 21 | 1.1.2.1 | Monthly Reports |  | 435d | 2008-04-22 | 2009-12-21 | 4 | 7d |  | finish no earlier than 2009-12-21 | 130h |
| 22 | 1.1.2.2 | Preliminary Design Report |  | 43d | 2009-10-01 | 2009-11-30 |  | 22d |  | start no earlier than 2009-10-01 | 160h |
| 23 | 1.1.3 | **Reviews** |  | 456d | 2008-04-02 | 2009-12-30 |  | 0d |  |  | 380h |
| 24 | 1.1.3.1 | **AO Design Reviews** |  | 456d | 2008-04-02 | 2009-12-30 |  | 0d |  |  | 380h |
| 25 | 1.1.3.1.1 | System Design Review | milestone | 2d | 2008-04-02 | 2008-04-03 |  | 19d | 0d | start no earlier than 2008-04-02 |  |

| ID | WBS | Task | Duration | Start | Finish | Predecessors | Total slack | Free slack | Constraint | Work |
| --- | --- | --- | --- | --- | --- | --- | --- | --- | --- | --- |
| 26 | 1.1.3.1.2 | **Preliminary Design Review** | 43d | 2009-11-02 | 2009-12-30 |  | 0d |  |  | 380h |
| 27 | 1.1.3.1.2.1 | Preliminary Design Review Support | 43d | 2009-11-02 | 2009-12-30 |  | 0d |  | finish no earlier than 2009-12-30 | 300h |
| 28 | 1.1.3.1.2.2 | Preliminary Design Review | 2d | 2009-12-15 | 2009-12-16 |  | 475d | 0d | start no earlier than 2009-12-15 | 80h |
| 29 | 1.1.4 | **Systems Engineering Management Plan** | 238d | 2009-01-01 | 2009-11-30 |  | 22d |  |  | 1500h |
| 30 | 1.1.4.1 | Project Plan | 109d | 2009-07-01 | 2009-11-30 |  | 487d |  | start no earlier than 2009-07-01 | 640h |
| 31 | 1.1.4.2 | Risk Assessment & Management Plan | 65d | 2009-08-03 | 2009-10-30 |  | 508d |  | start no earlier than 2009-08-03 | 100h |
| 32 | 1.1.4.3 | Detailed Design Phase Plan | 107d | 2009-01-01 | 2009-10-30 |  | 508d |  | start no earlier than 2009-01-01 | 260h |
| 33 | 1.1.4.4 | Integration and Test Plans | 109d | 2009-04-01 | 2009-08-31 |  | 552d |  | start no earlier than 2009-04-01 | 300h |
| 34 | 1.1.4.5 | SEMP Document | 43d | 2009-10-01 | 2009-11-30 |  | 487d |  | start no earlier than 2009-10-01 | 200h |
| 35 | 1.2 | **Science** | 435d | 2008-04-04 | 2009-12-03 |  | 19d |  |  | 2560h |
| 36 | 1.2.1 | **Science Requirements** | 435d | 2008-04-04 | 2009-12-03 |  | 19d |  |  | 760h |
| 37 | 1.2.1.1 | Science Requirements | 435d | 2008-04-04 | 2009-12-03 | 4 | 19d |  |  | 380h |
| 38 | 1.2.1.2 | Science Case Development | 435d | 2008-04-04 | 2009-12-03 | 4 | 19d |  |  | 380h |
| 39 | 1.2.2 | **Science Operations** | 348d | 2008-06-02 | 2009-09-30 |  | 65d |  |  | 1800h |
| 40 | 1.2.2.1 | Astronomical Observations Operations | 348d | 2008-06-02 | 2009-09-30 | 4 | 65d |  | start no earlier than 2008-06-02 | 800h |
| 41 | 1.2.2.2 | AO-Instrument Operations | 348d | 2008-06-02 | 2009-09-30 | 4 | 65d |  | start no earlier than 2008-06-02 | 1000h |
| 42 | 1.3 | **AO Design** | 829d | 2006-10-02 | 2009-12-03 |  | 19d |  |  | 17120h |
| 43 | 1.3.1 | **System Design** | 392d | 2006-10-02 | 2008-04-01 |  | 456d |  |  |  |
| 44 | 1.3.1.1 | System Design Activities | 392d | 2006-10-02 | 2008-04-01 |  | 921d |  | start no earlier than 2006-10-02 |  |
| 45 | 1.3.2 | **Preliminary Design** | 435d | 2008-04-04 | 2009-12-03 |  | 19d |  |  | 17120h |
| 46 | 1.3.2.1 | **Systems Engineering** | 435d | 2008-04-04 | 2009-12-03 |  | 19d |  |  | 6210h |
| 47 | 1.3.2.1.1 | **Requirements** | 435d | 2008-04-04 | 2009-12-03 |  | 19d |  |  | 670h |
| 48 | 1.3.2.1.1.1 | System Requirements | 435d | 2008-04-04 | 2009-12-03 | 4 | 19d |  |  | 170h |
| 49 | 1.3.2.1.1.2 | Functional Requirements | 435d | 2008-04-04 | 2009-12-03 | 4 | 19d |  |  | 500h |

| ID | WBS | Task | Duration | Start | Finish | Predecessors | Total slack | Constraint | Work |
| --- | --- | --- | --- | --- | --- | --- | --- | --- | --- |
| 50 | 1.3.2.1.4 | **Performance Budgets** | 347d | 2008-08-01 | 2009-11-30 |  | 22d |  | 1600h |
| 51 | 1.3.2.1.4.1 | Throughput & Backgroound | 65d | 2008-08-01 | 2009-04-30 |  | 174d | start no earlier than 2008-08-01 | 100h |
| 52 | 1.3.2.1.4.2 | Wavefront & Encircled Energy | 86d | 2008-09-01 | 2009-05-29 |  | 153d | start no earlier than 2008-09-01 | 300h |
| 53 | 1.3.2.1.4.3 | Astrometric | 88d | 2008-10-01 | 2009-06-30 |  | 131d | start no earlier than 2008-10-01 | 300h |
| 54 | 1.3.2.1.4.4 | Photometric | 88d | 2008-11-03 | 2009-07-31 |  | 108d | start no earlier than 2008-11-03 | 300h |
| 55 | 1.3.2.1.4.5 | Companion Sensitivity | 86d | 2008-12-01 | 2009-08-31 |  | 87d | start no earlier than 2008-12-01 | 250h |
| 56 | 1.3.2.1.4.6 | Polarimetry | 64d | 2009-01-01 | 2009-09-30 |  | 65d | start no earlier than 2009-01-01 | 50h |
| 57 | 1.3.2.1.4.7 | Observing Efficiency | 64d | 2009-02-02 | 2009-10-30 |  | 43d | start no earlier than 2009-02-02 | 150h |
| 58 | 1.3.2.1.4.8 | Observing Uptime | 65d | 2009-03-02 | 2009-11-30 |  | 22d | start no earlier than 2009-03-02 | 150h |
| 59 | 1.3.2.1.5 | **Technical Risk Assessment & Mitigation** | 435d | 2008-04-04 | 2009-12-03 |  | 19d |  | 2500h |
| 60 | 1.3.2.1.5.1 | Risk Assessment | 435d | 2008-04-04 | 2009-12-03 | 4 | 19d |  | 200h |
| 61 | 1.3.2.1.5.2 | **Risk Mitigation Efforts** | 370d | 2008-05-01 | 2009-09-30 |  | 65d |  | 2300h |
| 62 | 1.3.2.1.5.2.1 | CCID-56 | 175d | 2008-05-01 | 2008-12-31 |  | 260d | start no earlier than 2008-05-01 | 500h |
| 63 | 1.3.2.1.5.2.2 | Atmospheric Profiler | 217d | 2008-06-02 | 2009-03-31 |  | 196d | start no earlier than 2008-06-02 | 500h |
| 64 | 1.3.2.1.5.2.3 | Single Laser Tomography | 239d | 2008-07-01 | 2009-05-29 |  | 153d | start no earlier than 2008-07-01 | 500h |
| 65 | 1.3.2.1.5.2.4 | Tip/Tilt Vibration Analysis | 195d | 2008-09-01 | 2009-05-29 |  | 153d | start no earlier than 2008-09-01 | 500h |
| 66 | 1.3.2.1.5.2.5 | Other | 348d | 2008-06-02 | 2009-09-30 |  | 65d | start no earlier than 2008-06-02 | 300h |
| 67 | 1.3.2.1.6 | **System Architecture** | 109d | 2008-04-04 | 2008-09-03 |  | 345d |  | 1040h |
| 68 | 1.3.2.1.6.1 | Opto-Mechanical Architecture | 109d | 2008-04-04 | 2008-09-03 | 4 | 345d |  | 400h |
| 69 | 1.3.2.1.6.2 | Software Architecture | 109d | 2008-04-04 | 2008-09-03 | 4 | 345d |  | 360h |
| 70 | 1.3.2.1.6.3 | Motion Control / Electronics Architecture | 109d | 2008-04-04 | 2008-09-03 | 4 | 345d |  | 280h |
| 71 | 1.3.2.1.7 | System Design Manual | 174d | 2008-08-01 | 2009-11-30 |  | 22d | start no earlier than 2008-08-01 | 400h |
| 72 | 1.3.2.2 | **AO Facility Design** | 174d | 2008-09-01 | 2009-04-30 |  | 174d |  | 7000h |
| 73 | 1.3.2.2.1 | Opto-mechanical Subsystem | 174d | 2008-09-01 | 2009-04-30 |  | 174d | start no earlier than 2008-09-01 | 3200h |
| 74 | 1.3.2.2.4 | AO Enclosure | 130d | 2008-10-01 | 2009-03-31 |  | 196d | start no earlier than 2008-10-01 | 600h |
| 75 | 1.3.2.2.5 | Real-time Control | 174d | 2008-09-01 | 2009-04-30 |  | 174d | start no earlier than 2008-09-01 | 2000h |
| 76 | 1.3.2.2.6 | Other Controls | 174d | 2008-09-01 | 2009-04-30 |  | 174d | start no earlier than 2008-09-01 | 1200h |

| ID | WBS | Task | Duration | Start | Finish | Predecessors | Total slack | Constraint | Work |
| --- | --- | --- | --- | --- | --- | --- | --- | --- | --- |
| 77 | 1.3.2.3 | **Laser Facility Design** | 411d | 2008-04-04 | 2009-10-30 |  | 43d |  | 3300h |
| 78 | 1.3.2.3.2 | Lasers | 153d | 2009-04-01 | 2009-10-30 |  | 508d | start no earlier than 2009-04-01 | 500h |
| 79 | 1.3.2.3.17 | Laser Enclosure | 87d | 2009-05-01 | 2009-08-31 |  | 552d | start no earlier than 2009-05-01 | 300h |
| 80 | 1.3.2.3.18 | Laser Beam Transport | 131d | 2008-04-04 | 2008-10-03 | 4 | 788d |  | 500h |
| 81 | 1.3.2.3.3 | Laser Projection | 131d | 2009-04-01 | 2009-09-30 | 4 | 530d | start no earlier than 2009-04-01 | 500h |
| 82 | 1.3.2.3.19 | **Laser Supervisory Controls** | 131d | 2009-04-01 | 2009-09-30 |  | 65d |  | 1500h |
| 83 | 1.3.2.3.19.1 | Laser Safety Systems | 109d | 2009-05-01 | 2009-09-30 |  | 530d | start no earlier than 2009-05-01 | 500h |
| 84 | 1.3.2.3.19.2 | Laser System Control | 109d | 2009-04-01 | 2009-09-30 |  | 530d | start no earlier than 2009-04-01 | 1000h |
| 85 | 1.3.2.4 | **External Interfaces** | 258d | 2008-04-04 | 2009-03-31 |  | 196d |  | 610h |
| 86 | 1.3.2.4.1 | **Observatory Interfaces** | 85d | 2008-04-04 | 2008-07-31 |  | 369d |  | 220h |
| 87 | 1.3.2.4.1.2 | Telecope and Facilities | 66d | 2008-04-04 | 2008-07-04 | 4 | 853d |  | 100h |
| 88 | 1.3.2.4.1.1 | Interferometer | 66d | 2008-05-01 | 2008-07-31 |  | 834d | start no earlier than 2008-05-01 | 120h |
| 89 | 1.3.2.4.2 | **Instrument Interfaces** | 239d | 2008-05-01 | 2009-03-31 |  | 196d |  | 390h |
| 90 | 1.3.2.4.2.1 | **Requirements Input** | 239d | 2008-05-01 | 2009-03-31 |  | 196d |  | 230h |
| 91 | 1.3.2.4.2.1.1 | Near-IR Imager | 109d | 2008-06-02 | 2008-11-28 |  | 748d | start no earlier than 2008-06-02 | 40h |
| 92 | 1.3.2.4.2.1.2 | Deployable Near-IR IFU | 239d | 2008-05-01 | 2009-03-31 |  | 661d | start no earlier than 2008-05-01 | 150h |
| 93 | 1.3.2.4.2.1.3 | Visible Imager | 110d | 2008-09-01 | 2009-01-30 |  | 703d | start no earlier than 2008-09-01 | 40h |
| 94 | 1.3.2.4.2.2 | **Interface Control Documents (ICDs)** | 109d | 2008-07-01 | 2008-11-28 |  | 283d |  | 160h |
| 95 | 1.3.2.4.2.2.3 | Near-IR Imager | 43d | 2008-08-01 | 2008-09-30 |  | 791d | start no earlier than 2008-08-01 | 40h |
| 96 | 1.3.2.4.2.2.4 | Deployable Near-IR IFU | 89d | 2008-07-01 | 2008-10-31 |  | 768d | start no earlier than 2008-07-01 | 80h |
| 97 | 1.3.2.4.2.2.5 | Visible Imager | 43d | 2008-10-01 | 2008-11-28 |  | 748d | start no earlier than 2008-10-01 | 40h |
| 98 | 1.4 | **Instrumentation Design** | 350d | 2008-06-27 | 2009-10-29 |  | 44d |  |  |
| 99 | 1.4.1 | **System Design** | 350d | 2008-06-27 | 2009-10-29 |  | 44d |  |  |
| 100 | 1.4.1.1 | Design Activities | 350d | 2008-06-27 | 2009-10-29 | 4FS+60d | 509d |  |  |
