# NGAO schedule

Schedule from MS Project, 2006-01-02 to 2012-08-01.
CARA

## Calendars

- Standard: Mon-Fri 08:00-12:00, 13:00-17:00; Sat-Sun off.

## Schedule

| ID | WBS | Task | Type | Duration | Start | Finish | Predecessors | Total slack | Free slack | Constraint |
| --- | --- | --- | --- | --- | --- | --- | --- | --- | --- | --- |
| 1 | 1 | **Design & System Engineering** |  | 1695d? | 2006-01-02 | 2012-06-29 |  | 22d |  |  |
| 2 | 1.1 | **Proposal** |  | 411d? | 2006-01-02 | 2007-07-30 |  | 608d |  |  |
| 3 | 1.1.1 | Science Case Proposal |  | 150d? | 2006-01-02 | 2006-07-28 |  | 1567d |  | finish no earlier than 2006-07-28 |
| 4 | 1.1.2 | Technical & Management Proposal |  | 150d? | 2006-01-02 | 2006-07-28 |  | 1567d |  | finish no earlier than 2006-07-28 |
| 5 | 1.1.3 | CARA Proposal Approval | milestone | 0d | 2006-06-23 | 2006-06-23 |  | 1592d |  | finish no earlier than 2006-06-23 |
| 6 | 1.1.4 | Funding Search |  | 260d? | 2006-08-01 | 2007-07-30 |  | 1306d |  | finish no earlier than 2007-07-30 |
| 7 | 1.1.5 | Proposal Funded | milestone | 0d | 2007-07-30 | 2007-07-30 |  | 198d | 176d | start no earlier than 2007-07-30 |
| 8 | 1.2 | System Design |  | 193d? | 2006-07-05 | 2007-03-30 |  | 23d | 0d | finish no earlier than 2007-03-30 |
| 9 | 1.3 | Preliminary Design |  | 260d? | 2007-04-02 | 2008-03-28 | 8 | 23d | 1d | start no earlier than 2007-04-02 |
| 10 | 1.4 | Detailed Design |  | 261d? | 2008-04-01 | 2009-03-31 | 9, 7 | 22d | 0d | start no earlier than 2008-04-01 |
| 11 | 1.5 | Modeling Tools & Analysis |  | 783d? | 2009-04-01 | 2012-03-30 | 10 | 87d |  | start no earlier than 2009-04-01 |
| 12 | 1.6 | Requirements Maintenance |  | 848d? | 2009-04-01 | 2012-06-29 | 10 | 22d |  | start no earlier than 2009-04-01 |
| 13 | 1.7 | Performance Budgets Maintenance |  | 848d? | 2009-04-01 | 2012-06-29 | 10 | 22d |  | start no earlier than 2009-04-01 |
| 14 | 2 | **AO System Development** |  | 521d? | 2009-04-01 | 2011-03-30 |  | 22d | 0d |  |
| 15 | 2.1 | Development Facilities |  | 131d? | 2009-04-01 | 2009-09-30 | 10 | 412d |  | finish no earlier than 2009-09-30 |
| 16 | 2.2 | Opto-Mechanical |  | 392d? | 2009-04-01 | 2010-09-30 |  | 151d |  | finish no earlier than 2010-09-30 |
| 17 | 2.3 | Motion Control |  | 392d? | 2009-04-01 | 2010-09-30 |  | 151d |  | finish no earlier than 2010-09-30 |
| 18 | 2.4 | Real-time Control |  | 392d? | 2009-04-01 | 2010-09-30 |  | 151d |  | finish no earlier than 2010-09-30 |
| 19 | 2.5 | AO System Lab Integration & Test |  | 129d? | 2010-10-01 | 2011-03-30 |  | 22d |  | finish no earlier than 2011-03-30 |
| 20 | 2.6 | AO System Acceptance Activities |  | 108d? | 2010-11-01 | 2011-03-30 |  | 22d | 1d | finish no earlier than 2011-03-30 |
| 21 | 3 | **Laser System Development** |  | 478d? | 2009-04-01 | 2011-01-28 | 10 | 392d |  |  |
| 22 | 3.1 | Development Facilities |  | 131d? | 2009-04-01 | 2009-09-30 |  | 739d |  | start no earlier than 2009-04-01 |
| 23 | 3.2 | Laser |  | 392d? | 2009-04-01 | 2010-09-30 |  | 392d | 0d | finish no earlier than 2010-09-30 |
| 24 | 3.3 | Laser Enclosure |  | 153d? | 2009-06-01 | 2009-12-30 |  | 674d |  | finish no earlier than 2009-12-30 |
| 25 | 3.4 | Beam Transport |  | 260d? | 2009-06-01 | 2010-05-28 |  | 567d |  | finish no earlier than 2010-05-28 |
| 26 | 3.5 | Launch Telescope |  | 305d? | 2009-06-01 | 2010-07-30 |  | 522d |  | finish no earlier than 2010-07-30 |
| 27 | 3.6 | Laser System Lab Integration & Test |  | 86d? | 2010-10-01 | 2011-01-28 | 23 | 392d |  | start no earlier than 2010-10-01 |
| 28 | 3.7 | Laser System Acceptance Activities |  | 65d? | 2010-11-01 | 2011-01-28 |  | 65d | 1d | finish no earlier than 2011-01-28 |

| ID | WBS | Task | Duration | Start | Finish | Predecessors | Total slack | Free slack | Constraint |
| --- | --- | --- | --- | --- | --- | --- | --- | --- | --- |
| 29 | 4 | **Operations Tools Development** | 521d? | 2009-04-01 | 2011-03-30 | 10 | 349d |  |  |
| 30 | 4.1 | Automation & Optimization Tools | 392d? | 2009-04-01 | 2010-09-30 |  | 478d |  | finish no earlier than 2010-09-30 |
| 31 | 4.2 | Observing Tools | 392d? | 2009-04-01 | 2010-09-30 |  | 478d |  | start no earlier than 2009-04-01 |
| 32 | 4.3 | Astronomer Tools | 392d? | 2009-04-01 | 2010-09-30 |  | 478d |  | start no earlier than 2009-04-01 |
| 33 | 4.4 | Operations Tools Acceptance Activities | 129d? | 2010-10-01 | 2011-03-30 |  | 22d | 0d | finish no earlier than 2011-03-30 |
| 34 | 5 | **Telescope & Summit Facilities Development** | 457d? | 2009-04-01 | 2010-12-30 | 10 | 413d |  |  |
| 35 | 5.1 | Telescope Improvements | 392d? | 2009-04-01 | 2010-09-30 |  | 478d |  | finish no earlier than 2010-09-30 |
| 36 | 5.2 | **Facilities Preparations for AO System** | 370d? | 2009-05-01 | 2010-09-30 |  | 282d | 130d |  |
| 37 | 5.2.1 | Nasmyth Platform Modifications | 174d? | 2009-05-01 | 2009-12-30 |  | 478d |  | start no earlier than 2009-05-01 |
| 38 | 5.2.2 | AO Enclosure Installation/Modification | 195d? | 2010-01-01 | 2010-09-30 |  | 282d |  | finish no earlier than 2010-09-30 |
| 39 | 5.2.3 | Power & Cooling | 195d? | 2010-01-01 | 2010-09-30 |  | 282d |  | finish no earlier than 2010-09-30 |
| 40 | 5.2.4 | DCS Modifications | 67d? | 2010-06-30 | 2010-09-30 |  | 282d |  | finish no earlier than 2010-09-30 |
| 41 | 5.3 | **Facilities Preparations for Laser System** | 195d? | 2010-01-01 | 2010-09-30 |  | 349d | 87d |  |
| 42 | 5.3.1 | Laser Enclosure Installation/Modifications | 195d? | 2010-01-01 | 2010-09-30 |  | 349d |  | finish no earlier than 2010-09-30 |
| 43 | 5.3.2 | Power & Cooling | 67d? | 2010-06-30 | 2010-09-30 |  | 349d |  | finish no earlier than 2010-09-30 |
| 44 | 5.3.3 | Laser Traffic Control Modifications | 67d? | 2010-06-30 | 2010-09-30 |  | 349d |  | finish no earlier than 2010-09-30 |
| 45 | 5.3.4 | Aircraft Safety System Modifications | 67d? | 2010-06-30 | 2010-09-30 |  | 349d |  | finish no earlier than 2010-09-30 |
| 46 | 5.4 | Facilities Preparations for Science Instrument(s) | 195d? | 2010-01-01 | 2010-09-30 |  | 368d | 216d | finish no earlier than 2010-09-30 |
| 47 | 5.5 | Telescope & Summit Development Acceptance Activities | 65d? | 2010-10-01 | 2010-12-30 |  | 86d | 64d | finish no earlier than 2010-12-30 |
| 48 | 6 | **Telescope Integration & Test** | 304d? | 2011-02-01 | 2012-03-30 |  | 87d |  |  |
| 49 | 6.1 | AO System Installation | 43d? | 2011-04-01 | 2011-05-31 | 20, 36 | 152d | 0d | start no earlier than 2011-04-01 |
| 50 | 6.2 | AO System Integration & Test | 43d? | 2011-06-01 | 2011-07-29 | 49 | 152d | 0d | start no earlier than 2011-06-01 |
| 51 | 6.3 | Laser System Installation | 97d? | 2011-02-01 | 2011-06-15 | 28, 41 | 262d | 0d | finish no earlier than 2011-06-15 |
| 52 | 6.4 | Laser System Integration & Test | 32d? | 2011-06-16 | 2011-07-29 | 51 | 262d |  | start no earlier than 2011-06-16 |
| 53 | 6.5 | Science Instrument Integration & Test with NGAO | 110d? | 2011-08-01 | 2011-12-30 | 50, 46 | 152d |  | finish no earlier than 2011-12-30 |
| 54 | 6.6 | On-sky Testing | 110d? | 2011-08-01 | 2011-12-30 | 50 | 152d |  | finish no earlier than 2011-12-30 |
| 55 | 6.7 | Performance Characterization | 130d? | 2011-10-03 | 2012-03-30 |  | 87d |  | finish no earlier than 2012-03-30 |
| 56 | 6.8 | Science Verification | 109d? | 2011-11-01 | 2012-03-30 |  | 87d |  | start no earlier than 2011-11-01 |

| ID | WBS | Task | Type | Duration | Start | Finish | Predecessors | Total slack | Free slack | Constraint |
| --- | --- | --- | --- | --- | --- | --- | --- | --- | --- | --- |
| 57 | 7 | **Operations Transition** |  | 522d? | 2010-08-02 | 2012-08-01 |  | 0d |  |  |
| 58 | 7.1 | Operations Personnel Training |  | 435d? | 2010-08-02 | 2012-03-30 |  | 22d | 0d | finish no earlier than 2012-03-30 |
| 59 | 7.2 | Operations Acceptance Activities |  | 65d? | 2012-04-02 | 2012-06-29 | 58 | 22d |  | finish no earlier than 2012-06-29 |
| 60 | 7.3 | Shared-risk Science Starts | milestone | 0d | 2012-08-01 | 2012-08-01 |  | 0d |  | start no earlier than 2012-08-01 |
| 61 | 8 | **Management** |  | 1695d? | 2006-01-02 | 2012-06-29 |  | 22d |  |  |
| 62 | 8.1 | Planning, Tracking & Reporting |  | 1695d? | 2006-01-02 | 2012-06-29 |  | 22d |  | finish no earlier than 2012-06-29 |
| 63 | 8.2 | Contracts Management |  | 1370d? | 2007-04-02 | 2012-06-29 |  | 22d |  | finish no earlier than 2012-06-29 |
| 64 | 8.3 | Personnel Management |  | 1695d? | 2006-01-02 | 2012-06-29 |  | 22d |  | finish no earlier than 2012-06-29 |
| 65 | 8.4 | Configuration Management |  | 327d? | 2011-03-31 | 2012-06-29 | 14, 28, 33, 47 | 22d |  | finish no earlier than 2012-06-29 |
| 66 | 8.5 | Documentation Control |  | 1695d? | 2006-01-02 | 2012-06-29 |  | 22d |  | finish no earlier than 2012-06-29 |
| 67 | 8.6 | Training & Travel Budget |  | 1695d? | 2006-01-02 | 2012-06-29 |  | 22d |  | finish no earlier than 2012-06-29 |
| 68 | 8.7 | Science Advisory Team Budget |  | 1695d? | 2006-01-02 | 2012-06-29 |  | 22d |  | finish no earlier than 2012-06-29 |
